# Installation BHS_2

Schedule from MS Project, 2018-10-01 to 2028-03-22, costs in €, A marks actual dates.
Selex ES

## Calendars

- Calendrier Geneve: Mon-Fri 09:00-13:00, 14:00-18:00; Sat-Sun off. Exceptions (off unless hours are given): 2019-04-19 to 2019-04-22 (Pâques 2019), 2019-05-30 (Ascension 2019), 2019-06-10 (Lundi de Pentecote), 2019-08-01 (Fete Nationale 2019), 2019-09-05 (Geneve Rapide), 2019-12-25 (Noel 2019), 2019-12-31 (Fete Republique), 2020-04-10 to 2020-04-13 (Paques 2020), 2020-05-21 (Ascension 2020), 2020-06-01 (Lundi de Pentecote), 2020-08-01 (Fete Nationale 2020), 2020-09-10 (Geneve rapide), 2020-12-24 to 2021-01-04 (Noel 2020), 2021-04-02 to 2021-04-05 (Paques 2021), 2021-05-13 (Ascension 2021), 2021-05-24 (Lundi de Pentecote), 2021-08-01 (Fete Nationale 2021), 2021-09-09 (Geneva Rapide 2021), 2021-12-24 to 2022-01-03 (Noel 2021), 2022-04-15 to 2022-04-18 (Paques 2022), 2022-05-26 (Ascension 2022), 2022-06-06 (Lundi de Pentecote), 2022-08-01 (Fete Nationale 2022), 2022-09-08 (Geneve Rapide 2022), 2022-12-24 to 2023-01-02 (Noel 2022).

## Resources

| Resource | Group | Rate |
| --- | --- | --- |
| Méca 1 | Méca | 80 |
| Méca 2 | Méca | 80 |
| Méca 3 | Méca | 80 |
| Méca 4 | Méca | 80 |
| Méca 5 | Méca | 80 |
| Méca 6 | Méca | 80 |
| Méca 7 | Méca | 80 |
| Méca 8 | Méca | 80 |
| Méca 9 | Méca | 80 |
| Méca 10 | Méca | 80 |
| Méca 11 | Méca | 80 |
| Méca 12 | Méca | 80 |
| Méca 13 | Méca | 80 |
| Méca 14 | Méca | 80 |
| Méca 15 | Méca | 80 |
| Méca 16 | Méca | 80 |
| Méca 17 | Méca | 80 |
| Méca 18 | Méca | 80 |
| Méca 19 | Méca | 80 |
| Méca 20 | Méca | 80 |
| Elec 1 | Elec | 80 |
| Elec 2 | Elec | 80 |
| Elec 3 | Elec | 80 |
| Elec 4 | Elec | 80 |
| Elec 5 | Elec | 80 |
| Elec 6 | Elec | 80 |
| Elec 7 | Elec | 80 |
| Elec 8 | Elec | 80 |
| Elec 9 | Elec | 80 |
| Elec 10 | Elec | 80 |
| Automaticien 1 | Automaticien | 100 |
| Automaticien 2 | Automaticien | 100 |
| Automaticien 3 | Automaticien | 100 |
| Automaticien 4 | Automaticien | 100 |
| Automaticien 5 | Automaticien | 100 |
| Automaticien 6 | Automaticien | 100 |
| Automaticien 7 | Automaticien | 100 |
| Automaticien 8 | Automaticien | 100 |
| Automaticien 9 | Automaticien | 100 |
| Automaticien 10 | Automaticien | 100 |

## Schedule

| ID | WBS | Task | Type | Duration | Start | Finish | Predecessors | Total slack | Constraint | Text12 | Text21 | Text29 |
| --- | --- | --- | --- | --- | --- | --- | --- | --- | --- | --- | --- | --- |
| 1 | 1 | **Planning de synthèse** |  | 1065d | 2018-10-01 | 2022-12-23 |  | 0d |  | Blank | NA | NA |
| 2 | 1.1 | **Lignes "Arrivée"** |  | 1065d | 2018-10-01 | 2022-12-23 |  | 0d |  | Blank | NA | NA |
| 3 | 1.1.1 | **Ligne 9 - Skis** |  | 1065d | 2018-10-01 | 2022-12-23 |  | 0d |  | Blank | NA | NA |
| 4 | 1.1.1.1 | **Exploitation avant travaux** |  | 254d | 2018-10-01 | 2019-09-30 |  | 0d |  | Blank |  |  |
| 5 | 1.1.1.1.1 | Début initial | milestone | 0d | 2018-10-01 | 2018-10-01 |  | 0d | start no earlier than 2018-10-01 | Blank |  |  |
| 6 | 1.1.1.1.2 | Fin Exploitation avant travaux | milestone | 0d | 2019-09-30 | 2019-09-30 | 533 | 0d |  | Blank |  |  |
| 7 | 1.1.1.2 | **Démontage + Remontage + Mise en service** |  | 58d | 2019-10-01 | 2019-12-19 |  | 0d |  | Blank |  |  |
| 8 | 1.1.1.2.1 | Début Travaux | milestone | 0d | 2019-10-01 | 2019-10-01 | 534SS | 0d | start no earlier than 2019-01-01 | Blank |  |  |
| 9 | 1.1.1.2.2 | Fin Mise en service | milestone | 0d | 2019-12-19 | 2019-12-19 | 550 | 0d |  | Blank |  |  |
| 10 | 1.1.1.3 | **Exploitation définitive** |  | 752d | 2019-12-20 | 2022-12-23 |  | 0d |  | Blank |  |  |
| 11 | 1.1.1.3.1 | Début exploitation |  | 1d | 2019-12-20 | 2019-12-20 | 9 | 0d | start no earlier than 2019-01-01 | Blank |  |  |
| 12 | 1.1.1.3.2 | Fin | milestone | 0d | 2022-12-23 | 2022-12-23 |  | 0d | start no earlier than 2022-12-23 | Blank |  |  |
| 13 | 1.1.2 | **Ligne Spécial** |  | 339d | 2018-10-01 | 2020-01-28 |  | 0d |  | Blank | NA | NA |
| 14 | 1.1.2.1 | **Exploitation avant travaux** |  | 333d | 2018-10-01 | 2020-01-20 |  | 0d |  | Blank |  |  |
| 15 | 1.1.2.1.1 | Début initial | milestone | 0d | 2018-10-01 | 2018-10-01 |  | 0d | start no earlier than 2018-10-01 | Blank |  |  |
| 16 | 1.1.2.1.2 | Fin Exploitation avant travaux | milestone | 0d | 2020-01-20 | 2020-01-20 | 638 | 0d |  | Blank |  |  |
| 17 | 1.1.2.2 | **Démontage** |  | 7d | 2020-01-20 | 2020-01-28 |  | 0d |  | Blank |  |  |
| 18 | 1.1.2.2.1 | Début Travaux | milestone | 0d | 2020-01-20 | 2020-01-20 | 639SS | 0d | start no earlier than 2019-01-01 | Blank |  |  |
| 19 | 1.1.2.2.2 | Fin des Travaux | milestone | 0d | 2020-01-28 | 2020-01-28 | 640 | 0d |  | Blank |  |  |
| 20 | 1.1.3 | **Ligne C7 et carrousel 7** |  | 1065d | 2018-10-01 | 2022-12-23 |  | 0d |  | Blank | NA | NA |
| 21 | 1.1.3.1 | **Exploitation avant travaux** |  | 255d | 2018-10-01 | 2019-09-30 |  | 0d |  | Blank |  |  |
| 22 | 1.1.3.1.1 | Début initial | milestone | 0d | 2018-10-01 | 2018-10-01 |  | 0d | start no earlier than 2018-10-01 | Blank |  |  |
| 23 | 1.1.3.1.2 | Fin Exploitation avant travaux | milestone | 0d | 2019-09-30 | 2019-09-30 | 552 | 0d |  | Blank |  |  |
| 24 | 1.1.3.2 | **Démontage + Remontage C7 + Mise en service C7 et carrousel 7** |  | 77d | 2019-10-01 | 2020-01-17 |  | 0d |  | Blank |  |  |
| 25 | 1.1.3.2.1 | Début Travaux | milestone | 0d | 2019-10-01 | 2019-10-01 | 553SS | 0d | start no earlier than 2019-01-01 | Blank |  |  |
| 26 | 1.1.3.2.2 | Fin Mise en service | milestone | 0d | 2020-01-17 | 2020-01-17 | 604 | 0d |  | Blank |  |  |

| ID | WBS | Task | Type | Duration | Start | Finish | Predecessors | Total slack | Constraint | Text12 | Text21 | Text29 |
| --- | --- | --- | --- | --- | --- | --- | --- | --- | --- | --- | --- | --- |
| 27 | 1.1.3.3 | **Exploitation définitive** |  | 733d | 2020-01-20 | 2022-12-23 |  | 0d |  | Blank |  |  |
| 28 | 1.1.3.3.1 | Début exploitation |  | 1d | 2020-01-20 | 2020-01-20 | 26, 36 | 0d | start no earlier than 2019-01-01 | Blank |  |  |
| 29 | 1.1.3.3.2 | Fin | milestone | 0d | 2022-12-23 | 2022-12-23 |  | 0d | start no earlier than 2022-12-23 | Blank |  |  |
| 30 | 1.1.4 | **Ligne C8 et carrousel 8** |  | 266d | 2018-10-01 | 2019-10-15 |  | 0d |  | Blank | NA | NA |
| 31 | 1.1.4.1 | **Exploitation avant travaux** |  | 255d | 2018-10-01 | 2019-09-30 |  | 0d |  | Blank |  |  |
| 32 | 1.1.4.1.1 | Début initial | milestone | 0d | 2018-10-01 | 2018-10-01 |  | 0d | start no earlier than 2018-10-01 | Blank |  |  |
| 33 | 1.1.4.1.2 | Fin Exploitation avant travaux | milestone | 0d | 2019-09-30 | 2019-09-30 | 552 | 0d |  | Blank |  |  |
| 34 | 1.1.4.2 | **Démontage** |  | 1d | 2019-10-14 | 2019-10-15 |  | 0d |  | Blank |  |  |
| 35 | 1.1.4.2.1 | Début Travaux | milestone | 0d | 2019-10-14 | 2019-10-14 | 553SS | 0d | start no earlier than 2019-10-14 | Blank |  |  |
| 36 | 1.1.4.2.2 | Fin Travaux | milestone | 0d | 2019-10-15 | 2019-10-15 | 559 | 66d |  | Blank |  |  |
| 37 | 1.1.5 | **Ligne gare** |  | 255d | 2018-10-01 | 2019-10-01 |  | 0d |  | Blank | NA | NA |
| 38 | 1.1.5.1 | **Exploitation avant travaux** |  | 254d | 2018-10-01 | 2019-09-30 |  | 0d |  | Blank |  |  |
| 39 | 1.1.5.1.1 | Début initial | milestone | 0d | 2018-10-01 | 2018-10-01 |  | 0d | start no earlier than 2018-10-01 | Blank |  |  |
| 40 | 1.1.5.1.2 | Fin Exploitation avant travaux | milestone | 0d | 2019-09-30 | 2019-09-30 | 564 | 0d |  | Blank |  |  |
| 41 | 1.1.5.2 | **Démontage** |  | 0d | 2019-10-01 | 2019-10-01 |  | 0d |  | Blank |  |  |
| 42 | 1.1.5.2.1 | Début Travaux | milestone | 0d | 2019-10-01 | 2019-10-01 | 565SS | 0d | start no earlier than 2019-01-01 | Blank |  |  |
| 43 | 1.1.6 | **Ligne Transfert et Ligne TR1** |  | 1065d | 2018-10-01 | 2022-12-23 |  | 0d |  | Blank | NA | NA |
| 44 | 1.1.6.1 | **Exploitation avant travaux** |  | 262d | 2018-10-01 | 2019-10-09 |  | 0d |  | Blank |  |  |
| 45 | 1.1.6.1.1 | Début initial | milestone | 0d | 2018-10-01 | 2018-10-01 |  | 0d | start no earlier than 2018-10-01 | Blank |  |  |
| 46 | 1.1.6.1.2 | Fin Exploitation avant travaux | milestone | 0d | 2019-10-09 | 2019-10-09 | 573 | 0d |  | Blank |  |  |
| 47 | 1.1.6.2 | **Démontage + Remontage + Mise en service** |  | 34d | 2019-10-10 | 2019-11-26 |  | 0d |  | Blank |  |  |
| 48 | 1.1.6.2.1 | Début Travaux | milestone | 0d | 2019-10-10 | 2019-10-10 | 574SS | 0d | start no earlier than 2019-01-01 | Blank |  |  |
| 49 | 1.1.6.2.2 | Fin Mise en service | milestone | 0d | 2019-11-26 | 2019-11-26 | 587 | 0d |  | Blank |  |  |
| 50 | 1.1.6.3 | **Exploitation définitive** |  | 769d | 2019-11-27 | 2022-12-23 |  | 0d |  | Blank |  |  |
| 51 | 1.1.6.3.1 | Début exploitation |  | 1d | 2019-11-27 | 2019-11-27 | 49 | 0d | start no earlier than 2019-01-01 | Blank |  |  |
| 52 | 1.1.6.3.2 | Fin | milestone | 0d | 2022-12-23 | 2022-12-23 |  | 0d | start no earlier than 2022-12-23 | Blank |  |  |

| ID | WBS | Task | Type | Duration | Start | Finish | Predecessors | Total slack | Constraint | Text12 | Text21 | Text29 |
| --- | --- | --- | --- | --- | --- | --- | --- | --- | --- | --- | --- | --- |
| 53 | 1.1.7 | **Ligne C6 et carrousel 6** |  | 1065d | 2018-10-01 | 2022-12-23 |  | 0d |  | Blank | NA | NA |
| 54 | 1.1.7.1 | **Exploitation avant travaux** |  | 338d | 2018-10-01 | 2020-01-27 |  | 0d |  | Blank |  |  |
| 55 | 1.1.7.1.1 | Début initial | milestone | 0d | 2018-10-01 | 2018-10-01 |  | 0d | start no earlier than 2018-10-01 | Blank |  |  |
| 56 | 1.1.7.1.2 | Fin Exploitation avant travaux | milestone | 0d | 2020-01-27 | 2020-01-27 | 644 | 0d |  | Blank |  |  |
| 57 | 1.1.7.2 | **Démontage + Remontage C6 + Mise en service C6 et carrousel 6** |  | 58d | 2020-01-31 | 2020-04-23 |  | 0d |  | Blank |  |  |
| 58 | 1.1.7.2.1 | Début Travaux | milestone | 0d | 2020-01-31 | 2020-01-31 | 649SS | 0d | start no earlier than 2019-01-01 | Blank |  |  |
| 59 | 1.1.7.2.2 | Fin Mise en service | milestone | 0d | 2020-04-23 | 2020-04-23 | 666 | 0d |  | Blank |  |  |
| 60 | 1.1.7.3 | **Exploitation définitive** |  | 666d | 2020-04-24 | 2022-12-23 |  | 0d |  | Blank |  |  |
| 61 | 1.1.7.3.1 | Début exploitation |  | 1d | 2020-04-24 | 2020-04-24 | 59 | 0d | start no earlier than 2019-01-01 | Blank |  |  |
| 62 | 1.1.7.3.2 | Fin | milestone | 0d | 2022-12-23 | 2022-12-23 |  | 0d | start no earlier than 2022-12-23 | Blank |  |  |
| 63 | 1.1.8 | **Ligne C5** |  | 1065d | 2018-10-01 | 2022-12-23 |  | 0d |  | Blank | NA | NA |
| 64 | 1.1.8.1 | **Exploitation avant travaux** |  | 399d | 2018-10-01 | 2020-04-23 |  | 0d |  | Blank |  |  |
| 65 | 1.1.8.1.1 | Début initial | milestone | 0d | 2018-10-01 | 2018-10-01 |  | 0d | start no earlier than 2018-10-01 | Blank |  |  |
| 66 | 1.1.8.1.2 | Fin Exploitation avant travaux | milestone | 0d | 2020-04-23 | 2020-04-23 | 691 | 0d |  | Blank |  |  |
| 67 | 1.1.8.2 | **Démontage + Remontage C5 + Mise en service C5** |  | 37d | 2020-05-01 | 2020-06-24 |  | 0d |  | Blank |  |  |
| 68 | 1.1.8.2.1 | Début Travaux | milestone | 0d | 2020-05-01 | 2020-05-01 | 694SS | 0d | start no earlier than 2019-01-01 | Blank |  |  |
| 69 | 1.1.8.2.2 | Fin Mise en service | milestone | 0d | 2020-06-24 | 2020-06-24 | 705 | 0d |  | Blank |  |  |
| 70 | 1.1.8.3 | **Exploitation définitive** |  | 624d | 2020-06-25 | 2022-12-23 |  | 0d |  | Blank |  |  |
| 71 | 1.1.8.3.1 | Début exploitation |  | 1d | 2020-06-25 | 2020-06-25 | 69 | 0d | start no earlier than 2019-01-01 | Blank |  |  |
| 72 | 1.1.8.3.2 | Fin | milestone | 0d | 2022-12-23 | 2022-12-23 |  | 0d | start no earlier than 2022-12-23 | Blank |  |  |
| 73 | 1.1.9 | **Ligne C4** |  | 1065d | 2018-10-01 | 2022-12-23 |  | 0d |  | Blank | NA | NA |
| 74 | 1.1.9.1 | **Exploitation avant travaux** |  | 441d | 2018-10-01 | 2020-06-24 |  | 0d |  | Blank |  |  |
| 75 | 1.1.9.1.1 | Début initial | milestone | 0d | 2018-10-01 | 2018-10-01 |  | 0d | start no earlier than 2018-10-01 | Blank |  |  |
| 76 | 1.1.9.1.2 | Fin Exploitation avant travaux | milestone | 0d | 2020-06-24 | 2020-06-24 | 723 | 0d |  | Blank |  |  |

| ID | WBS | Task | Type | Duration | Start | Finish | Predecessors | Total slack | Constraint | Text12 | Text21 | Text29 |
| --- | --- | --- | --- | --- | --- | --- | --- | --- | --- | --- | --- | --- |
| 77 | 1.1.9.2 | **Démontage + Remontage C4 + Mise en service C4** |  | 44d | 2020-06-25 | 2020-08-25 |  | 0d |  | Blank |  |  |
| 78 | 1.1.9.2.1 | Début Travaux | milestone | 0d | 2020-06-25 | 2020-06-25 | 724SS | 0d | start no earlier than 2019-01-01 | Blank |  |  |
| 79 | 1.1.9.2.2 | Fin Mise en service | milestone | 0d | 2020-08-25 | 2020-08-25 | 736 | 0d |  | Blank |  |  |
| 80 | 1.1.9.3 | **Exploitation définitive** |  | 580d | 2020-08-26 | 2022-12-23 |  | 0d |  | Blank |  |  |
| 81 | 1.1.9.3.1 | Début exploitation |  | 1d | 2020-08-26 | 2020-08-26 | 79 | 0d | start no earlier than 2019-01-01 | Blank |  |  |
| 82 | 1.1.9.3.2 | Fin | milestone | 0d | 2022-12-23 | 2022-12-23 |  | 0d | start no earlier than 2022-12-23 | Blank |  |  |
| 83 | 1.1.10 | **Ligne Secteur France** |  | 609d | 2020-07-16 | 2022-12-23 |  | 0d |  | Blank | NA | NA |
| 84 | 1.1.10.1 | **Exploitation avant travaux** |  | 0d | 2020-07-16 | 2020-07-16 |  | 0d |  | Blank |  |  |
| 85 | 1.1.10.1.1 | Début initial | milestone | 0d | 2020-07-16 | 2020-07-16 | 722 | 0d | start no earlier than 2018-10-01 | Blank |  |  |
| 86 | 1.1.10.1.2 | Fin Exploitation avant travaux | milestone | 0d | 2020-07-16 | 2020-07-16 | 792 | 0d |  | Blank |  |  |
| 87 | 1.1.10.2 | **Démontage + Remontage SF + Mise en service SF** |  | 60d | 2020-07-16 | 2020-10-08 |  | 0d |  | Blank |  |  |
| 88 | 1.1.10.2.1 | Début Travaux | milestone | 0d | 2020-07-16 | 2020-07-16 | 793SS | 0d | start no earlier than 2019-01-01 | Blank |  |  |
| 89 | 1.1.10.2.2 | Fin Mise en service | milestone | 0d | 2020-10-08 | 2020-10-08 | 805 | 0d |  | Blank |  |  |
| 90 | 1.1.10.3 | **Exploitation définitive** |  | 549d | 2020-10-09 | 2022-12-23 |  | 0d |  | Blank |  |  |
| 91 | 1.1.10.3.1 | Début exploitation |  | 1d | 2020-10-09 | 2020-10-09 | 89 | 0d | start no earlier than 2019-01-01 | Blank |  |  |
| 92 | 1.1.10.3.2 | Fin | milestone | 0d | 2022-12-23 | 2022-12-23 |  | 0d | start no earlier than 2022-12-23 | Blank |  |  |
| 93 | 1.1.11 | **Ligne C3 + Transfert 3** |  | 1065d | 2018-10-01 | 2022-12-23 |  | 0d |  | Blank | NA | NA |
| 94 | 1.1.11.1 | **Exploitation avant travaux** |  | 485d | 2018-10-01 | 2020-08-25 |  | 0d |  | Blank |  |  |
| 95 | 1.1.11.1.1 | Début initial | milestone | 0d | 2018-10-01 | 2018-10-01 |  | 0d | start no earlier than 2018-10-01 | Blank |  |  |
| 96 | 1.1.11.1.2 | Fin Exploitation avant travaux | milestone | 0d | 2020-08-25 | 2020-08-25 | 771 | 0d |  | Blank |  |  |
| 97 | 1.1.11.2 | **Démontage + Remontage C3 + Mise en service C3 + Transfert 3** |  | 49d | 2020-08-26 | 2020-11-03 |  | 0d |  | Blank |  |  |
| 98 | 1.1.11.2.1 | Début Travaux | milestone | 0d | 2020-08-26 | 2020-08-26 | 772SS | 0d | start no earlier than 2019-01-01 | Blank |  |  |
| 99 | 1.1.11.2.2 | Fin Mise en service | milestone | 0d | 2020-11-03 | 2020-11-03 | 785 | 0d |  | Blank |  |  |
| 100 | 1.1.11.3 | **Exploitation définitive** |  | 531d | 2020-11-04 | 2022-12-23 |  | 0d |  | Blank |  |  |
| 101 | 1.1.11.3.1 | Début exploitation |  | 1d | 2020-11-04 | 2020-11-04 | 99 | 0d | start no earlier than 2019-01-01 | Blank |  |  |
| 102 | 1.1.11.3.2 | Fin | milestone | 0d | 2022-12-23 | 2022-12-23 |  | 0d | start no earlier than 2022-12-23 | Blank |  |  |

| ID | WBS | Task | Type | Duration | Start | Finish | Predecessors | Total slack | Constraint | Text12 | Text21 | Text29 |
| --- | --- | --- | --- | --- | --- | --- | --- | --- | --- | --- | --- | --- |
| 103 | 1.1.12 | **Ligne C2 + Transfert 2** |  | 1065d | 2018-10-01 | 2022-12-23 |  | 0d |  | Blank | NA | NA |
| 104 | 1.1.12.1 | **Exploitation avant travaux** |  | 534d | 2018-10-01 | 2020-11-03 |  | 0d |  | Blank |  |  |
| 105 | 1.1.12.1.1 | Début initial | milestone | 0d | 2018-10-01 | 2018-10-01 |  | 0d | start no earlier than 2018-10-01 | Blank |  |  |
| 106 | 1.1.12.1.2 | Fin Exploitation avant travaux | milestone | 0d | 2020-11-03 | 2020-11-03 | 818 | 0d |  | Blank |  |  |
| 107 | 1.1.12.2 | **Démontage + Remontage C2 + Mise en service C2 + Transfert 2** |  | 45d | 2020-11-04 | 2021-01-15 |  | 0d |  | Blank |  |  |
| 108 | 1.1.12.2.1 | Début Travaux | milestone | 0d | 2020-11-04 | 2020-11-04 | 819SS | 0d | start no earlier than 2019-01-01 | Blank |  |  |
| 109 | 1.1.12.2.2 | Fin Mise en service | milestone | 0d | 2021-01-15 | 2021-01-15 | 832 | 0d |  | Blank |  |  |
| 110 | 1.1.12.3 | **Exploitation définitive** |  | 486d | 2021-01-18 | 2022-12-23 |  | 0d |  | Blank |  |  |
| 111 | 1.1.12.3.1 | Début exploitation |  | 1d | 2021-01-18 | 2021-01-18 | 109 | 0d | start no earlier than 2019-01-01 | Blank |  |  |
| 112 | 1.1.12.3.2 | Fin | milestone | 0d | 2022-12-23 | 2022-12-23 |  | 0d | start no earlier than 2022-12-23 | Blank |  |  |
| 113 | 1.1.13 | **Ligne C1** |  | 1065d | 2018-10-01 | 2022-12-23 |  | 0d |  | Blank | NA | NA |
| 114 | 1.1.13.1 | **Exploitation avant travaux** |  | 534d | 2018-10-01 | 2020-11-03 |  | 0d |  | Blank |  |  |
| 115 | 1.1.13.1.1 | Début initial | milestone | 0d | 2018-10-01 | 2018-10-01 |  | 0d | start no earlier than 2018-10-01 | Blank |  |  |
| 116 | 1.1.13.1.2 | Fin Exploitation avant travaux | milestone | 0d | 2020-11-03 | 2020-11-03 | 833 | 0d |  | Blank |  |  |
| 117 | 1.1.13.2 | **Démontage + Remontage C1 + Mise en service C1** |  | 46d | 2020-11-04 | 2021-01-18 |  | 0d |  | Blank |  |  |
| 118 | 1.1.13.2.1 | Début Travaux | milestone | 0d | 2020-11-04 | 2020-11-04 | 834SS | 0d | start no earlier than 2019-01-01 | Blank |  |  |
| 119 | 1.1.13.2.2 | Fin Mise en service | milestone | 0d | 2021-01-18 | 2021-01-18 | 847 | 0d |  | Blank |  |  |
| 120 | 1.1.13.3 | **Exploitation définitive** |  | 485d | 2021-01-19 | 2022-12-23 |  | 0d |  | Blank |  |  |
| 121 | 1.1.13.3.1 | Début exploitation |  | 1d | 2021-01-19 | 2021-01-19 | 119 | 0d | start no earlier than 2019-01-01 | Blank |  |  |
| 122 | 1.1.13.3.2 | Fin | milestone | 0d | 2022-12-23 | 2022-12-23 |  | 0d | start no earlier than 2022-12-23 | Blank |  |  |
| 123 | 1.2 | **Lignes provisoires** |  | 420d | 2019-10-01 | 2021-06-04 |  | 0d |  | Blank | NA | NA |
| 124 | 1.2.1 | **Ligne 900** |  | 397d | 2019-11-01 | 2021-06-04 |  | 0d |  | Blank | NA | NA |
| 125 | 1.2.1.1 | **Montage + Mise en service** |  | 36d | 2019-11-01 | 2019-12-20 |  | 0d |  | Blank |  |  |
| 126 | 1.2.1.1.1 | Début Travaux | milestone | 0d | 2019-11-01 | 2019-11-01 | 583SS | 0d | start no earlier than 2019-01-01 | Blank |  |  |
| 127 | 1.2.1.1.2 | Fin Mise en service | milestone | 0d | 2019-12-20 | 2019-12-20 | 584, 591 | 0d |  | Blank |  |  |

| ID | WBS | Task | Type | Duration | Start | Finish | Predecessors | Total slack | Constraint | Text12 | Text21 | Text29 |
| --- | --- | --- | --- | --- | --- | --- | --- | --- | --- | --- | --- | --- |
| 128 | 1.2.1.2 | **Exploitation provisoire** |  | 343d | 2019-12-23 | 2021-05-10 |  | 0d |  | Blank |  |  |
| 129 | 1.2.1.2.1 | Début exploitation |  | 1d | 2019-12-23 | 2019-12-23 | 127 | 0d | start no earlier than 2019-01-01 | Blank |  |  |
| 130 | 1.2.1.2.2 | Fin | milestone | 0d | 2021-05-10 | 2021-05-10 | 898SS | 0d |  | Blank |  |  |
| 131 | 1.2.1.3 | **Démontage** |  | 18d | 2021-05-10 | 2021-06-04 |  | 0d |  | Blank |  |  |
| 132 | 1.2.1.3.1 | Début Démontage | milestone | 0d | 2021-05-10 | 2021-05-10 | 898SS | 0d | start no earlier than 2019-01-01 | Blank |  |  |
| 133 | 1.2.1.3.2 | Fin Démontage | milestone | 0d | 2021-06-04 | 2021-06-04 | 898 | 0d |  | Blank |  |  |
| 134 | 1.2.2 | **Ligne HF4000** |  | 404d | 2019-10-01 | 2021-05-11 |  | 0d |  | Blank | NA | NA |
| 135 | 1.2.2.1 | **Montage + Mise en service** |  | 73d | 2019-10-01 | 2020-01-13 |  | 0d |  | Blank |  |  |
| 136 | 1.2.2.1.1 | Début Travaux | milestone | 0d | 2019-10-01 | 2019-10-01 | 566SS | 0d | start no earlier than 2019-01-01 | Blank |  |  |
| 137 | 1.2.2.1.2 | Fin Mise en service | milestone | 0d | 2020-01-13 | 2020-01-13 | 572 | 0d |  | Blank |  |  |
| 138 | 1.2.2.2 | **Exploitation provisoire** |  | 331d | 2020-01-14 | 2021-05-11 |  | 0d |  | Blank |  |  |
| 139 | 1.2.2.2.1 | Début exploitation |  | 1d | 2020-01-14 | 2020-01-14 | 572 | 0d | start no earlier than 2019-01-01 | Blank |  |  |
| 140 | 1.2.2.2.2 | Fin | milestone | 0d | 2021-05-11 | 2021-05-11 | 895 | 0d |  | Blank |  |  |
| 141 | 1.2.2.3 | **Démontage** |  | 2d | 2021-05-10 | 2021-05-11 |  | 0d |  | Blank |  |  |
| 142 | 1.2.2.3.1 | Début Démontage | milestone | 0d | 2021-05-10 | 2021-05-10 | 895SS | 0d | start no earlier than 2019-01-01 | Blank |  |  |
| 143 | 1.2.2.3.2 | Fin Démontage | milestone | 0d | 2021-05-11 | 2021-05-11 | 895 | 0d |  | Blank |  |  |
| 144 | 1.3 | **Lignes "Départ"** |  | 1065d | 2018-10-01 | 2022-12-23 |  | 0d |  | Blank | NA | NA |
| 145 | 1.3.1 | **Ligne HF 4000** |  | 1065d | 2018-10-01 | 2022-12-23 |  | 0d |  | Blank | NA | NA |
| 146 | 1.3.1.1 | **Exploitation avant travaux** |  | 254d | 2018-10-01 | 2019-09-30 |  | 0d |  | Blank |  |  |
| 147 | 1.3.1.1.1 | Début initial | milestone | 0d | 2018-10-01 | 2018-10-01 |  | 0d | start no earlier than 2018-10-01 | Blank |  |  |
| 148 | 1.3.1.1.2 | Fin Exploitation avant travaux | milestone | 0d | 2019-09-30 | 2019-09-30 | 564 | 0d |  | Blank |  |  |
| 149 | 1.3.1.2 | **Démontage + Remontage + Mise en service** |  | 73d | 2019-10-01 | 2020-01-13 |  | 0d |  | Blank |  |  |
| 150 | 1.3.1.2.1 | Début Travaux | milestone | 0d | 2019-10-01 | 2019-10-01 | 566SS | 0d | start no earlier than 2019-01-01 | Blank |  |  |
| 151 | 1.3.1.2.2 | Fin Mise en service | milestone | 0d | 2020-01-13 | 2020-01-13 | 572 | 0d |  | Blank |  |  |

| ID | WBS | Task | Type | Duration | Start | Finish | Predecessors | Total slack | Constraint | Text12 | Text21 | Text29 |
| --- | --- | --- | --- | --- | --- | --- | --- | --- | --- | --- | --- | --- |
| 152 | 1.3.1.3 | **Exploitation définitive** |  | 737d | 2020-01-14 | 2022-12-23 |  | 0d |  | Blank |  |  |
| 153 | 1.3.1.3.1 | Début exploitation |  | 1d | 2020-01-14 | 2020-01-14 | 151 | 0d | start no earlier than 2019-01-01 | Blank |  |  |
| 154 | 1.3.1.3.2 | Fin | milestone | 0d | 2022-12-23 | 2022-12-23 |  | 0d | start no earlier than 2022-12-23 | Blank |  |  |
| 155 | 1.3.2 | **Ligne BS1** |  | 999d | 2019-01-01 | 2022-12-23 |  | 0d |  | Blank | NA | NA |
| 156 | 1.3.2.1 | **Montage** |  | 351d | 2019-01-01 | 2020-05-19 |  | 0d |  | Blank |  |  |
| 157 | 1.3.2.1.1 | Début Travaux | milestone | 0d | 2019-01-01 | 2019-01-01 |  | 0d | start no earlier than 2019-01-01 | Blank |  |  |
| 158 | 1.3.2.1.2 | Fin Mise en service | milestone | 0d | 2020-05-19 | 2020-05-19 | 627 | 0d |  | Blank |  |  |
| 159 | 1.3.2.2 | **Exploitation définitive** |  | 648d | 2020-05-20 | 2022-12-23 |  | 0d |  | Blank |  |  |
| 160 | 1.3.2.2.1 | Début exploitation |  | 1d | 2020-05-20 | 2020-05-20 | 158 | 0d | start no earlier than 2019-01-01 | Blank |  |  |
| 161 | 1.3.2.2.2 | Fin | milestone | 0d | 2022-12-23 | 2022-12-23 |  | 0d | start no earlier than 2022-12-23 | Blank |  |  |
| 162 | 1.3.3 | **SAS Lausanne** |  | 422d | 2018-10-01 | 2020-05-27 |  | 0d |  | Blank | NA | NA |
| 163 | 1.3.3.1 | **Exploitation avant travaux** |  | 417d | 2018-10-01 | 2020-05-19 |  | 0d |  | Blank |  |  |
| 164 | 1.3.3.1.1 | Début initial | milestone | 0d | 2018-10-01 | 2018-10-01 |  | 0d | start no earlier than 2018-10-01 | Blank |  |  |
| 165 | 1.3.3.1.2 | Fin Exploitation avant travaux | milestone | 0d | 2020-05-19 | 2020-05-19 | 630 | 0d |  | Blank |  |  |
| 166 | 1.3.3.2 | **Démontage** |  | 0d | 2020-05-27 | 2020-05-27 |  | 0d |  | Blank |  |  |
| 167 | 1.3.3.2.1 | Début Travaux | milestone | 0d | 2020-05-27 | 2020-05-27 | 631 | 0d | start no earlier than 2019-01-01 | Blank |  |  |
| 168 | 1.3.4 | **Ligne HBS1** |  | 583d | 2020-08-21 | 2022-12-23 |  | 0d |  | Blank | NA | NA |
| 169 | 1.3.4.1 | **Montage** |  | 216d | 2020-08-21 | 2021-07-07 |  | 0d |  | Blank |  |  |
| 170 | 1.3.4.1.1 | Début Travaux | milestone | 0d | 2020-08-21 | 2020-08-21 | 744SS | 0d | start no earlier than 2019-01-01 | Blank |  |  |
| 171 | 1.3.4.1.2 | Fin Mise en service | milestone | 0d | 2021-07-07 | 2021-07-07 | 929 | 0d |  | Blank |  |  |
| 172 | 1.3.4.2 | **Exploitation définitive** |  | 367d | 2021-07-08 | 2022-12-23 |  | 0d |  | Blank |  |  |
| 173 | 1.3.4.2.1 | Début exploitation |  | 1d | 2021-07-08 | 2021-07-08 | 171 | 0d | start no earlier than 2019-01-01 | Blank |  |  |
| 174 | 1.3.4.2.2 | Fin | milestone | 0d | 2022-12-23 | 2022-12-23 |  | 0d | start no earlier than 2022-12-23 | Blank |  |  |
| 175 | 1.3.5 | **Ligne HBS2** |  | 775d | 2019-11-19 | 2022-12-23 |  | 0d |  | Blank | NA | NA |
| 176 | 1.3.5.1 | **Montage** |  | 325d | 2019-11-19 | 2021-03-08 |  | 0d |  | Blank |  |  |
| 177 | 1.3.5.1.1 | Début Travaux | milestone | 0d | 2019-11-19 | 2019-11-19 | 606SS | 0d | start no earlier than 2019-01-01 | Blank |  |  |
| 178 | 1.3.5.1.2 | Fin Mise en service | milestone | 0d | 2021-03-08 | 2021-03-08 | 892, 893 | 0d |  | Blank |  |  |

| ID | WBS | Task | Type | Duration | Start | Finish | Predecessors | Total slack | Constraint | Text12 | Text21 | Text29 |
| --- | --- | --- | --- | --- | --- | --- | --- | --- | --- | --- | --- | --- |
| 179 | 1.3.5.2 | **Exploitation définitive** |  | 450d | 2021-03-09 | 2022-12-23 |  | 0d |  | Blank |  |  |
| 180 | 1.3.5.2.1 | Début exploitation |  | 1d | 2021-03-09 | 2021-03-09 | 178 | 0d | start no earlier than 2019-01-01 | Blank |  |  |
| 181 | 1.3.5.2.2 | Fin | milestone | 0d | 2022-12-23 | 2022-12-23 |  | 0d | start no earlier than 2022-12-23 | Blank |  |  |
| 182 | 1.3.6 | **Ligne HBS3** |  | 680d | 2020-04-02 | 2022-12-23 |  | 0d |  | Blank | NA | NA |
| 183 | 1.3.6.1 | **Montage** |  | 264d | 2020-04-02 | 2021-04-27 |  | 0d |  | Blank |  |  |
| 184 | 1.3.6.1.1 | Début Travaux | milestone | 0d | 2020-04-02 | 2020-04-02 | 633SS | 0d | start no earlier than 2019-01-01 | Blank |  |  |
| 185 | 1.3.6.1.2 | Fin Mise en service | milestone | 0d | 2021-04-27 | 2021-04-27 | 902 | 0d |  | Blank |  |  |
| 186 | 1.3.6.2 | **Exploitation définitive** |  | 416d | 2021-04-28 | 2022-12-23 |  | 0d |  | Blank |  |  |
| 187 | 1.3.6.2.1 | Début exploitation |  | 1d | 2021-04-28 | 2021-04-28 | 185 | 0d | start no earlier than 2019-01-01 | Blank |  |  |
| 188 | 1.3.6.2.2 | Fin | milestone | 0d | 2022-12-23 | 2022-12-23 |  | 0d | start no earlier than 2022-12-23 | Blank |  |  |
| 189 | 1.3.7 | **Ligne HBS4** |  | 581d | 2020-08-25 | 2022-12-23 |  | 0d |  | Blank | NA | NA |
| 190 | 1.3.7.1 | **Montage** |  | 165d | 2020-08-25 | 2021-04-27 |  | 0d |  | Blank |  |  |
| 191 | 1.3.7.1.1 | Début Travaux | milestone | 0d | 2020-08-25 | 2020-08-25 | 789SS | 0d | start no earlier than 2019-01-01 | Blank |  |  |
| 192 | 1.3.7.1.2 | Fin Mise en service | milestone | 0d | 2021-04-27 | 2021-04-27 | 902 | 0d |  | Blank |  |  |
| 193 | 1.3.7.2 | **Exploitation définitive** |  | 416d | 2021-04-28 | 2022-12-23 |  | 0d |  | Blank |  |  |
| 194 | 1.3.7.2.1 | Début exploitation |  | 1d | 2021-04-28 | 2021-04-28 | 192 | 0d | start no earlier than 2019-01-01 | Blank |  |  |
| 195 | 1.3.7.2.2 | Fin | milestone | 0d | 2022-12-23 | 2022-12-23 |  | 0d | start no earlier than 2022-12-23 | Blank |  |  |
| 196 | 1.3.8 | **Ligne HBS5** |  | 657d | 2020-05-07 | 2022-12-23 |  | 0d |  | Blank | NA | NA |
| 197 | 1.3.8.1 | **Montage** |  | 359d | 2020-05-07 | 2021-10-13 |  | 0d |  | Blank |  |  |
| 198 | 1.3.8.1.1 | Début Travaux | milestone | 0d | 2020-05-07 | 2020-05-07 | 697SS | 0d | start no earlier than 2019-01-01 | Blank |  |  |
| 199 | 1.3.8.1.2 | Fin Mise en service | milestone | 0d | 2021-10-13 | 2021-10-13 | 959 | 0d |  | Blank |  |  |
| 200 | 1.3.8.2 | **Exploitation définitive** |  | 298d | 2021-10-14 | 2022-12-23 |  | 0d |  | Blank |  |  |
| 201 | 1.3.8.2.1 | Début exploitation |  | 1d | 2021-10-14 | 2021-10-14 | 199 | 0d | start no earlier than 2019-01-01 | Blank |  |  |
| 202 | 1.3.8.2.2 | Fin | milestone | 0d | 2022-12-23 | 2022-12-23 |  | 0d | start no earlier than 2022-12-23 | Blank |  |  |

| ID | WBS | Task | Type | Duration | Start | Finish | Predecessors | Total slack | Constraint | Text12 | Text21 | Text29 |
| --- | --- | --- | --- | --- | --- | --- | --- | --- | --- | --- | --- | --- |
| 203 | 1.3.9 | **Ligne HBS6** |  | 695d | 2020-03-12 | 2022-12-23 |  | 0d |  | Blank | NA | NA |
| 204 | 1.3.9.1 | **Montage** |  | 397d | 2020-03-12 | 2021-10-13 |  | 0d |  | Blank |  |  |
| 205 | 1.3.9.1.1 | Début Travaux | milestone | 0d | 2020-03-12 | 2020-03-12 | 614SS | 0d | start no earlier than 2019-01-01 | Blank |  |  |
| 206 | 1.3.9.1.2 | Fin Mise en service | milestone | 0d | 2021-10-13 | 2021-10-13 | 959 | 0d |  | Blank |  |  |
| 207 | 1.3.9.2 | **Exploitation définitive** |  | 298d | 2021-10-14 | 2022-12-23 |  | 0d |  | Blank |  |  |
| 208 | 1.3.9.2.1 | Début exploitation |  | 1d | 2021-10-14 | 2021-10-14 | 206 | 0d | start no earlier than 2019-01-01 | Blank |  |  |
| 209 | 1.3.9.2.2 | Fin | milestone | 0d | 2022-12-23 | 2022-12-23 |  | 0d | start no earlier than 2022-12-23 | Blank |  |  |
| 210 | 1.3.10 | **Ligne HBS7** |  | 515d | 2020-11-25 | 2022-12-23 |  | 0d |  | Blank | NA | NA |
| 211 | 1.3.10.1 | **Montage** |  | 363d | 2020-11-25 | 2022-05-18 |  | 0d |  | Blank |  |  |
| 212 | 1.3.10.1.1 | Début Travaux | milestone | 0d | 2020-11-25 | 2020-11-25 | 824 | 0d | start no earlier than 2019-01-01 | Blank |  |  |
| 213 | 1.3.10.1.2 | Fin Mise en service | milestone | 0d | 2022-05-18 | 2022-05-18 | 1036 | 0d |  | Blank |  |  |
| 214 | 1.3.10.2 | **Exploitation définitive** |  | 152d | 2022-05-19 | 2022-12-23 |  | 0d |  | Blank |  |  |
| 215 | 1.3.10.2.1 | Début exploitation |  | 1d | 2022-05-19 | 2022-05-19 | 213 | 0d | start no earlier than 2019-01-01 | Blank |  |  |
| 216 | 1.3.10.2.2 | Fin | milestone | 0d | 2022-12-23 | 2022-12-23 |  | 0d | start no earlier than 2022-12-23 | Blank |  |  |
| 217 | 1.3.11 | **Ligne HBS8** |  | 456d | 2021-03-01 | 2022-12-23 |  | 0d |  | Blank | NA | NA |
| 218 | 1.3.11.1 | **Montage** |  | 204d | 2021-03-01 | 2021-12-16 |  | 0d |  | Blank |  |  |
| 219 | 1.3.11.1.1 | Début Travaux | milestone | 0d | 2021-03-01 | 2021-03-01 | 891SS | 0d | start no earlier than 2019-01-01 | Blank |  |  |
| 220 | 1.3.11.1.2 | Fin Mise en service | milestone | 0d | 2021-12-16 | 2021-12-16 | 987 | 0d |  | Blank |  |  |
| 221 | 1.3.11.2 | **Exploitation définitive** |  | 252d | 2021-12-17 | 2022-12-23 |  | 0d |  | Blank |  |  |
| 222 | 1.3.11.2.1 | Début exploitation |  | 1d | 2021-12-17 | 2021-12-17 | 220 | 0d | start no earlier than 2019-01-01 | Blank |  |  |
| 223 | 1.3.11.2.2 | Fin | milestone | 0d | 2022-12-23 | 2022-12-23 |  | 0d | start no earlier than 2022-12-23 | Blank |  |  |
| 224 | 1.3.12 | **Check-In HF1** |  | 1065d | 2018-10-01 | 2022-12-23 |  | 0d |  | Blank | NA | NA |
| 225 | 1.3.12.1 | **Exploitation avant travaux** |  | 95d | 2018-10-01 | 2019-02-11 |  | 0d |  | Blank |  |  |
| 226 | 1.3.12.1.1 | Début initial | milestone | 0d | 2018-10-01 | 2018-10-01 |  | 0d | start no earlier than 2018-10-01 | Blank |  |  |
| 227 | 1.3.12.1.2 | Fin Exploitation avant travaux | milestone | 0d | 2019-02-11 | 2019-02-11 |  | 0d |  | Blank |  |  |

| ID | WBS | Task | Type | Duration | Start | Finish | Predecessors | Total slack | Constraint | Text12 | Text21 | Text29 |
| --- | --- | --- | --- | --- | --- | --- | --- | --- | --- | --- | --- | --- |
| 228 | 1.3.12.2 | **Montage** |  | 195d | 2020-05-26 | 2021-03-08 |  | 0d |  | Blank |  |  |
| 229 | 1.3.12.2.1 | Début Travaux | milestone | 0d | 2020-05-26 | 2020-05-26 | 687SS | 0d | start no earlier than 2019-01-01 | Blank |  |  |
| 230 | 1.3.12.2.2 | Fin Mise en service | milestone | 0d | 2021-03-08 | 2021-03-08 | 892 | 0d |  | Blank |  |  |
| 231 | 1.3.12.3 | **Exploitation définitive** |  | 450d | 2021-03-09 | 2022-12-23 |  | 0d |  | Blank |  |  |
| 232 | 1.3.12.3.1 | Début exploitation |  | 1d | 2021-03-09 | 2021-03-09 | 230 | 0d | start no earlier than 2019-01-01 | Blank |  |  |
| 233 | 1.3.12.3.2 | Fin | milestone | 0d | 2022-12-23 | 2022-12-23 |  | 0d | start no earlier than 2022-12-23 | Blank |  |  |
| 234 | 1.3.13 | **Check-In HF2** |  | 1065d | 2018-10-01 | 2022-12-23 |  | 0d |  | Blank | NA | NA |
| 235 | 1.3.13.1 | **Exploitation avant travaux** |  | 95d | 2018-10-01 | 2019-02-11 |  | 0d |  | Blank |  |  |
| 236 | 1.3.13.1.1 | Début initial | milestone | 0d | 2018-10-01 | 2018-10-01 |  | 0d | start no earlier than 2018-10-01 | Blank |  |  |
| 237 | 1.3.13.1.2 | Fin Exploitation avant travaux | milestone | 0d | 2019-02-11 | 2019-02-11 |  | 0d |  | Blank |  |  |
| 238 | 1.3.13.2 | **Montage** |  | 35d | 2021-01-19 | 2021-03-08 |  | 0d |  | Blank |  |  |
| 239 | 1.3.13.2.1 | Début Travaux | milestone | 0d | 2021-01-19 | 2021-01-19 | 854SS | 0d | start no earlier than 2019-01-01 | Blank |  |  |
| 240 | 1.3.13.2.2 | Fin Mise en service | milestone | 0d | 2021-03-08 | 2021-03-08 | 893 | 0d |  | Blank |  |  |
| 241 | 1.3.13.3 | **Exploitation définitive** |  | 450d | 2021-03-09 | 2022-12-23 |  | 0d |  | Blank |  |  |
| 242 | 1.3.13.3.1 | Début exploitation |  | 1d | 2021-03-09 | 2021-03-09 | 240 | 0d | start no earlier than 2019-01-01 | Blank |  |  |
| 243 | 1.3.13.3.2 | Fin | milestone | 0d | 2022-12-23 | 2022-12-23 |  | 0d | start no earlier than 2022-12-23 | Blank |  |  |
| 244 | 1.3.14 | **Check-In HF3** |  | 1065d | 2018-10-01 | 2022-12-23 |  | 0d |  | Blank | NA | NA |
| 245 | 1.3.14.1 | **Exploitation avant travaux** |  | 95d | 2018-10-01 | 2019-02-11 |  | 0d |  | Blank |  |  |
| 246 | 1.3.14.1.1 | Début initial | milestone | 0d | 2018-10-01 | 2018-10-01 |  | 0d | start no earlier than 2018-10-01 | Blank |  |  |
| 247 | 1.3.14.1.2 | Fin Exploitation avant travaux | milestone | 0d | 2019-02-11 | 2019-02-11 |  | 0d |  | Blank |  |  |
| 248 | 1.3.14.2 | **Montage** |  | 31d | 2021-05-26 | 2021-07-07 |  | 0d |  | Blank |  |  |
| 249 | 1.3.14.2.1 | Début Travaux | milestone | 0d | 2021-05-26 | 2021-05-26 | 909SS | 0d | start no earlier than 2019-01-01 | Blank |  |  |
| 250 | 1.3.14.2.2 | Fin Mise en service | milestone | 0d | 2021-07-07 | 2021-07-07 | 929 | 0d |  | Blank |  |  |
| 251 | 1.3.14.3 | **Exploitation définitive** |  | 367d | 2021-07-08 | 2022-12-23 |  | 0d |  | Blank |  |  |
| 252 | 1.3.14.3.1 | Début exploitation |  | 1d | 2021-07-08 | 2021-07-08 | 250 | 0d | start no earlier than 2019-01-01 | Blank |  |  |
| 253 | 1.3.14.3.2 | Fin | milestone | 0d | 2022-12-23 | 2022-12-23 |  | 0d | start no earlier than 2022-12-23 | Blank |  |  |

| ID | WBS | Task | Type | Duration | Start | Finish | Predecessors | Total slack | Constraint | Text12 | Text21 | Text29 |
| --- | --- | --- | --- | --- | --- | --- | --- | --- | --- | --- | --- | --- |
| 254 | 1.3.15 | **Check-In G17** |  | 1065d | 2018-10-01 | 2022-12-23 |  | 0d |  | Blank | NA | NA |
| 255 | 1.3.15.1 | **Exploitation avant travaux** |  | 385d | 2018-10-01 | 2020-04-02 |  | 0d |  | Blank | NA |  |
| 256 | 1.3.15.1.1 | Début initial | milestone | 0d | 2018-10-01 | 2018-10-01 |  | 0d | start no earlier than 2018-10-01 | Blank | NA |  |
| 257 | 1.3.15.1.2 | Fin Exploitation avant travaux | milestone | 0d | 2020-04-02 | 2020-04-02 | 674 | 0d |  | Blank | NA |  |
| 258 | 1.3.15.2 | **Démontage + Remontage + Mise en service** |  | 56d | 2020-04-02 | 2020-06-24 |  | 0d |  | Blank | NA |  |
| 259 | 1.3.15.2.1 | Début Travaux | milestone | 0d | 2020-04-02 | 2020-04-02 | 675SS | 0d | start no earlier than 2019-01-01 | Blank | NA |  |
| 260 | 1.3.15.2.2 | Fin Mise en service | milestone | 0d | 2020-06-24 | 2020-06-24 | 714 | 0d |  | Blank | NA |  |
| 261 | 1.3.15.3 | **Exploitation définitive** |  | 624d | 2020-06-25 | 2022-12-23 |  | 0d |  | Blank | NA |  |
| 262 | 1.3.15.3.1 | Début exploitation |  | 1d | 2020-06-25 | 2020-06-25 | 260 | 0d | start no earlier than 2019-01-01 | Blank | NA |  |
| 263 | 1.3.15.3.2 | Fin | milestone | 0d | 2022-12-23 | 2022-12-23 |  | 0d | start no earlier than 2022-12-23 | Blank | NA |  |
| 264 | 1.3.16 | **Check-In G20** |  | 1065d | 2018-10-01 | 2022-12-23 |  | 0d |  | Blank | NA | NA |
| 265 | 1.3.16.1 | **Exploitation avant travaux** |  | 385d | 2018-10-01 | 2020-04-02 |  | 0d |  | Blank | NA |  |
| 266 | 1.3.16.1.1 | Début initial | milestone | 0d | 2018-10-01 | 2018-10-01 |  | 0d | start no earlier than 2018-10-01 | Blank | NA |  |
| 267 | 1.3.16.1.2 | Fin Exploitation avant travaux | milestone | 0d | 2020-04-02 | 2020-04-02 | 674 | 0d |  | Blank | NA |  |
| 268 | 1.3.16.2 | **Démontage + Remontage + Mise en service** |  | 56d | 2020-04-02 | 2020-06-24 |  | 0d |  | Blank | NA |  |
| 269 | 1.3.16.2.1 | Début Travaux | milestone | 0d | 2020-04-02 | 2020-04-02 | 675SS | 0d | start no earlier than 2019-01-01 | Blank | NA |  |
| 270 | 1.3.16.2.2 | Fin Mise en service | milestone | 0d | 2020-06-24 | 2020-06-24 | 714 | 0d |  | Blank | NA |  |
| 271 | 1.3.16.3 | **Exploitation définitive** |  | 624d | 2020-06-25 | 2022-12-23 |  | 0d |  | Blank | NA |  |
| 272 | 1.3.16.3.1 | Début exploitation |  | 1d | 2020-06-25 | 2020-06-25 | 270 | 0d | start no earlier than 2019-01-01 | Blank | NA |  |
| 273 | 1.3.16.3.2 | Fin | milestone | 0d | 2022-12-23 | 2022-12-23 |  | 0d | start no earlier than 2022-12-23 | Blank | NA |  |
| 274 | 1.3.17 | **Check-In G25** |  | 1065d | 2018-10-01 | 2022-12-23 |  | 0d |  | Blank | NA | NA |
| 275 | 1.3.17.1 | **Exploitation avant travaux** |  | 385d | 2018-10-01 | 2020-04-02 |  | 0d |  | Blank | NA |  |
| 276 | 1.3.17.1.1 | Début initial | milestone | 0d | 2018-10-01 | 2018-10-01 |  | 0d | start no earlier than 2018-10-01 | Blank | NA |  |
| 277 | 1.3.17.1.2 | Fin Exploitation avant travaux | milestone | 0d | 2020-04-02 | 2020-04-02 | 674 | 0d |  | Blank | NA |  |

| ID | WBS | Task | Type | Duration | Start | Finish | Predecessors | Total slack | Constraint | Text12 | Text21 | Text29 |
| --- | --- | --- | --- | --- | --- | --- | --- | --- | --- | --- | --- | --- |
| 278 | 1.3.17.2 | **Démontage + Remontage + Mise en service** |  | 50d | 2020-04-02 | 2020-06-16 |  | 0d |  | Blank | NA |  |
| 279 | 1.3.17.2.1 | Début Travaux | milestone | 0d | 2020-04-02 | 2020-04-02 | 675SS | 0d | start no earlier than 2019-01-01 | Blank | NA |  |
| 280 | 1.3.17.2.2 | Fin Mise en service | milestone | 0d | 2020-06-16 | 2020-06-16 | 686 | 0d |  | Blank | NA |  |
| 281 | 1.3.17.3 | **Exploitation définitive** |  | 630d | 2020-06-17 | 2022-12-23 |  | 0d |  | Blank | NA |  |
| 282 | 1.3.17.3.1 | Début exploitation |  | 1d | 2020-06-17 | 2020-06-17 | 280 | 0d | start no earlier than 2019-01-01 | Blank | NA |  |
| 283 | 1.3.17.3.2 | Fin | milestone | 0d | 2022-12-23 | 2022-12-23 |  | 0d | start no earlier than 2022-12-23 | Blank | NA |  |
| 284 | 1.3.18 | **Check-In G30** |  | 1065d | 2018-10-01 | 2022-12-23 |  | 0d |  | Blank | NA | NA |
| 285 | 1.3.18.1 | **Exploitation avant travaux** |  | 441d | 2018-10-01 | 2020-06-24 |  | 0d |  | Blank | NA |  |
| 286 | 1.3.18.1.1 | Début initial | milestone | 0d | 2018-10-01 | 2018-10-01 |  | 0d | start no earlier than 2018-10-01 | Blank | NA |  |
| 287 | 1.3.18.1.2 | Fin Exploitation avant travaux | milestone | 0d | 2020-06-24 | 2020-06-24 | 752 | 0d |  | Blank | NA |  |
| 288 | 1.3.18.2 | **Démontage + Remontage + Mise en service** |  | 43d | 2020-06-25 | 2020-08-24 |  | 0d |  | Blank | NA |  |
| 289 | 1.3.18.2.1 | Début Travaux | milestone | 0d | 2020-06-25 | 2020-06-25 | 753SS | 0d | start no earlier than 2019-01-01 | Blank | NA |  |
| 290 | 1.3.18.2.2 | Fin Mise en service | milestone | 0d | 2020-08-24 | 2020-08-24 | 759 | 0d |  | Blank | NA |  |
| 291 | 1.3.18.3 | **Exploitation définitive** |  | 581d | 2020-08-25 | 2022-12-23 |  | 0d |  | Blank | NA |  |
| 292 | 1.3.18.3.1 | Début exploitation |  | 1d | 2020-08-25 | 2020-08-25 | 290 | 0d | start no earlier than 2019-01-01 | Blank | NA |  |
| 293 | 1.3.18.3.2 | Fin | milestone | 0d | 2022-12-23 | 2022-12-23 |  | 0d | start no earlier than 2022-12-23 | Blank | NA |  |
| 294 | 1.3.19 | **Check-In G35** |  | 1065d | 2018-10-01 | 2022-12-23 |  | 0d |  | Blank | NA | NA |
| 295 | 1.3.19.1 | **Exploitation avant travaux** |  | 708d | 2018-10-01 | 2021-07-21 |  | 0d |  | Blank | NA |  |
| 296 | 1.3.19.1.1 | Début initial | milestone | 0d | 2018-10-01 | 2018-10-01 |  | 0d | start no earlier than 2018-10-01 | Blank | NA |  |
| 297 | 1.3.19.1.2 | Fin Exploitation avant travaux | milestone | 0d | 2021-07-21 | 2021-07-21 | 952 | 0d |  | Blank | NA |  |
| 298 | 1.3.19.2 | **Démontage + Remontage + Mise en service** |  | 59d | 2021-07-22 | 2021-10-13 |  | 0d |  | Blank | NA |  |
| 299 | 1.3.19.2.1 | Début Travaux | milestone | 0d | 2021-07-22 | 2021-07-22 | 953SS | 0d | start no earlier than 2019-01-01 | Blank | NA |  |
| 300 | 1.3.19.2.2 | Fin Mise en service | milestone | 0d | 2021-10-13 | 2021-10-13 | 959 | 0d |  | Blank | NA |  |
| 301 | 1.3.19.3 | **Exploitation définitive** |  | 298d | 2021-10-14 | 2022-12-23 |  | 0d |  | Blank | NA |  |
| 302 | 1.3.19.3.1 | Début exploitation |  | 1d | 2021-10-14 | 2021-10-14 | 300 | 0d | start no earlier than 2019-01-01 | Blank | NA |  |
| 303 | 1.3.19.3.2 | Fin | milestone | 0d | 2022-12-23 | 2022-12-23 |  | 0d | start no earlier than 2022-12-23 | Blank | NA |  |

| ID | WBS | Task | Type | Duration | Start | Finish | Predecessors | Total slack | Constraint | Text12 | Text21 | Text29 |
| --- | --- | --- | --- | --- | --- | --- | --- | --- | --- | --- | --- | --- |
| 304 | 1.3.20 | **Check-In G40** |  | 1065d | 2018-10-01 | 2022-12-23 |  | 0d |  | Blank | NA | NA |
| 305 | 1.3.20.1 | **Exploitation avant travaux** |  | 886d | 2018-10-01 | 2022-04-07 |  | 0d |  | Blank | NA |  |
| 306 | 1.3.20.1.1 | Début initial | milestone | 0d | 2018-10-01 | 2018-10-01 |  | 0d | start no earlier than 2018-10-01 | Blank | NA |  |
| 307 | 1.3.20.1.2 | Fin Exploitation avant travaux | milestone | 0d | 2022-04-07 | 2022-04-07 | 1029 | 0d |  | Blank | NA |  |
| 308 | 1.3.20.2 | **Démontage + Remontage + Mise en service** |  | 27d | 2022-04-08 | 2022-05-18 |  | 0d |  | Blank | NA |  |
| 309 | 1.3.20.2.1 | Début Travaux | milestone | 0d | 2022-04-08 | 2022-04-08 | 1030SS | 0d | start no earlier than 2019-01-01 | Blank | NA |  |
| 310 | 1.3.20.2.2 | Fin Mise en service | milestone | 0d | 2022-05-18 | 2022-05-18 | 1036 | 0d |  | Blank | NA |  |
| 311 | 1.3.20.3 | **Exploitation définitive** |  | 152d | 2022-05-19 | 2022-12-23 |  | 0d |  | Blank | NA |  |
| 312 | 1.3.20.3.1 | Début exploitation |  | 1d | 2022-05-19 | 2022-05-19 | 310 | 0d | start no earlier than 2019-01-01 | Blank | NA |  |
| 313 | 1.3.20.3.2 | Fin | milestone | 0d | 2022-12-23 | 2022-12-23 |  | 0d | start no earlier than 2022-12-23 | Blank | NA |  |
| 314 | 1.3.21 | **Check-In G50** |  | 1065d | 2018-10-01 | 2022-12-23 |  | 0d |  | Blank | NA | NA |
| 315 | 1.3.21.1 | **Exploitation avant travaux** |  | 860d | 2018-10-01 | 2022-03-02 |  | 0d |  | Blank | NA |  |
| 316 | 1.3.21.1.1 | Début initial | milestone | 0d | 2018-10-01 | 2018-10-01 |  | 0d | start no earlier than 2018-10-01 | Blank | NA |  |
| 317 | 1.3.21.1.2 | Fin Exploitation avant travaux | milestone | 0d | 2022-03-02 | 2022-03-02 | 998 | 0d |  | Blank | NA |  |
| 318 | 1.3.21.2 | **Démontage + Remontage + Mise en service** |  | 26d | 2022-03-03 | 2022-04-07 |  | 0d |  | Blank | NA |  |
| 319 | 1.3.21.2.1 | Début Travaux | milestone | 0d | 2022-03-03 | 2022-03-03 | 999SS | 0d | start no earlier than 2019-01-01 | Blank | NA |  |
| 320 | 1.3.21.2.2 | Fin Mise en service | milestone | 0d | 2022-04-07 | 2022-04-07 | 1006 | 0d |  | Blank | NA |  |
| 321 | 1.3.21.3 | **Exploitation définitive** |  | 179d | 2022-04-08 | 2022-12-23 |  | 0d |  | Blank | NA |  |
| 322 | 1.3.21.3.1 | Début exploitation |  | 1d | 2022-04-08 | 2022-04-08 | 320 | 0d | start no earlier than 2019-01-01 | Blank | NA |  |
| 323 | 1.3.21.3.2 | Fin | milestone | 0d | 2022-12-23 | 2022-12-23 |  | 0d | start no earlier than 2022-12-23 | Blank | NA |  |
| 324 | 1.3.22 | **Check-In G55** |  | 1065d | 2018-10-01 | 2022-12-23 |  | 0d |  | Blank | NA | NA |
| 325 | 1.3.22.1 | **Exploitation avant travaux** |  | 657d | 2018-10-01 | 2021-05-07 |  | 0d |  | Blank | NA |  |
| 326 | 1.3.22.1.1 | Début initial | milestone | 0d | 2018-10-01 | 2018-10-01 |  | 0d | start no earlier than 2018-10-01 | Blank | NA |  |
| 327 | 1.3.22.1.2 | Fin Exploitation avant travaux | milestone | 0d | 2021-05-07 | 2021-05-07 | 918 | 0d |  | Blank | NA |  |

| ID | WBS | Task | Type | Duration | Start | Finish | Predecessors | Total slack | Constraint | Text12 | Text21 | Text29 |
| --- | --- | --- | --- | --- | --- | --- | --- | --- | --- | --- | --- | --- |
| 328 | 1.3.22.2 | **Démontage + Remontage + Mise en service** |  | 27d | 2021-05-10 | 2021-06-17 |  | 0d |  | Blank | NA |  |
| 329 | 1.3.22.2.1 | Début Travaux | milestone | 0d | 2021-05-10 | 2021-05-10 | 919SS | 0d | start no earlier than 2019-01-01 | Blank | NA |  |
| 330 | 1.3.22.2.2 | Fin Mise en service | milestone | 0d | 2021-06-17 | 2021-06-17 | 925 | 0d |  | Blank | NA |  |
| 331 | 1.3.22.3 | **Exploitation définitive** |  | 381d | 2021-06-18 | 2022-12-23 |  | 0d |  | Blank | NA |  |
| 332 | 1.3.22.3.1 | Début exploitation |  | 1d | 2021-06-18 | 2021-06-18 | 330 | 0d | start no earlier than 2019-01-01 | Blank | NA |  |
| 333 | 1.3.22.3.2 | Fin | milestone | 0d | 2022-12-23 | 2022-12-23 |  | 0d | start no earlier than 2022-12-23 | Blank | NA |  |
| 334 | 1.3.23 | **Check-In G60** |  | 1065d | 2018-10-01 | 2022-12-23 |  | 0d |  | Blank | NA | NA |
| 335 | 1.3.23.1 | **Exploitation avant travaux** |  | 767d | 2018-10-01 | 2021-10-13 |  | 0d |  | Blank | NA |  |
| 336 | 1.3.23.1.1 | Début initial | milestone | 0d | 2018-10-01 | 2018-10-01 |  | 0d | start no earlier than 2018-10-01 | Blank | NA |  |
| 337 | 1.3.23.1.2 | Fin Exploitation avant travaux | milestone | 0d | 2021-10-13 | 2021-10-13 | 979 | 0d |  | Blank | NA |  |
| 338 | 1.3.23.2 | **Démontage + Remontage + Mise en service** |  | 46d | 2021-10-14 | 2021-12-16 |  | 0d |  | Blank | NA |  |
| 339 | 1.3.23.2.1 | Début Travaux | milestone | 0d | 2021-10-14 | 2021-10-14 | 980SS | 0d | start no earlier than 2019-01-01 | Blank | NA |  |
| 340 | 1.3.23.2.2 | Fin Mise en service | milestone | 0d | 2021-12-16 | 2021-12-16 | 987 | 0d |  | Blank | NA |  |
| 341 | 1.3.23.3 | **Exploitation définitive** |  | 252d | 2021-12-17 | 2022-12-23 |  | 0d |  | Blank | NA |  |
| 342 | 1.3.23.3.1 | Début exploitation |  | 1d | 2021-12-17 | 2021-12-17 | 340 | 0d | start no earlier than 2019-01-01 | Blank | NA |  |
| 343 | 1.3.23.3.2 | Fin | milestone | 0d | 2022-12-23 | 2022-12-23 |  | 0d | start no earlier than 2022-12-23 | Blank | NA |  |
| 344 | 1.3.24 | **Trieur Nord** |  | 671d | 2020-04-17 | 2022-12-23 |  | 0d |  | Blank | NA | NA |
| 345 | 1.3.24.1 | Fin Exploitation avant travaux | milestone | 0d | 2020-04-17 | 2020-04-17 | 504 | 0d |  | Blank | NA |  |
| 346 | 1.3.24.2 | **Montage** |  | 255d | 2020-04-17 | 2021-04-27 |  | 0d |  | Blank | NA |  |
| 347 | 1.3.24.2.1 | Début Travaux | milestone | 0d | 2020-04-17 | 2020-04-17 | 669SS | 0d | start no earlier than 2019-01-01 | Blank | NA |  |
| 348 | 1.3.24.2.2 | Fin Mise en service | milestone | 0d | 2021-04-27 | 2021-04-27 | 902 | 0d |  | Blank | NA |  |
| 349 | 1.3.24.3 | **Exploitation définitive** |  | 416d | 2021-04-28 | 2022-12-23 |  | 0d |  | Blank | NA |  |
| 350 | 1.3.24.3.1 | Début exploitation |  | 1d | 2021-04-28 | 2021-04-28 | 348 | 0d | start no earlier than 2019-01-01 | Blank | NA |  |
| 351 | 1.3.24.3.2 | Fin | milestone | 0d | 2022-12-23 | 2022-12-23 |  | 0d | start no earlier than 2022-12-23 | Blank | NA |  |

| ID | WBS | Task | Type | Duration | Start | Finish | Predecessors | Complete | Remaining | Total slack | Constraint | Work | Cost | Text12 | Text21 | Text29 | Text26 | Text1 |
| --- | --- | --- | --- | --- | --- | --- | --- | --- | --- | --- | --- | --- | --- | --- | --- | --- | --- | --- |
| 352 | 1.3.25 | **Trieur Sud** |  | 323d | 2021-09-08 | 2022-12-23 |  |  |  | 0d |  |  |  | Blank | NA | NA |  |  |
| 353 | 1.3.25.1 | **Montage** |  | 95d | 2021-09-08 | 2022-01-28 |  |  |  | 0d |  |  |  | Blank | NA |  |  |  |
| 354 | 1.3.25.1.1 | Début Travaux | milestone | 0d | 2021-09-08 | 2021-09-08 | 942SS |  |  | 0d | start no earlier than 2019-01-01 |  |  | Blank | NA |  |  |  |
| 355 | 1.3.25.1.2 | Fin Mise en service | milestone | 0d | 2022-01-28 | 2022-01-28 | 996 |  |  | 0d |  |  |  | Blank | NA |  |  |  |
| 356 | 1.3.25.2 | **Exploitation définitive** |  | 228d | 2022-01-31 | 2022-12-23 |  |  |  | 0d |  |  |  | Blank | NA |  |  |  |
| 357 | 1.3.25.2.1 | Début exploitation |  | 1d | 2022-01-31 | 2022-01-31 | 355 |  |  | 0d | start no earlier than 2019-01-01 |  |  | Blank | NA |  |  |  |
| 358 | 1.3.25.2.2 | Fin | milestone | 0d | 2022-12-23 | 2022-12-23 |  |  |  | 0d | start no earlier than 2022-12-23 |  |  | Blank | NA |  |  |  |
| 359 | 1.3.26 | **Passerelle** |  | 1035d | 2018-10-01 | 2022-11-11 |  |  |  | 0d |  |  |  | Blank | NA | NA |  |  |
| 360 | 1.3.26.1 | **Exploitation avant travaux** |  | 923d | 2018-10-01 | 2022-06-02 |  |  |  | 0d |  |  |  | Blank |  |  |  |  |
| 361 | 1.3.26.1.1 | Début initial | milestone | 0d | 2018-10-01 | 2018-10-01 |  |  |  | 0d | start no earlier than 2018-10-01 |  |  | Blank |  |  |  |  |
| 362 | 1.3.26.1.2 | Fin Exploitation avant travaux | milestone | 0d | 2022-06-02 | 2022-06-02 | 1025 |  |  | 0d |  |  |  | Blank |  |  |  |  |
| 363 | 1.3.26.2 | **Démontage** |  | 0d | 2022-11-11 | 2022-11-11 |  |  |  | 0d |  |  |  | Blank |  |  |  |  |
| 364 | 1.3.26.2.1 | Début Travaux | milestone | 0d | 2022-11-11 | 2022-11-11 | 497 |  |  | 0d | start no earlier than 2019-01-01 |  |  | Blank |  |  |  |  |
| 365 | 2 | **Période de forte affluence** |  | 786d | 2019-12-21 | 2023-02-17 |  |  |  | 0d |  |  |  | Blank | NA | NA | Blank |  |
| 366 | 2.1 | # periode Noel 2019 | manual | 10d | 2019-12-21 | 2020-01-06 |  |  |  |  |  |  |  | Blank | NA | NA | Blank |  |
| 367 | 2.2 | # periode Fevrier 2020 | manual | 7d | 2020-02-08 | 2020-02-17 |  |  |  |  |  |  |  | Blank | NA | NA | Blank |  |
| 368 | 2.3 | # periode Fevrier 2020 Extension | manual | 7d | 2020-02-22 | 2020-03-02 |  |  |  |  |  |  |  | Blank | NA | NA |  |  |
| 369 | 2.4 | # periode Noel 2020 | manual | 10d | 2020-12-24 | 2021-01-15 |  |  |  |  |  |  |  | Blank | NA | NA | Blank |  |
| 370 | 2.5 | # periode Fevrier 2021 | manual | 5d | 2021-02-15 | 2021-02-19 |  |  |  |  |  |  |  | Blank | NA | NA | Blank |  |
| 371 | 2.6 | # periode Noel 2021 (estimation) | manual | 10d | 2020-12-24 | 2021-01-15 |  |  |  |  |  |  |  | Blank | NA | NA | Blank |  |
| 372 | 2.7 | # periode Fevrier 2022 (estimation) | manual | 5d | 2022-02-14 | 2022-02-18 |  |  |  |  |  |  |  | Blank | NA | NA | Blank |  |
| 373 | 2.8 | # periode Noel 2022 (estimation) | manual | 10d | 2022-12-26 | 2023-01-13 |  |  |  |  |  |  |  | Blank | NA | NA | Blank |  |
| 374 | 2.9 | # periode Fevrier 2023 (estimation) | manual | 5d | 2023-02-13 | 2023-02-17 |  |  |  |  |  |  |  | Blank | NA | NA | Blank |  |
| 375 | 3 | **Projet GA BLC** |  | 2333d | 2019-02-11 A | 2028-03-22 |  |  | 2327.32d | 0d |  | 168h | 13,440 | Blank | NA | NA | Blank | BHS |
| 376 | 3.1 | **Realisation Projet BHS** |  | 1170d | 2019-02-11 A | 2023-10-06 |  | 2% | 1152.09d | 0d |  | 168h | 13,440 | Blank | NA | NA | Blank | BHS |
| 377 | 3.1.1 | Debut du Projet (T0) | milestone | 0d | 2019-02-11 | 2019-02-11 |  |  |  | 0d |  |  |  | Blank | NA | NA | Blank | BHS |

Notes:
- 366: validé GA
- 367: validé GA
- 368: Demande GA

| ID | WBS | Task | Type | Duration | Start | Finish | Predecessors | Total slack | Constraint | Text1 | Text12 | Text21 | Text26 | Text29 | Acteur |
| --- | --- | --- | --- | --- | --- | --- | --- | --- | --- | --- | --- | --- | --- | --- | --- |
| 378 | 3.1.2 | **Etudes et préparation à l'execution** |  | 254d | 2019-02-11 | 2020-02-11 |  | 0d |  | BHS | Blank | NA | Blank | NA |  |
| 379 | 3.1.2.1 | Elaboration du planning en coordination avec ET |  | 65d | 2019-02-11 | 2019-05-14 |  | 0d |  | BHS | Blank | NA | Blank | NA | ET/INT |
| 380 | 3.1.2.2 | **Etude Generale** |  | 95d | 2019-02-18 | 2019-07-04 |  | 0d |  | BHS | Blank | NA | Blank | NA |  |
| 381 | 3.1.2.2.1 | Partie charpente et mécanique |  | 95d | 2019-02-18 | 2019-07-04 | 377FS+5d | 0d |  | BHS | Blank | NA | Blank | NA | INT |
| 382 | 3.1.2.2.2 | Partie electrique |  | 95d | 2019-02-18 | 2019-07-04 | 377FS+5d | 0d |  | BHS | Blank | NA | Blank | NA | INT |
| 383 | 3.1.2.2.3 | Partie automatisme |  | 95d | 2019-02-18 | 2019-07-04 | 377FS+5d | 0d |  | BHS | Blank | NA | Blank | NA | INT |
| 384 | 3.1.2.2.4 | Partie Logiciel SAC/SCADA |  | 95d | 2019-02-18 | 2019-07-04 | 377FS+5d | 0d |  | BHS | Blank | NA | Blank | NA | INT |
| 385 | 3.1.2.2.5 | Organisation chantier |  | 95d | 2019-02-18 | 2019-07-04 | 377FS+5d | 0d |  | BHS | Blank | NA | Blank | NA | INT |
| 386 | 3.1.2.2.6 | Organisation du commissionnement globale |  | 95d | 2019-02-18 | 2019-07-04 | 377FS+5d | 0d |  | BHS | Blank | NA | Blank | NA | INT |
| 387 | 3.1.2.3 | Appobation des etude génerales | milestone | 0d | 2019-07-11 | 2019-07-11 | 380FS+5d | 0d |  | BHS | Blank | NA | Blank | NA | IS/MO |
| 388 | 3.1.2.4 | **Etude Detaillés** |  | 149d | 2019-07-12 | 2020-02-11 | 380 | 0d |  | BHS | Blank | NA | Blank | NA |  |
| 389 | 3.1.2.4.1 | Partie charpente et mécanique |  | 149d | 2019-07-12 | 2020-02-11 | 387 | 0d |  | BHS | Blank | NA | Blank | NA | INT |
| 390 | 3.1.2.4.2 | Partie electrique |  | 149d | 2019-07-12 | 2020-02-11 | 387 | 0d |  | BHS | Blank | NA | Blank | NA | INT |
| 391 | 3.1.2.4.3 | Partie automatisme |  | 149d | 2019-07-12 | 2020-02-11 | 387 | 0d |  | BHS | Blank | NA | Blank | NA | INT |
| 392 | 3.1.2.4.4 | Partie Logiciel SAC/SCADA |  | 149d | 2019-07-12 | 2020-02-11 | 387 | 0d |  | BHS | Blank | NA | Blank | NA | INT |
| 393 | 3.1.2.4.5 | Definition des procedures des Essais en site et en usine |  | 149d | 2019-07-12 | 2020-02-11 | 387 | 0d |  | BHS | Blank | NA | Blank | NA | INT |
| 394 | 3.1.3 | **Gestion achats, fabrication Essais en usine et livraison** |  | 512d | 2019-07-15 | 2021-07-28 |  | 0d |  | BHS | Blank | NA | Blank | NA |  |
| 395 | 3.1.3.1 | **C1- Enregistrement** |  | 388d | 2019-10-01 | 2021-04-19 |  | 0d |  | BHS | Blank | NA | Blank | NA |  |
| 396 | 3.1.3.1.1 | **Lot 1 Enregistrement G17,G20,G25,HF1** |  | 126d | 2019-10-01 | 2020-03-26 |  | 0d |  | BHS | Blank | NA | Blank | NA |  |
| 397 | 3.1.3.1.1.1 | Approbation des fiches techniques GVA/TG Concept |  | 5d | 2019-10-01 | 2019-10-07 |  | 0d | start no earlier than 2019-10-01 | BHS | Blank | NA | Blank | NA | IS/MO |
| 398 | 3.1.3.1.1.2 | Gestion achats et fabrication |  | 110d | 2019-10-08 | 2020-03-11 | 397 | 0d |  | BHS | Blank | NA | Blank | NA | INT |
| 399 | 3.1.3.1.1.3 | Essais en usine (FAT) |  | 1d | 2020-03-12 | 2020-03-12 | 398 | 0d |  | BHS | Blank | NA | Blank | NA | INT |
| 400 | 3.1.3.1.1.4 | Essais en usine (FIT) su la platform de prèproduction |  | 2d | 2020-03-13 | 2020-03-16 | 399 | 0d |  | BHS | Blank | NA | Blank | NA | INT |
| 401 | 3.1.3.1.1.5 | Livraison |  | 10d | 2020-03-13 | 2020-03-26 | 399 | 24d |  | BHS | Blank | NA | Blank | NA | INT |

| ID | WBS | Task | Duration | Start | Finish | Predecessors | Total slack | Constraint | Text1 | Text12 | Text21 | Text26 | Text29 | Acteur |
| --- | --- | --- | --- | --- | --- | --- | --- | --- | --- | --- | --- | --- | --- | --- |
| 402 | 3.1.3.1.2 | **Lot 2 Enregistrement HF2,HF3,G55** | 178d | 2019-11-25 | 2020-08-06 |  | 0d |  | BHS | Blank | NA | Blank | NA |  |
| 403 | 3.1.3.1.2.1 | Approbation des fiches techniques GVA/TG Concept | 5d | 2019-11-25 | 2019-11-29 |  | 0d | start no earlier than 2019-11-25 | BHS | Blank | NA | Blank | NA | IS/MO |
| 404 | 3.1.3.1.2.2 | Gestion achats et fabrication | 120d | 2019-12-02 | 2020-05-22 | 403 | 0d |  | BHS | Blank | NA | Blank | NA | INT |
| 405 | 3.1.3.1.2.3 | Essais en usine (FAT) | 3d | 2020-05-25 | 2020-05-27 | 404 | 0d |  | BHS | Blank | NA | Blank | NA | INT |
| 406 | 3.1.3.1.2.4 | Essais en usine (FIT) su la platform de prèproduction | 2d | 2020-05-28 | 2020-05-29 | 405 | 0d |  | BHS | Blank | NA | Blank | NA | INT |
| 407 | 3.1.3.1.2.5 | Livraison | 50d | 2020-05-28 | 2020-08-06 | 405 | 0d |  | BHS | Blank | NA | Blank | NA | INT |
| 408 | 3.1.3.1.3 | **Lot 3 Enregistrement G35,G60** | 252d | 2020-02-03 | 2021-02-05 |  | 0d |  | BHS | Blank | NA | Blank |  |  |
| 409 | 3.1.3.1.3.1 | Approbation des fiches techniques GVA/TG Concept | 5d | 2020-02-03 | 2020-02-07 |  | 0d | start no earlier than 2020-02-03 | BHS | Blank | NA | Blank | NA | IS/MO |
| 410 | 3.1.3.1.3.2 | Gestion achats et fabrication | 120d | 2020-02-10 | 2020-07-30 | 409 | 0d |  | BHS | Blank | NA | Blank | NA | INT |
| 411 | 3.1.3.1.3.3 | Essais en usine (FAT) | 1d | 2020-07-31 | 2020-07-31 | 410 | 0d |  | BHS | Blank | NA | Blank | NA | INT |
| 412 | 3.1.3.1.3.4 | Essais en usine (FIT) su la platform de prèproduction | 1d | 2020-08-03 | 2020-08-03 | 411 | 0d |  | BHS | Blank | NA | Blank | NA | INT |
| 413 | 3.1.3.1.3.5 | Livraison | 126d | 2020-08-03 | 2021-02-05 | 411 | 127d |  | BHS | Blank | NA | Blank | NA | INT |
| 414 | 3.1.3.1.4 | **Lot 4 Enregistrement G50,G40,G30;G10,G15** | 296d | 2020-02-10 | 2021-04-19 |  | 0d |  | BHS | Blank | NA | Blank | NA |  |
| 415 | 3.1.3.1.4.1 | Approbation des fiches techniques GVA/TG Concept | 5d | 2020-02-10 | 2020-02-14 |  | 0d | start no earlier than 2020-02-10 | BHS | Blank | NA | Blank | NA | IS/MO |
| 416 | 3.1.3.1.4.2 | Gestion achats et fabrication | 200d | 2020-02-17 | 2020-11-27 | 415 | 0d |  | BHS | Blank | NA | Blank | NA | INT |
| 417 | 3.1.3.1.4.3 | Essais en usine (FAT) | 1d | 2020-11-30 | 2020-11-30 | 416 | 0d |  | BHS | Blank | NA | Blank | NA | INT |
| 418 | 3.1.3.1.4.4 | Essais en usine (FIT) su la platform de prèproduction | 2d | 2020-12-01 | 2020-12-02 | 417 | 0d |  | BHS | Blank | NA | Blank | NA | INT |
| 419 | 3.1.3.1.4.5 | Livraison | 90d | 2020-12-01 | 2021-04-19 | 417 | 418d |  | BHS | Blank | NA | Blank | NA | INT |
| 420 | 3.1.3.2 | **C2 Controle Surete** | 170d | 2019-10-21 | 2020-06-22 |  | 0d |  | BHS | Blank | NA | Blank | NA |  |
| 421 | 3.1.3.2.1 | **Lot1 - HBS1,HBS2, HBS3, HBS4, controle complaimentaire** | 127d | 2019-11-04 | 2020-05-04 |  |  |  | BHS | Blank | NA | Blank | NA |  |
| 422 | 3.1.3.2.1.1 | Approbation des fiches techniques et schémas GVA/TG Concept | 5d | 2019-10-21 | 2019-10-25 |  | 5d | start no earlier than 2019-10-21 | BHS | Blank | NA | Blank | NA | IS/MO |
| 423 | 3.1.3.2.1.2 | Gestion achats et fabrication | 90d | 2019-11-04 | 2020-03-10 | 422 | 0d |  | BHS | Blank | NA | Blank | NA | INT |
| 424 | 3.1.3.2.1.3 | Essais en usine (FAT) | 2d | 2020-03-11 | 2020-03-12 | 423 | 0d |  | BHS | Blank | NA | Blank | NA | INT |
| 425 | 3.1.3.2.1.4 | Essais en usine (FIT) su la platform de prèproduction | 3d | 2020-03-27 | 2020-03-31 | 424FS+10d | 0d |  | BHS | Blank | NA | Blank | NA | INT |
| 426 | 3.1.3.2.1.5 | Livraison | 15d | 2020-03-13 | 2020-04-02 | 424 | 0d |  | BHS | Blank | NA | Blank | NA | INT |

| ID | WBS | Task | Duration | Start | Finish | Predecessors | Total slack | Constraint | Text1 | Text12 | Text21 | Text26 | Text29 | Acteur |
| --- | --- | --- | --- | --- | --- | --- | --- | --- | --- | --- | --- | --- | --- | --- |
| 427 | 3.1.3.2.2 | **Lot 2 - HBS5, HBS6, HBS7, HBS8** | 117d | 2020-01-06 | 2020-06-22 |  | 0d |  | BHS | Blank | NA | Blank | NA |  |
| 428 | 3.1.3.2.2.1 | Approbation des fiches techniques et schémas GVA/TG Concept | 5d | 2020-01-06 | 2020-01-10 |  | 0d | start no earlier than 2020-01-06 | BHS | Blank | NA | Blank | NA | IS/MO |
| 429 | 3.1.3.2.2.2 | Gestion achats et fabrication | 90d | 2020-01-13 | 2020-05-19 | 428 | 0d |  | BHS | Blank | NA | Blank | NA | INT |
| 430 | 3.1.3.2.2.3 | Essais en usine (FAT) | 2d | 2020-05-20 | 2020-05-22 | 429 | 0d |  | BHS | Blank | NA | Blank | NA | INT |
| 431 | 3.1.3.2.2.4 | Essais en usine (FIT) su la platform de prèproduction | 5d | 2020-06-09 | 2020-06-15 | 430FS+10d | 0d |  | BHS | Blank | NA | Blank | NA | INT |
| 432 | 3.1.3.2.2.5 | Livraison | 20d | 2020-05-25 | 2020-06-22 | 430 | 140d |  | BHS | Blank | NA | Blank | NA | INT |
| 433 | 3.1.3.3 | **C3 Triage** | 454d | 2019-10-07 | 2021-07-28 |  | 0d |  | BHS | Blank | NA | Blank | NA |  |
| 434 | 3.1.3.3.1 | **Lot1 - Triage Nord inclus MUP** | 111d | 2019-10-07 | 2020-03-11 |  | 0d |  | BHS | Blank | NA | Blank | NA |  |
| 435 | 3.1.3.3.1.1 | Approbation des fiches techniques et schémas GVA/TG Concept | 5d | 2019-10-07 | 2019-10-11 |  | 0d | start no earlier than 2019-10-07 | BHS | Blank | NA | Blank | NA | IS/MO |
| 436 | 3.1.3.3.1.2 | Gestion achats et fabrication | 90d | 2019-10-14 | 2020-02-18 | 435 | 0d |  | BHS | Blank | NA | Blank | NA | INT |
| 437 | 3.1.3.3.1.3 | Essais en usine (FAT) | 3d | 2020-02-19 | 2020-02-21 | 436 | 0d |  | BHS | Blank | NA | Blank | NA | INT |
| 438 | 3.1.3.3.1.4 | Essais en usine (FIT) su la platform de prèproduction | 3d | 2020-03-09 | 2020-03-11 | 437FS+10d | 0d | start no earlier than 2019-11-25 | BHS | Blank | NA | Blank | NA | INT |
| 439 | 3.1.3.3.1.5 | Livraison | 10d | 2020-02-24 | 2020-03-06 | 437 | 0d |  | BHS | Blank | NA | Blank | NA | INT |
| 440 | 3.1.3.3.2 | **Lot2 - Triage Sud inclus MUP, MUP Est** | 268d | 2020-01-27 | 2021-02-22 |  | 0d |  | BHS | Blank | NA | Blank | NA |  |
| 441 | 3.1.3.3.2.1 | Approbation des fiches techniques GVA/TG Concept | 5d | 2020-01-27 | 2020-01-31 |  | 0d | start no earlier than 2020-01-27 | BHS | Blank | NA | Blank | NA | IS/MO |
| 442 | 3.1.3.3.2.2 | Gestion achats et fabrication | 170d | 2020-02-03 | 2020-10-02 | 441 | 0d |  | BHS | Blank | NA | Blank | NA | INT |
| 443 | 3.1.3.3.2.3 | Essais en usine (FAT) | 3d | 2020-10-05 | 2020-10-07 | 442 | 0d |  | BHS | Blank | NA | Blank | NA | INT |
| 444 | 3.1.3.3.2.4 | Essais en usine (FIT) su la platform de prèproduction | 2d | 2020-10-22 | 2020-10-23 | 443FS+10d | 0d |  | BHS | Blank | NA | Blank | NA | INT |
| 445 | 3.1.3.3.2.5 | Livraison | 90d | 2020-10-08 | 2021-02-22 | 443 | 0d |  | BHS | Blank | NA | Blank | NA | INT |
| 446 | 3.1.3.3.3 | **Lot3 - MUP Ouest et Centraux** | 366d | 2020-02-10 | 2021-07-28 |  | 0d |  | BHS | Blank | NA | Blank | NA |  |
| 447 | 3.1.3.3.3.1 | Approbation des fiches techniques GVA/TG Concept | 5d | 2020-02-10 | 2020-02-14 |  | 0d | start no earlier than 2020-02-10 | BHS | Blank | NA | Blank | NA | IS/MO |
| 448 | 3.1.3.3.3.2 | Gestion achats et fabrication | 200d | 2020-02-17 | 2020-11-27 | 447 | 0d |  | BHS | Blank | NA | Blank | NA | INT |
| 449 | 3.1.3.3.3.3 | Essais en usine (FAT) | 3d | 2020-11-30 | 2020-12-02 | 448 | 0d |  | BHS | Blank | NA | Blank | NA | INT |
| 450 | 3.1.3.3.3.4 | Essais en usine (FIT) su la platform de prèproduction | 3d | 2021-07-26 | 2021-07-28 | 449FS+10d | 0d | start no earlier than 2021-07-26 | BHS | Blank | NA | Blank | NA | INT |
| 451 | 3.1.3.3.3.5 | Livraison | 140d | 2020-12-03 | 2021-07-02 | 449 | 0d |  | BHS | Blank | NA | Blank | NA | INT |

| ID | WBS | Task | Duration | Start | Finish | Predecessors | Total slack | Free slack | Constraint | Text1 | Text12 | Text21 | Text26 | Text29 | Acteur |
| --- | --- | --- | --- | --- | --- | --- | --- | --- | --- | --- | --- | --- | --- | --- | --- |
| 452 | 3.1.3.4 | **C4 EBS** | 198d | 2019-10-07 | 2020-07-16 |  | -3d | 0d |  | BHS | Blank | NA | Blank | NA |  |
| 453 | 3.1.3.4.1 | **Lot1 - EBS Plateforme, Area B et C** | 101d | 2019-10-07 | 2020-02-26 |  | -3d | 0d |  | BHS | Blank | NA | Blank | NA |  |
| 454 | 3.1.3.4.1.1 | Approbation des fiches techniques et schema GVA/TG Concept | 5d | 2019-10-07 | 2019-10-11 |  | -3d | 0d | start no earlier than 2019-10-07 | BHS | Blank | NA | Blank | NA | IS/MO |
| 455 | 3.1.3.4.1.2 | Gestion achats et fabrication | 80d | 2019-10-14 | 2020-02-04 | 454 | -3d | 0d |  | BHS | Blank | NA | Blank | NA | INT |
| 456 | 3.1.3.4.1.3 | Essais en usine (FAT) | 1d | 2020-02-05 | 2020-02-05 | 455 | -3d | 0d |  | BHS | Blank | NA | Blank | NA | INT |
| 457 | 3.1.3.4.1.4 | Essais en usine (FIT) su la platform de prèproduction | 5d | 2020-02-20 | 2020-02-26 | 456FS+10d | 0d |  | start no earlier than 2019-11-25 | BHS | Blank | NA | Blank | NA | INT |
| 458 | 3.1.3.4.1.5 | Livraison | 15d | 2020-02-06 | 2020-02-26 | 456 | -3d | 0d |  | BHS | Blank | NA | Blank | NA | INT |
| 459 | 3.1.3.4.2 | **Lot2 - EBS Area A, Connexions Trieur Nord etc Sud** | 168d | 2019-11-18 | 2020-07-16 |  | 0d |  |  | BHS | Blank | NA | Blank | NA |  |
| 460 | 3.1.3.4.2.1 | Approbation des fiches techniques GVA/TG Concept | 5d | 2019-11-18 | 2019-11-22 |  | 0d |  | start no earlier than 2019-11-18 | BHS | Blank | NA | Blank | NA | IS/MO |
| 461 | 3.1.3.4.2.2 | Gestion achats et fabrication | 100d | 2019-11-25 | 2020-04-16 | 460 | 0d |  |  | BHS | Blank | NA | Blank | NA | INT |
| 462 | 3.1.3.4.2.3 | Essais en usine (FAT) | 3d | 2020-04-17 | 2020-04-21 | 461 | 0d |  |  | BHS | Blank | NA | Blank | NA | INT |
| 463 | 3.1.3.4.2.4 | Essais en usine (FIT) su la platform de prèproduction | 5d | 2020-05-06 | 2020-05-12 | 462FS+10d | 0d |  |  | BHS | Blank | NA | Blank | NA | INT |
| 464 | 3.1.3.4.2.5 | Livraison | 60d | 2020-04-22 | 2020-07-16 | 462 | 71d |  |  | BHS | Blank | NA | Blank | NA | INT |
| 465 | 3.1.3.5 | **C5 Arrivée** | 200d | 2019-07-15 | 2020-04-27 |  | 0d |  |  | BHS | Blank | NA | Blank | NA |  |
| 466 | 3.1.3.5.1 | **Lot 1 Ligne Deposè : C7; activitée preparatoire C5** | 68d | 2019-07-15 | 2019-10-18 |  | 0d |  |  | BHS | Blank | NA | Blank | NA |  |
| 467 | 3.1.3.5.1.1 | Approbation des fiches techniques GVA/TG Concept | 5d | 2019-07-15 | 2019-07-19 |  | 0d |  | start no earlier than 2019-07-15 | BHS | Blank | NA | Blank | NA | IS/MO |
| 468 | 3.1.3.5.1.2 | Gestion achats et fabrication | 50d | 2019-07-22 | 2019-10-01 | 467 | 0d |  |  | BHS | Blank | NA | Blank | NA | INT |
| 469 | 3.1.3.5.1.3 | Essais en usine (FAT) | 1d | 2019-10-02 | 2019-10-02 | 468 | 0d |  |  | BHS | Blank | NA | Blank | NA | INT |
| 470 | 3.1.3.5.1.4 | Essais en usine (FIT) su la platform de prèproduction | 2d | 2019-10-17 | 2019-10-18 | 469FS+10d | 0d |  |  | BHS | Blank | NA | Blank | NA | INT |
| 471 | 3.1.3.5.1.5 | Livraison | 10d | 2019-10-03 | 2019-10-16 | 469 | 36d | 14d |  | BHS | Blank | NA | Blank | NA | INT |
| 472 | 3.1.3.5.2 | **Lot 2 Ligne Deposè : C4,C5, C6** | 86d | 2019-10-14 | 2020-02-12 |  | 0d |  |  | BHS | Blank | NA | Blank | NA |  |
| 473 | 3.1.3.5.2.1 | Approbation des fiches techniques GVA/TG Concept | 5d | 2019-10-14 | 2019-10-18 | 389SS | 0d |  | start no earlier than 2019-10-14 | BHS | Blank | NA | Blank | NA | IS/MO |
| 474 | 3.1.3.5.2.2 | Gestion achats et fabrication | 60d | 2019-10-21 | 2020-01-14 | 473 | 0d |  |  | BHS | Blank | NA | Blank | NA | INT |
| 475 | 3.1.3.5.2.3 | Essais en usine (FAT) | 1d | 2020-01-15 | 2020-01-15 | 474 | 0d |  |  | BHS | Blank | NA | Blank | NA | INT |
| 476 | 3.1.3.5.2.4 | Essais en usine (FIT) su la plateforme de prèproduction | 2d | 2020-01-30 | 2020-01-31 | 475FS+10d | 0d |  |  | BHS | Blank | NA | Blank | NA | INT |
| 477 | 3.1.3.5.2.5 | Livraison | 20d | 2020-01-16 | 2020-02-12 | 475 | 0d |  |  | BHS | Blank | NA | Blank | NA | INT |

| ID | WBS | Task | Type | Duration | Start | Finish | Predecessors | Total slack | Free slack | Constraint | Text1 | Text12 | Text21 | Text26 | Text29 | Acteur | Text13 | name 2 | Etage |
| --- | --- | --- | --- | --- | --- | --- | --- | --- | --- | --- | --- | --- | --- | --- | --- | --- | --- | --- | --- |
| 478 | 3.1.3.5.3 | **Lot 3 Ligne Deposè : C1;C2;C3; Secteur France** |  | 156d | 2019-09-17 | 2020-04-27 |  | 0d |  |  | BHS | Blank | NA | Blank | NA |  |  |  |  |
| 479 | 3.1.3.5.3.1 | Approbation des fiches techniques GVA/TG Concept |  | 5d | 2019-09-17 | 2019-09-23 | 389SS+30d | 0d |  | start no earlier than 2019-09-17 | BHS | Blank | NA | Blank | NA | IS/MO |  |  |  |
| 480 | 3.1.3.5.3.2 | Gestion achats et fabrication |  | 120d | 2019-09-24 | 2020-03-11 | 479 | 0d |  |  | BHS | Blank | NA | Blank | NA | INT |  |  |  |
| 481 | 3.1.3.5.3.3 | Essais en usine (FAT) |  | 1d | 2020-03-12 | 2020-03-12 | 480 | 0d |  |  | BHS | Blank | NA | Blank | NA | INT |  |  |  |
| 482 | 3.1.3.5.3.4 | Essais en usine (FIT) su la platform de prèproduction |  | 2d | 2020-03-27 | 2020-03-30 | 481FS+10d | 0d |  |  | BHS | Blank | NA | Blank | NA | INT |  |  |  |
| 483 | 3.1.3.5.3.5 | Livraison |  | 30d | 2020-03-13 | 2020-04-27 | 481 | 96d |  |  | BHS | Blank | NA | Blank | NA | INT |  |  |  |
| 484 | 3.1.4 | **Jalons du batiment** |  | 812d | 2019-08-15 | 2022-11-11 |  | 0d |  |  | BLC | Blank | NA | Blank | NA |  |  |  |  |
| 485 | 3.1.4.1 | *Z3.1 Mise à disposition Trémie HF | milestone | 0d | 2019-10-28 | 2019-10-28 | 522SS | 0d |  |  | BLC | Blank | NA | Blank | NA | ET | 3.1 |  |  |
| 486 | 3.1.4.2 | Z4.1 Remise dalle travaux préparatoires (y compris finitions) - (ne concerne pas INT) | milestone | 0d | 2020-02-03 | 2020-02-03 |  | 0d |  | start no earlier than 2020-02-03 | BLC | Blank | NA | Blank | NA | ET | 4.1 |  |  |
| 487 | 3.1.4.3 | Z4.2 Mise à disposition des nouveaux locaux axe K - (ne concerne pas INT) | milestone | 0d | 2020-03-06 | 2020-03-06 |  | 0d |  | start no earlier than 2020-03-06 | BLC | Blank | NA | Blank | NA | ET | 4.2 |  |  |
| 488 | 3.1.4.4 | Z4.3 Remise du SS02 axe jusqu’à l’axe 39 - (ne concerne pas INT) | milestone | 0d | 2020-04-02 | 2020-04-02 |  | 0d |  | start no earlier than 2020-04-02 | BLC | Blank | NA | Blank | NA | ET | 4.3 |  |  |
| 489 | 3.1.4.5 | Z5.3 Mise à disposition SS02 39-44 - (ne concerne pas INT) | milestone | 0d | 2020-06-11 | 2020-06-11 |  | 0d |  | start no earlier than 2020-06-11 | BLC | Blank | NA | Blank | NA | ET | 5.3 |  |  |
| 490 | 3.1.4.6 | Z7.2 Mise à disposition Plateforme supervision | milestone | 0d | 2020-07-31 | 2020-07-31 |  | 0d |  | must start on 2020-07-31 | BLC | Blank | NA | Blank | NA | ET | 7.2 |  |  |
| 491 | 3.1.4.7 | Z4.5 Mise à disposition Zone HBS Sud | milestone | 0d | 2020-06-26 | 2020-06-26 |  | 187d | 167d | start no earlier than 2020-06-26 | BLC | Blank | NA | Blank | NA | ET | 4.5 |  |  |
| 492 | 3.1.4.8 | Z5.4 Charpente Sud Solde SS01 y compris 2nd oeuvre | milestone | 0d | 2020-10-21 | 2020-10-21 |  | -39d | 0d | start no earlier than 2020-10-21 | BLC | Blank | NA | Blank | NA | ET | 5.4 |  |  |
| 493 | 3.1.4.9 | Z5.5 Mise à disposition Sheraton | milestone | 0d | 2020-11-19 | 2020-11-19 |  | -13d | 0d | start no earlier than 2020-11-19 | BLC | Blank | NA | Blank | NA | ET | 5.5 |  |  |
| 494 | 3.1.4.10 | Z7.3 Solde de la plateforme extérieure complète - (ne concerne pas INT) | milestone | 0d | 2021-03-31 | 2021-03-31 |  | 0d |  | must start on 2021-03-31 | BLC | Blank | NA | Blank | NA | ET | 7.3 |  |  |
| 495 | 3.1.4.11 | *Z5.6 Démolition triangle Sud / charpente Sud solde | milestone | 0d | 2021-05-11 | 2021-05-11 | 895 | 0d |  |  | BLC | Blank | NA | Blank | NA | ET | 5.6 |  |  |
| 496 | 3.1.4.12 | Z1.1 Remise surface T1 | milestone | 0d | 2022-03-31 | 2022-03-31 | 1011FS+11d | -39d | 0d | start no earlier than 2022-03-14 | BLC | Blank | NA | Blank | NA | ET | 1.1 |  |  |
| 497 | 3.1.4.13 | Z5.7 Mise à disposition surfaces ancienne passerelle y compris 2nd oeuvre et techniques | milestone | 0d | 2022-11-11 | 2022-11-11 | 1025FS+70d | 0d |  | start no earlier than 2022-11-11 | BLC | Blank | NA | Blank | NA | ET | 5.7 |  |  |
| 498 | 3.1.4.14 | Z7.1 Mise à disposition zone EBS SS02/SS01 | milestone | 0d | 2020-04-09 | 2020-04-09 |  | -33d | 0d | start no earlier than 2020-04-09 | BLC | Blank | NA | Blank | NA | ET | 7.1 | EBS |  |
| 499 | 3.1.4.15 | *JZ3.2 VL-Mise à disposition Gare de Triage Arrivée | milestone | 0d | 2019-08-15 | 2019-08-15 |  | 31d |  | start no earlier than 2019-08-15 | BLC | Blank | NA | Blank | NA | ET | 3.2 |  | RZ00 |
| 500 | 3.1.4.16 | JZ2.1 VG- Mise à disposition couloir SS01 Ligne ski | milestone | 0d | 2019-12-19 | 2019-12-19 | 550 | 0d |  | start no earlier than 2019-12-06 | BLC | Blank | NA |  | NA | ET | 2.1 |  | SS01 |
| 501 | 3.1.4.17 | Z5.1 Mise à disposition pour caisson Hors Format provisoire | milestone | 0d | 2019-09-27 | 2019-09-27 |  | 1d |  | start no earlier than 2019-09-27 | BLC | Blank | NA | Blank | NA | ET | 5.1 |  |  |
| 502 | 3.1.4.18 | Z3.3 Mise à disposition zone BS1 Gare de triage | milestone | 0d | 2020-01-14 | 2020-01-14 |  | 32d |  | start no earlier than 2020-01-14 | BLC | Blank | NA | Blank | NA | ET | 3.3 |  | RZ00 |
| 503 | 3.1.4.19 | *Z3.5 Trémies principales Gare de Triage | milestone | 0d | 2020-04-27 | 2020-04-27 | 632FS+15d | -37d | 0d | must start on 2020-04-27 | BLC | Blank | NA | Blank | NA | ET | 3.5 |  |  |
| 504 | 3.1.4.20 | Z6.1 Mise à disposition zone Trieur Nord avec charpente | milestone | 0d | 2020-04-17 | 2020-04-17 |  | 0d |  | start no earlier than 2020-04-17 | BLC | Blank | NA | Blank | NA | ET | 6.1 |  |  |
| 505 | 3.1.4.21 | Z5.2 Charpente Nord (SS01), levée de doutes HF | milestone | 0d | 2020-07-03 | 2020-07-03 |  | 0d |  | start no earlier than 2020-07-03 | BLC | Blank | NA | Blank | NA | ET | 5.2 |  | SS01 |
| 506 | 3.1.4.22 | Z4.4 Mise à disposition zone HBS Nord | milestone | 0d | 2020-07-16 | 2020-07-16 |  | 0d |  | start no earlier than 2020-07-16 | BLC | Blank | NA | Blank | NA | ET | 4.4 |  |  |
| 507 | 3.1.4.23 | Z3.4 Modification litiges (sous étape HBS Nord) | milestone | 0d | 2020-02-13 | 2020-02-13 |  | 106d |  | start no earlier than 2020-02-13 | BLC | Blank | NA | Blank | NA | ET | 3.4 |  |  |
| 508 | 3.1.4.24 | Z4.6 Mise à disposition zone Secteur France (Fin de travaux archi Mise à disposition zone Secteur France (hors trémie)) | milestone | 0d | 2020-07-13 | 2020-07-13 |  | 314d |  | start no earlier than 2020-07-13 | BLC | Blank | NA | Blank | NA | ET | 4.6 |  |  |
| 509 | 3.1.4.25 | *Z4.7 Trémie Secteur France (Fin de travaux archi pour installation équipement dans trémie - Trémie réalisée au SF) | milestone | 0d | 2021-11-16 | 2021-11-16 | 981FS+20d | 0d |  |  | BLC | Blank | NA | Blank | NA | ET | 4.7 |  |  |
| 510 | 3.1.4.26 | JZ2.2 VL-Mise à disposition Couloir derrière checkin 900 RZ00 | milestone | 0d | 2019-09-02 | 2019-09-02 |  | 58d | 55d | start no earlier than 2019-09-02 | BLC | Blank | NA | Blank | NA | ET | 2.2 |  | RZ00 |

Notes:
- 484: Vérifier si les taches doivent être "doit finir le"
- 502: VCS fera tous les travaux relatifs au jalon SAUF le démontage du mur derrière les check-in groupe 3000
- 505: Confirmer avec VCS que ce jalon comporte les 2 ouvertures dans mur IATA + local ETD et que le mur entre C de F et extension IATA est ouvert et cloison de sureté. ILS DOIVENT VERIFIER

| ID | WBS | Task | Type | Duration | Start | Finish | Predecessors | Complete | Remaining | Total slack | Free slack | Constraint | Work | Cost | Text1 | Text12 | Text21 | Text26 | Acteur | Text13 | Etage | Text8 | Coordonnées | Text25 |
| --- | --- | --- | --- | --- | --- | --- | --- | --- | --- | --- | --- | --- | --- | --- | --- | --- | --- | --- | --- | --- | --- | --- | --- | --- |
| 511 | 3.1.5 | **Installation BHS** |  | 980d | 2019-05-10 A | 2023-04-11 | 377 | 3% | 946.03d | 0d |  |  | 168h | 13,440 | BHS | Blank | NA | Blank |  |  |  |  |  |  |
| 512 | 3.1.5.1 | **Phase 1** |  | 4d | 2019-05-10 A | 2019-05-16 |  | 60% | 1.6d | 0d |  |  |  |  | BHS | Blank | NA | Blank |  |  |  |  |  |  |
| 513 | 3.1.5.1.1 | **Travaux Fonction C5 - ARRIVEE** |  | 4d | 2019-05-10 A | 2019-05-16 |  | 60% | 1.6d | 0d |  |  |  |  | BHS | Blank | NA | Blank |  |  |  |  |  |  |
| 514 | 3.1.5.1.1.1 | Consignation de la ligne Ski Partielle |  | 1d | 2019-05-10 | 2019-05-10 |  |  |  | 0d |  | start no earlier than 2019-05-10 |  |  | BLC | Stopped | NA | Stopped | GA |  |  |  |  |  |
| 515 | 3.1.5.1.1.2 | Mise à disposition de la zone de chantier par ET |  | 1d | 2019-05-10 | 2019-05-10 |  |  |  | 0d |  | start no earlier than 2019-05-10 |  |  | BHS | Blank | NA | Blank | ET | 3.1 | RZ00 |  |  |  |
| 516 | 3.1.5.1.1.3 | Raccourcissement Ligne ski , VABF |  | 3d | 2019-05-13 A | 2019-05-15 A | 514, 515 | 100% |  |  |  | start no earlier than 2019-05-13 |  |  | BHS | Dismounting | Ski | Dismounting | INT | 3.1 | RZ00 | 100% |  |  |
| 517 | 3.1.5.1.1.4 | Mise en service | milestone, manual | 0d | 2019-05-16 | 2019-05-16 | 516 |  |  |  |  |  |  |  | BHS | Working | Ski | Working | INT |  |  | 100% |  |  |
| 518 | 3.1.5.2 | **Phase 2 et Phase 3** |  | 91d | 2019-09-27 A | 2020-02-04 |  | 55% | 41.31d | 598d |  |  |  |  | BHS | Blank | NA | Blank |  |  |  |  |  |  |
| 519 | 3.1.5.2.1 | Début installation Leonardo | milestone | 0d | 2019-09-30 | 2019-09-30 |  |  |  | 0d |  | start no earlier than 2019-09-30 |  |  | BLC | Blank | NA | Blank | INT | 3.1 | RZ00 |  |  |  |
| 520 | 3.1.5.2.2 | JZ21.01VL- Mise à disposition du couloir SS01 pour démontage ligne ski | milestone | 0d | 2019-09-27 | 2019-09-27 |  |  |  | 0d |  | must start on 2019-09-27 |  |  | BLC | Blank | NA | Blank | ET | 2.1 | SS01 |  |  |  |
| 521 | 3.1.5.2.3 | JZ32.01LV-Mise à disposition pour création trémie+CF+trottoir ligne ski | milestone | 0d | 2019-10-14 | 2019-10-14 | 535, 553, 580 |  |  | 0d |  |  |  |  | BHS | Blank | NA | Blank | INT | 3.2 | RZ00 |  | 21/CD |  |
| 522 | 3.1.5.2.4 | JZ32.03VL-Mise à disposition trémie+CF+trottoir pour installation ligne ski+arrivée puissance | milestone | 0d | 2019-10-28 | 2019-10-28 | 521FS+10d |  |  | 0d |  |  |  |  | BLC | Blank | NA | Blank | ET | 3.2 | RZ00 |  | 21/CD |  |
| 523 | 3.1.5.2.5 | JZ21.02LV-Mise à disposition couloir SS01 pour création IS Est provisoire et modification cloison file 12-13 | milestone | 0d | 2019-10-07 | 2019-10-07 | 535, 534, 545 |  |  | 0d |  |  |  |  | BHS | Blank | NA | Blank | INT | 2.1 | SS01 |  | 20-21/CD |  |
| 524 | 3.1.5.2.6 | JZ21.03VL-IS Est provisoire réalisée et modification cloison file 12-13 réalisées pour montage ligne ski | milestone | 0d | 2019-10-21 | 2019-10-21 | 523FS+10d |  |  | 0d |  |  |  |  | BLC | Blank | NA | Blank | ET | 2.1 | SS01 |  |  |  |
| 525 | 3.1.5.2.7 | JZ21.04LV-Mise à disposition couloir SS01 pour technique | milestone | 0d | 2019-11-12 | 2019-11-12 | 539 |  |  | 17d | 0d |  |  |  | BHS | Blank | NA | Blank | INT | 2.1 | SS01 |  | 13-21/CD |  |
| 526 | 3.1.5.2.8 | JZ21.05VL-Fin des techniques dans couloir SS01 | milestone | 0d | 2019-11-26 | 2019-11-26 | 525FS+10d |  |  | 17d |  |  |  |  | BLC | Blank | NA | Blank | ET | 2.1 | SS01 |  | 13-21/CD |  |
| 527 | 3.1.5.2.9 | JZ32.05VL-Mise à disposition zone transfert TR1 et trottoir | milestone | 0d | 2019-11-13 | 2019-11-13 |  |  |  | 0d |  | start no earlier than 2019-11-13 |  |  | BLC | Blank | NA | Blank | ET | 3.2 | RZ00 |  | 29-30/AC |  |
| 528 | 3.1.5.2.10 | JZ32.06LV-Mise à disposition gare de triage ligne ski pour installation technique | milestone | 0d | 2019-12-19 | 2019-12-19 | 550 |  |  | 629d | 19d |  |  |  | BHS | Blank | NA |  | INT | 3.2 | RZ00 |  |  |  |
| 529 | 3.1.5.2.11 | JZ22.03LV- Mise à disposition couloir porte C pour remontage faux plafond (Ligne C7 testé) | milestone | 0d | 2020-01-16 | 2020-01-16 | 602 |  |  | 611d | 1d |  |  |  | BHS | Blank | NA |  | INT | 2.2 | RZ00 |  |  |  |
| 530 | 3.1.5.2.12 | JZ22.04VL-Mur Réalisé couloir derrière Check-In 900 pour montage HF1, T1+, HBS6 | milestone | 0d | 2019-11-18 | 2019-11-18 | 561SS |  |  | 73d |  |  |  |  | BLC | Blank | NA |  | ET | 2.2 | RZ00 |  |  |  |
| 531 | 3.1.5.2.13 | JZ32.07LV-Mise à disposition gare de triage ligne 7 et 900 et transfert pour installation technique | milestone | 0d | 2020-01-17 | 2020-01-17 | 604, 591, 587, 528, 529 |  |  | 610d |  |  |  |  | BHS | Blank | NA |  | INT | 3.2 | RZ00 |  |  |  |
| 532 | 3.1.5.2.14 | **Travaux Fonction C5 - ARRIVEE** |  | 59d | 2019-09-30 A | 2019-12-19 |  | 49% | 29.86d | 0d |  |  |  |  | BHS | Blank | NA | Blank |  |  |  |  |  |  |
| 533 | 3.1.5.2.14.1 | Consignation de la ligne Ski par GA | milestone | 0d | 2019-09-30 A | 2019-09-30 A | 499, 519 | 100% |  |  |  |  |  |  | BLC | Stopped | Ski | Stopped | GA |  |  |  |  |  |
| 534 | 3.1.5.2.14.2 | Demontage Ligne Ski (pour réaliser la trémie) |  | 5d | 2019-10-01 A | 2019-10-07 A | 533 | 100% |  |  |  | start no earlier than 2019-10-01 |  |  | BHS | Dismounting | Ski | Dismounting | INT | 3.2 | RZ00 | 100% | 21-22/AC | Arrivée |
| 535 | 3.1.5.2.14.3 | Demontage Ligne Ski (pour réaliser la trémie et IS Est) |  | 3d | 2019-09-30 A | 2019-10-02 A | 533 | 100% |  |  |  |  |  |  | BHS | Dismounting | Ski | Dismounting | INT | 3.2 | SS01 | 100% | 20-22/CD | Arrivée |
| 536 | 3.1.5.2.14.4 | JZ32.02LV-Mise à disposition pour rebouchage trémie ligne ski existante et pour création trottoir ligne 7 et 5 et mur CF ligne C7 | milestone | 0d | 2019-10-14 | 2019-10-14 | 553, 580, 534, 535 |  |  | 0d |  |  |  |  | BHS | Blank | NA | Blank | INT | 3.2 | RZ00 |  | 21/D |  |
| 537 | 3.1.5.2.14.5 | JZ32.04VL-Trémie ligne ski existante rebouchée+trottoir ligne 7-5 réalisé+arrivée puissance ligne 7 | milestone | 0d | 2019-10-31 | 2019-10-31 | 536FS+13d |  |  | 2.5d | 0d |  |  |  | BLC | Blank | NA | Blank | ET | 3.2 | RZ00 |  | 21/D |  |
| 538 | 3.1.5.2.14.6 | Montage mecanique et éléctrique Ligne ski zone sortie de secours existante SS01 |  | 4d | 2019-11-11 A | 2019-11-14 | 545 | 50% | 2d | 11d |  | start no earlier than 2019-11-11 |  |  | BHS | Installation | Ski | Installation | INT | 2.1 | SS01 |  | 12-13/DF |  |
| 539 | 3.1.5.2.14.7 | Montage Electrique Ligne Ski couloir SS01 |  | 7d | 2019-11-04 | 2019-11-12 | 546 |  |  | 13d | 0d |  |  |  | BHS | Installation | Ski | Installation | INT | 2.1 | SS01 |  | 13-20/CD |  |
| 540 | 3.1.5.2.14.8 | Demontage Ligne Ski couloir SS01 |  | 5d | 2019-09-30 A | 2019-10-04 A | 520, 533 | 100% |  |  |  |  |  |  | BHS | Dismounting | Ski | Dismounting | INT | 2.1 | SS01 | 100% | 13-20/CD | Arrivée |
| 541 | 3.1.5.2.14.9 | Montage Mécanique Ligne Ski et installation volet CF et AI (Avec descenseur dans trémie) |  | 10d | 2019-10-29 A | 2019-11-11 A | 522, 524, 485 | 100% |  |  |  |  |  |  | BHS | Installation | Ski | Installation | INT | 3.2 | RZ00 |  | 20-23/CD |  |
| 542 | 3.1.5.2.14.10 | Montage Mécanique Ligne Ski couloir SS01 |  | 7d | 2019-10-29 A | 2019-11-06 A | 544, 540 | 100% |  |  |  |  |  |  | BHS | Installation | Ski | Installation | INT | 2.1 | SS01 |  | 13-20/CD |  |
| 543 | 3.1.5.2.14.11 | Montage Electrique Ligne Ski (Avec descenseur dans trémie) |  | 14d | 2019-11-12 | 2019-11-29 | 541 |  |  | 0d |  |  |  |  | BHS | Installation | Ski | Installation | INT | 3.2 | RZ00 |  | 20-23/CD |  |
| 544 | 3.1.5.2.14.12 | Modification Ligne Ski (Abaissement convoyeur) |  | 5d | 2019-10-22 A | 2019-10-28 A | 524 | 100% |  |  |  |  |  |  | BHS | Dismounting | Ski | Dismounting | INT | 2.1 | SS01 |  | 12-13/DF |  |
| 545 | 3.1.5.2.14.13 | Demontage Ligne ski zone sortie de secours existante SS01 |  | 3d | 2019-09-30 A | 2019-10-02 A | 540SS | 100% |  |  |  |  |  |  | BHS | Dismounting | Ski | Dismounting | INT | 2.1 | SS01 | 100% | 12-13/DF | Arrivée |
| 546 | 3.1.5.2.14.14 | Câblage Electrique Ligne Ski existante |  | 4d | 2019-10-29 | 2019-11-01 | 542SS |  |  | 13d | 0d |  |  |  | BHS | Installation | Ski | Installation | INT | 2.1 | SS01 |  | 10-14/DL |  |
| 547 | 3.1.5.2.14.15 | Test Leonardo Preliminaire Ligne Ski |  | 3d | 2019-12-02 | 2019-12-04 | 539, 543, 546, 544, 541, 542, 538 |  |  | 0d |  |  |  |  | BHS | Commissioning | Ski | Commissioning | INT |  |  |  |  |  |
| 548 | 3.1.5.2.14.16 | Test Ligne ski |  | 5d | 2019-12-05 | 2019-12-11 | 547 |  |  | 0d |  |  |  |  | BHS | Commissioning | Ski | Commissioning | INT |  |  |  |  |  |
| 549 | 3.1.5.2.14.17 | VABF Ligne ski |  | 6d | 2019-12-12 | 2019-12-19 | 548 |  |  | 0d |  |  |  |  | BHS | Blank | Ski | Blank | INT/IS/GA |  |  |  |  |  |
| 550 | 3.1.5.2.14.18 | JZ21.06LG-Mise en service Ligne ski | milestone | 0d | 2019-12-19 | 2019-12-19 | 549, 526 |  |  | 0d |  |  |  |  | BHS | Working | Ski | Working | INT |  |  |  |  |  |

Notes:
- 511: Text29: NA
- 512: Text29: NA
- 513: Text29: NA
- 514: Text29: NA
- 515: Text29: NA
- 516: Text29: NA
- 517: Text29: NA
- 518: Text29: NA
- 519: Text29: NA
- 520: Text29: NA
- 521: Text29: NA
- 522: Text29: NA
- 523: Text29: NA
- 524: Text29: NA
- 525: Text29: NA
- 526: Text29: NA
- 527: Text29: NA
- 528: Text29: NA
- 529: Text29: NA
- 530: Text29: NA
- 531: Text29: NA
- 532: Text29: NA
- 533: Text29: NA
- 534: Text29: TB01 - TB04 - TB04A
- 535: Text29: TC05 - TC06
- 536: Text29: NA
- 537: Text29: NA
- 538: Text29: ARR08CV0110 - ARR08CV0120
- 539: Text29: NA
- 540: Text29: TB07 (METERING) - TB07 - (BELT CONVEYOR) - TB08 - TB09 - (METERING) - TB 09 (BELT CONVEYOR) - TB09 - (METERING) - TB 10
- 541: Text29: ARR08CV0010 - ARR08CV0020 - ARR08VI0030 - ARR08VF0030 - ARR08CV0030
- 542: Text29: ARR08CV0040 - ARR08CV0050 - ARR08CV0060 - ARR08CV0080
- 543: Durée revue initiale de 5j pour mise en service au 19.12.19 / Text29: NA
- 544: Text29: Existing eqt : ARR08CV0090 - ARR08CV0100
- 545: Text29: TB13 (Belt conveyor) - TB13 (Belt conveyor)
- 546: Text29: NA
- 547: Text29: NA
- 548: Text29: NA
- 549: Text29: NA
- 550: Text29: NA

| ID | WBS | Task | Type | Duration | Start | Finish | Predecessors | Complete | Remaining | Total slack | Free slack | Constraint | Text1 | Text12 | Text21 | Text26 | Acteur | Text8 | Coordonnées | Text13 | Etage | Text25 | Text17 |
| --- | --- | --- | --- | --- | --- | --- | --- | --- | --- | --- | --- | --- | --- | --- | --- | --- | --- | --- | --- | --- | --- | --- | --- |
| 551 | 3.1.5.2.15 | **Travaux Fonction C5 - ARRIVEE** |  | 37d | 2019-09-27 A | 2019-11-18 |  | 94% | 2.24d | 0d |  |  | BHS | Blank | NA | Blank |  |  |  |  |  |  |  |
| 552 | 3.1.5.2.15.1 | Consignation des Lignes 7 et 8 |  | 1d | 2019-09-30 | 2019-09-30 | 499, 519 |  |  | 0d |  |  | BLC | Stopped | NA | Stopped | GA |  |  |  |  |  |  |
| 553 | 3.1.5.2.15.2 | Démontage Lignes 7 et 8 (gare de triage pour réaliser trémie) |  | 10d | 2019-10-01 A | 2019-10-14 A | 552 | 100% |  |  |  |  | BHS | Dismounting | C7;C8 | Dismounting | INT | 100% | 17-22/BD | 3.2 | RZ00 | Arrivée |  |
| 554 | 3.1.5.2.15.3 | JZ22.05VL-Mise à disposition couloir Porte C (Faux plafond démontés) pour démontage ligne arrivée 7-8 | milestone | 0d | 2019-10-15 | 2019-10-15 | 555SF |  |  | 0d |  |  | BLC | Blank | NA | Blank | ET |  | 14-17/D | 2.2 | RZ00 |  |  |
| 555 | 3.1.5.2.15.4 | Démontage Lignes 7 et 8 (couloir Porte C) |  | 5d | 2019-10-15 A | 2019-10-21 A | 553 | 100% |  |  |  |  | BHS | Dismounting | C7;C8 | Dismounting | INT | 0% | 14-17/D | 2.2 | RZ00 | Arrivée |  |
| 556 | 3.1.5.2.15.5 | Démontage Lignes 7 et 8 (local technique) |  | 5d | 2019-10-22 A | 2019-10-28 A | 555, 510 | 100% |  |  |  |  | BHS | Dismounting | C7;C8 | Dismounting | INT | 95% | 13-15/DG | 2.2 | RZ00 | Arrivée |  |
| 557 | 3.1.5.2.15.6 | JZ21.07VL-Mise à disposition Cloison pour démontage carrousel | milestone | 0d | 2019-09-30 | 2019-09-30 | 540SS |  |  | 0d |  |  | BLC | Blank | NA | Blank | ET |  | 12-16/EI | 2.1 | SS01 |  |  |
| 558 | 3.1.5.2.15.7 | Démontage 4 écrans carrousel 7 et 8 par NEO Advertising |  | 1d | 2019-09-27 | 2019-09-27 | 559SS-2d |  |  | 0d |  |  | BLC | Blank | NA |  | GA |  | 12-16/EI | 2.1 | SS01 |  |  |
| 559 | 3.1.5.2.15.8 | Démontage Ligne 7 et 8 et carrousels Liv.7 et Liv.8 |  | 11d | 2019-10-01 A | 2019-10-15 A | 552, 557 | 100% |  |  |  |  | BHS | Dismounting | C7;C8 | Dismounting | INT | 70% | 12-16/EI | 2.1 | SS01 | Arrivée |  |
| 560 | 3.1.5.2.15.9 | JZ22.01LV-Mise à disposition local technique et couloir pour rebouchage trémie Ligne 7, création CF Ligne C7, création ouverture Ligne HF1, modification mur | milestone | 0d | 2019-10-28 | 2019-10-28 | 556, 559 |  |  | 0d |  |  | BHS | Blank | NA | Blank | INT |  | 15/F | 2.2 | RZ00 |  |  |
| 561 | 3.1.5.2.15.10 | JZ22.02VL-Fin de réalisation, Rebouchage trémie, CF Ligne C7, ouverture HF1, et modification mur pour montage ligne dans local technique et partielle couloir | milestone | 0d | 2019-11-18 | 2019-11-18 | 560FS+15d |  |  | 0d |  |  | BLC | Blank | NA | Blank | ET |  | 14/F | 2.2 | RZ00 |  |  |
| 562 | 3.1.5.2.15.11 | JZ21.08LV-Mise à disposition pour finition zone arrivée 7 et 8 (sol, et pour modification mur vers sortie Est existante) | milestone | 0d | 2019-10-15 | 2019-10-15 | 559, 545 |  |  | 22d | 0d |  | BHS | Blank | NA | Blank | INT |  | 12-16/EI | 2.1 | SS01 |  |  |
| 563 | 3.1.5.2.16 | **Travaux Fonction C1 - ENREGISTREMENTS** |  | 90d | 2019-09-30 A | 2020-02-04 |  | 48% | 47.16d | 0d |  |  | BHS | Blank | NA | Blank |  |  |  |  |  |  |  |
| 564 | 3.1.5.2.16.1 | Consignation de la ligne HF 4000 et Ligne gare 6000 | milestone | 0d | 2019-09-30 | 2019-09-30 | 501, 519 |  |  | 0d |  |  | BLC | Stopped | NA | Stopped | GA |  |  |  |  |  |  |
| 565 | 3.1.5.2.16.2 | Demontage Ligne gare 6000 |  | 14d | 2019-10-01 A | 2019-10-18 A | 564 | 100% |  |  |  | start no earlier than 2019-10-01 | BHS | Dismounting | Gare | Dismounting | INT | 90% | 47-48/FH |  | RZ00 | Enregistrement |  |
| 566 | 3.1.5.2.16.3 | Demontage partiel Ligne HF4000 |  | 15d | 2019-10-01 A | 2019-10-21 A | 564 | 100% |  |  |  | start no earlier than 2019-10-01 | BHS | Dismounting | HF4000 | Dismounting | INT | 95% | 45-48/EH |  | ET01 | Enregistrement | B C |
| 567 | 3.1.5.2.16.4 | Modification temporaire Ligne HF4000 |  | 20d | 2019-10-22 A | 2019-11-18 | 566, 565 | 50% | 10d | 33d |  |  | BHS | Installation | HF4000 | Installation | INT |  | 45-48/EH |  | RZ00 |  | B C |
| 568 | 3.1.5.2.16.5 | Demontage injection ET01-6000 |  | 2d | 2020-02-03 | 2020-02-04 | 566SS |  |  | 0d |  | must start on 2020-02-03 | BHS | Dismounting | NA | Dismounting | INT | 0% |  |  |  | Enregistrement |  |
| 569 | 3.1.5.2.16.6 | Reliquat activités HF4000 de 2019 |  | 1d | 2020-01-06 | 2020-01-06 | 366FS-1d |  |  | 0d |  |  |  |  | HF4000 |  | INT |  |  |  |  |  |  |
| 570 | 3.1.5.2.16.7 | Test Ligne HF4000 |  | 4d | 2020-01-07 | 2020-01-10 | 567, 569 |  |  | 0d |  |  | BHS | Commissioning | HF4000 | Commissioning | INT |  |  |  |  |  |  |
| 571 | 3.1.5.2.16.8 | VABF Ligne HF4000 |  | 1d | 2020-01-13 | 2020-01-13 | 570 |  |  | 0d |  |  | BHS | Blank | HF4000 | Blank | INT/IS/GA |  |  |  |  |  |  |
| 572 | 3.1.5.2.16.9 | Mise en service Ligne HF4000 | milestone | 0d | 2020-01-13 | 2020-01-13 | 571 |  |  | 0d |  |  | BHS | Working | HF4000 | Working | INT |  |  |  |  |  |  |
| 573 | 3.1.5.2.16.10 | Consignation Ligne Transfert | milestone | 0d | 2019-10-09 A | 2019-10-09 A | 499, 581 | 100% |  |  |  |  | BLC | Stopped | NA | Stopped | GA |  |  |  |  |  |  |
| 574 | 3.1.5.2.16.11 | Démontage Ligne Transfert |  | 4d | 2019-10-10 A | 2019-10-15 A | 573 | 100% |  |  |  |  | BHS | Dismounting | Transfert | Dismounting | INT | 100% | 21-28/AE |  | RZ00 | Enregistrement |  |
| 575 | 3.1.5.2.16.12 | Consignation Ligne EDX 8 | milestone | 0d | 2019-10-08 | 2019-10-08 | 576SF |  |  | 0d |  |  | BLC | Stopped | NA | Stopped | GA |  |  |  |  |  |  |
| 576 | 3.1.5.2.16.13 | Démontage Ligne EDX 8 |  | 2d | 2019-10-08 | 2019-10-10 | 577SF |  |  | 0d |  |  | BHS | Dismounting | EDX8 | Dismounting | GA | 100% | 24-25/D |  | RZ00 | Enregistrement |  |
| 577 | 3.1.5.2.16.14 | Installation Ligne EDX 8 nouvel emplacement |  | 3d | 2019-10-10 | 2019-10-14 | 578SF |  |  | 0d |  |  | BLC | Installation | EDX8 |  | GA | 100% |  |  | RZ00 | Enregistrement |  |
| 578 | 3.1.5.2.16.15 | Mise en service ligne EDX 8 nouvelle position | milestone | 0d | 2019-10-14 | 2019-10-14 | 536SF |  |  | 0d |  |  | BHS | Working | EDX8 |  | GA |  |  |  |  |  |  |
| 579 | 3.1.5.2.16.16 | Consignation Ligne 900 dans le sens EDS 1 (Check-In en service dans le sens 0000) | milestone | 0d | 2019-09-30 | 2019-09-30 | 499, 519 |  |  | 0d |  |  | BLC | Stopped | NA | Stopped | GA |  |  |  |  |  |  |
| 580 | 3.1.5.2.16.17 | Démontage Partielle Ligne 0900 (gare de triage pour réaliser trémie) |  | 4d | 2019-09-30 A | 2019-10-03 A | 579 | 100% |  |  |  |  | BHS | Dismounting | 900 | Dismounting | INT | 100% | 21-25/AE | 3.2 | RZ00 | Enregistrement |  |
| 581 | 3.1.5.2.16.18 | Démontage Partielle Ligne 0900 (gare de triage) |  | 4d | 2019-10-04 A | 2019-10-09 A | 580 | 100% |  |  |  |  | BHS | Dismounting | 900 | Dismounting | INT | 50% | 25-28/AE | 3.2 | RZ00 | Enregistrement |  |
| 582 | 3.1.5.2.16.19 | Demontage partielle(2° partie) Ligne 0900 (local technique) |  | 3d | 2019-10-04 A | 2019-10-08 A | 580 | 100% |  |  |  |  | BHS | Dismounting | 900 | Dismounting | INT | 60% | 14-15/GC | 3.2 | RZ00 | Enregistrement |  |
| 583 | 3.1.5.2.16.20 | Montage Partielle(1° partie) Meca + elec Ligne 0900 provisoire (gare de triage) |  | 10d | 2019-11-01 A | 2019-11-14 | 580, 537 | 25% | 7.5d | 23d | 0d | start no earlier than 2019-10-21 | BHS | Installation | 900 | Installation | INT |  | 21-28/AE | 3.2 | RZ00 |  |  |
| 584 | 3.1.5.2.16.21 | Montage partielle(2° partie) Meca + elec Ligne 0900 provisoire (couloir porte C et local technique) |  | 21d | 2019-11-19 A | 2019-12-17 | 561, 510, 582 | 14% | 18d | 0d |  |  | BHS | Installation | 900 | Installation | INT |  | 14-15/GC | 2.2 | RZ00 |  |  |
| 585 | 3.1.5.2.16.22 | Installation et Connection Ligne AuF Tr1 Nouvelle Partielle |  | 8d | 2019-11-13 | 2019-11-22 | 580SS, 527 |  |  | 0d |  |  | BHS | Installation | TR1 | Installation | INT |  | 29-30/AC | 3.2 | RZ00 |  |  |
| 586 | 3.1.5.2.16.23 | Installation de l'ATR pour la Tr1 |  | 2d | 2019-11-21 | 2019-11-22 | 585FS-2d |  |  | 0d |  |  | BHS | Installation | TR1 |  | INT |  | 29-30/AC | 3.2 | RZ00 |  |  |
| 587 | 3.1.5.2.16.24 | Mise en service Ligne Auf Tr1 Nouvelle Partielle |  | 2d | 2019-11-25 | 2019-11-26 | 585, 586 |  |  | 0d |  |  | BHS | Working | TR1 | Working | INT |  |  |  |  |  |  |
| 588 | 3.1.5.2.16.25 | Mise en service de l'ATR |  | 2d | 2019-11-27 | 2019-11-28 | 587 |  |  | 0d |  |  | BHS | Commissioning | TR1 |  | INT |  |  |  |  |  |  |
| 589 | 3.1.5.2.16.26 | Test Ligne 900 Provisoire |  | 2d | 2019-12-18 | 2019-12-19 | 584, 583, 585 |  |  | 0d |  |  | BHS | Commissioning | 900 | Commissioning | INT |  |  |  |  |  |  |
| 590 | 3.1.5.2.16.27 | VABF Ligne provisoire 0900 Casino |  | 1d | 2019-12-20 | 2019-12-20 | 589 |  |  | 0d |  |  | BHS | Blank | 900 | Blank | INT/IS/GA |  |  |  |  |  |  |
| 591 | 3.1.5.2.16.28 | Mise en service Ligne Provisoire 0900 Casino | milestone | 0d | 2019-12-20 | 2019-12-20 | 590 |  |  | 0d |  |  | BHS | Working | 900 | Working | INT |  |  |  |  |  |  |

Notes:
- 551: Text29: NA
- 552: Text29: NA
- 553: Text29: C71A - C7A - C7B - T70 - T71 - T72 -T72A - T72B - T73 - T74 -TB77 - CONV LIV 08 - 01 - CONV LIV 08 - 02
- 554: Imposition INT / Text29: NA
- 555: Text29: C7C - T75 - C8A - T81 - T82 - T83
- 556: Text29: C70 - T76 - C8B - T84
- 557: Text29: NA
- 558: Text29: NA
- 559: Text29: D70 - T77 - T78 - T79 - C8C - D80 - T85 - T86 - T87 - T88 - T89
- 560: Text29: NA
- 561: Text29: NA
- 562: Text29: NA
- 563: Text29: NA
- 564: Text29: NA
- 565: Text29: 6010 - 6011 - 6012 - 6020 - 6030 - 6040 - 6050 - 6080 - 6080 - 6100 - 6110 - 6120 - 6130 - INJ_1
- 566: Text29: 4150 - 4160 - 4170 - 4180 - 4190 - 4200 - 4210 - 4220 - 4230 - 4240 - 4250 - 4260
- 567: Text29: THF01CV0010 - THF01CV0070 Existing conveyor : 4150 - 4220 - 4230 - 4180 - 4190 - 4240 - 4250 - 4260
- 568: Non finalisé. A recaler en 2020. Date en dur / Text29: INJ_6
- 570: Text29: NA
- 571: Text29: NA
- 572: Text29: NA
- 573: Text29: NA
- 574: Text29: T1 - T2 - T3 - T4 - T5 - T6 - T7 - T7 - T8 - T9 -T10 - T11 - T12 - T13 - T14 - T15
- 575: Text29: NA
- 576: Text29: NA
- 577: Text29: NA
- 578: Text29: NA
- 579: Pas de ligne électrique donc compris dans la méca / Text29: NA
- 580: Text29: 916 - 917 - 918 - 918 - 919 - 920 - 921 - T17 - T18 - T19
- 581: Text29: 922 - 923 - 924 - 925
- 582: Text29: 907 - 908 - 909 - 910
- 583: Text29: 90001CV0080 - 90001CV0090 - 90001CV0100 - 90001CV0110 - 90001CV0120 - 90001CV0130 - 90001CV0140 - 90001CV0150 - 90001CV0160 - 90001CV0170 - 90001CV0180 - 90001CV0190 - 90001CV0200 - 90001CV0210 - 90001CV0220
- 584: Durée revue de 6 jours initialement pour MES au 20.12.2019 / Text29: 90001CV0010 - 90001CV0020 - 90001CV0030 - 90001CV0040 - 90001CV0050 - 90001CV0060 - 90001CV0070
- 585: Text29: TRF01CV0010 - TRF01CV0020 - TRF01CV0030 - TRF01LC0040 - TRF01LC0050 - TRF01LC0060 - TRF01LC0070
- 586: Text29: NA
- 587: Text29: NA
- 588: Text29: NA
- 589: Text29: NA
- 590: Text29: NA
- 591: Text29: NA

| ID | WBS | Task | Type | Duration | Start | Finish | Predecessors | Complete | Remaining | Total slack | Free slack | Constraint | Resources | Work | Cost | Text1 | Text12 | Text21 | Text26 | Acteur | Coordonnées | Text13 | Etage | Text25 | name 2 | Text27 |
| --- | --- | --- | --- | --- | --- | --- | --- | --- | --- | --- | --- | --- | --- | --- | --- | --- | --- | --- | --- | --- | --- | --- | --- | --- | --- | --- |
| 592 | 3.1.5.3 | **Phase 4** |  | 62d | 2019-10-22 A | 2020-01-17 |  | 3% | 59.93d | 0d |  |  |  |  |  | BHS | Blank | NA | Blank |  |  |  |  |  |  |  |
| 593 | 3.1.5.3.1 | **Travaux Fonction C5 - ARRIVEE** |  | 62d | 2019-10-22 A | 2020-01-17 |  | 4% | 59.62d | 0d |  |  |  |  |  | BHS | Blank | NA | Blank |  |  |  |  |  |  |  |
| 594 | 3.1.5.3.1.1 | JZ21.09VL-Mise à disposition sol pour installation ligne et carrousel 7 | milestone | 0d | 2019-11-05 | 2019-11-05 | 562FS+15d |  |  | 22d | 0d |  |  |  |  | BLC | Blank | NA | Blank | ET | 13-16/EI | 2.1 | SS01 |  |  |  |
| 595 | 3.1.5.3.1.2 | Installation Lignes arrivée C5-C7 (gare de triage) |  | 15d | 2019-11-04 | 2019-11-22 | 574, 537 |  |  | 25d | 0d | start no earlier than 2019-11-04 |  |  |  | BHS | Installation | C5;C7 | Installation | INT | 22-28/AC | 3.2 | RZ00 |  |  |  |
| 596 | 3.1.5.3.1.3 | Installation Ligne C7 (local technique) |  | 5d | 2019-11-19 | 2019-11-25 | 561 |  |  | 0d |  |  |  |  |  | BHS | Installation | C7 | Installation | INT | 13-17/DF | 3.2 | RZ00 |  |  |  |
| 597 | 3.1.5.3.1.4 | Installation Ligne C7 (gare de triage) |  | 6d | 2019-11-25 | 2019-12-02 | 595, 583, 537 |  |  | 25d |  |  |  |  |  | BHS | Installation | C7 | Installation | INT | 17-22/BD | 3.2 | RZ00 |  |  |  |
| 598 | 3.1.5.3.1.5 | Installation Ligne C7 (couloir porte C) |  | 5d | 2019-10-22 A | 2019-10-28 | 555 | 50% | 2.5d | 50d |  |  |  |  |  | BHS | Installation | C7 |  | INT | 14-17/D | 2.2 | RZ00 | Arrivée |  |  |
| 599 | 3.1.5.3.1.6 | Installation Ligne et carrousel C7 |  | 22d | 2019-11-06 | 2019-12-05 | 594, 471 |  |  | 22d |  |  |  |  |  | BHS | Installation | C7 | Installation | INT | 13-16/EI | 3.2 | SS01 |  |  |  |
| 600 | 3.1.5.3.1.7 | Reliquat activités C7 et carrousel de 2019 et montage C5 trottoir |  | 3d | 2020-01-06 | 2020-01-08 | 366FS-1d |  |  | 0d |  |  |  |  |  |  |  | C7 |  | INT |  |  |  |  |  |  |
| 601 | 3.1.5.3.1.8 | Montage 2 écrans carrousel 7 par NEO Advertising |  | 2d | 2020-01-07 | 2020-01-08 | 600FS-2d |  |  | 0d |  |  |  |  |  | BLC | Blank | NA |  | GA |  |  |  |  |  |  |
| 602 | 3.1.5.3.1.9 | Test Ligne arrivée C7 |  | 6d | 2020-01-09 | 2020-01-16 | 595, 597, 596, 599, 598, 601, 600 |  |  | 0d |  |  |  |  |  | BHS | Commissioning | C7 | Commissioning | INT |  |  |  |  |  |  |
| 603 | 3.1.5.3.1.10 | VABF Ligne arrivée C7 (B.F. LIV n°7) |  | 1d | 2020-01-17 | 2020-01-17 | 602 |  |  | 0d |  |  |  |  |  | BHS | Blank | C7 | Blank | INT/IS/GA |  |  |  |  |  |  |
| 604 | 3.1.5.3.1.11 | Mise en service Ligne arrivée C7 (B.F. LIV n°7) | milestone | 0d | 2020-01-17 | 2020-01-17 | 603 |  |  | 0d |  |  |  |  |  | BHS | Working | C7 | Working | INT |  |  |  |  |  |  |
| 605 | 3.1.5.3.2 | **Travaux Fonction C1 - ENREGISTREMENTS** |  | 10d | 2019-11-19 | 2019-12-02 |  |  |  | 0d |  |  |  |  |  | BHS | Blank | NA | Blank |  |  |  |  |  |  |  |
| 606 | 3.1.5.3.2.1 | Installation ligne HF1 HBS2 (local technique) |  | 10d | 2019-11-19 | 2019-12-02 | 561, 596SS |  |  | 0d |  |  |  |  |  | BHS | Installation | HBS2 | Blank | INT | 15/DE | 2.2 | RZ00 |  |  |  |
| 607 | 3.1.5.4 | **Phase 5** |  | 97d | 2020-01-13 | 2020-05-29 |  |  |  | 0d |  |  |  | 168h | 13,440 | BHS | Blank | NA | Blank |  |  |  |  |  |  |  |
| 608 | 3.1.5.4.1 | **Travaux Fonction C4 - EBS** |  | 58d | 2020-03-03 | 2020-05-26 |  |  |  | -33d | 0d |  |  |  |  | BHS | Blank | NA | Blank |  |  |  |  |  | EBS |  |
| 609 | 3.1.5.4.1.1 | Livraison LEO EBS | milestone | 0d | 2020-03-03 | 2020-03-03 |  |  |  | -6d | 0d | start no earlier than 2020-03-03 |  |  |  | BHS | Blank | NA |  | INT |  |  |  |  |  |  |
| 610 | 3.1.5.4.1.2 | Installation plateforme EBS AIRE C |  | 31d | 2020-04-09 | 2020-05-26 | 498, 609, 458 |  |  | -33d | 0d |  |  |  |  | BHS | Installation | NA | Installation | INT |  |  | SS01 |  | EBS |  |
| 611 | 3.1.5.4.2 | **Travaux Fonction C1 - ENREGISTREMENTS** |  | 70d | 2020-02-17 | 2020-05-27 |  |  |  | -25d | 0d |  |  | 168h | 13,440 | BHS | Blank | NA | Blank |  |  |  |  |  |  |  |
| 612 | 3.1.5.4.2.1 | Consignation ligne d'acheminement 900 au casino | milestone | 0d | 2020-03-02 | 2020-03-02 | 530, 366, 606, 367, 368 |  |  | 0d |  |  |  |  |  | BLC | Blank | NA |  | GA |  |  |  |  |  |  |
| 613 | 3.1.5.4.2.2 | Démontage ligne 900 au dessus du collecteur 900 et 0000 |  | 7d | 2020-03-03 | 2020-03-11 | 612 |  |  | 0d |  |  | Méca 1; Méca 2; Méca 3 | 168h | 13,440 | BHS | Dismounting | 900 |  | INT | 7-11/G | 2.2 | RZ00 |  |  | 3 méca |
| 614 | 3.1.5.4.2.3 | Installation ligne d'acheminement G10/G15/G17 (HBS6) au dessus du collecteur 900 et 0000 |  | 15d | 2020-03-12 | 2020-04-01 | 613 |  |  | 0d |  |  |  |  |  | BHS | Installation | HBS6 |  | INT | 7-11/G | 2.2 | RZ00 |  |  | 2 méca + 2 élec |
| 615 | 3.1.5.4.2.4 | Jalon GA : Mise à disposition EDS BS1 | milestone | 0d | 2020-04-20 | 2020-04-20 |  |  |  | 0d |  | must start on 2020-04-20 |  |  |  | BLC | Blank | NA |  | GA |  |  |  |  |  |  |
| 616 | 3.1.5.4.2.5 | Modification informatique sur la table à rouleaux du SAS Lausanne |  | 2d | 2020-04-08 | 2020-04-09 | 618SS-2d |  |  | 0d |  |  |  |  |  | BLC | Blank | NA |  | GA |  |  |  |  |  |  |
| 617 | 3.1.5.4.2.6 | Modification du SAS Lausanne mécanique et inversion du sens de prise de bagage |  | 2d | 2020-04-14 | 2020-04-15 | 616 |  |  | 0d |  |  |  |  |  | BLC | Installation | Lausanne |  | GA |  |  |  |  |  |  |
| 618 | 3.1.5.4.2.7 | Installation ligne BS1 |  | 8d | 2020-04-14 | 2020-04-23 | 615FS-4d, 502 |  |  | -31d | 0d |  |  |  |  | BHS | Installation | BS1 |  | INT |  |  |  |  |  | 1 méca + 1 élec |
| 619 | 3.1.5.4.2.8 | Installation informatique local opérateur pour BS1 |  | 10d | 2020-04-20 | 2020-05-01 | 615 |  |  | -37d | 0d |  |  |  |  | BHS | Blank | BS1 |  | GA |  |  |  |  |  |  |
| 620 | 3.1.5.4.2.9 | Test Ligne BS1 |  | 1d | 2020-05-04 | 2020-05-04 | 619, 618 |  |  | -37d | 0d |  |  |  |  | BHS | Commissioning | BS1 |  | INT |  |  |  |  |  |  |
| 621 | 3.1.5.4.2.10 | VABF Ligne BS1 (B.F. BS1) |  | 1d | 2020-05-05 | 2020-05-05 | 620 |  |  | -37d | 0d |  |  |  |  | BHS | Blank | BS1 | Blank | INT |  |  |  |  |  |  |
| 622 | 3.1.5.4.2.11 | Consignation Check-In groupe 3000 | milestone | 0d | 2020-05-05 | 2020-05-05 | 621 |  |  | -37d | 0d |  |  |  |  | BLC | Blank | NA |  | GA |  |  |  |  |  |  |
| 623 | 3.1.5.4.2.12 | Démontage de 2 Check-In 3000 et raccourcissement collecteur |  | 5d | 2020-05-06 | 2020-05-12 | 622 |  |  | -37d | 0d |  |  |  |  | BHS | Installation | 3000 |  | INT |  |  |  |  |  | 1 méca + 1 élec |
| 624 | 3.1.5.4.2.13 | Mise en service Check-In 3000 (G55) | milestone | 0d | 2020-05-12 | 2020-05-12 | 623 |  |  | -37d | 0d |  |  |  |  | BHS | Commissioning | NA |  | INT |  |  |  |  |  |  |
| 625 | 3.1.5.4.2.14 | Mise à disposition de la zone Check-In 3000 pour démontage cloison, création mur et plafond pour rendre la zone sécurisée | milestone | 0d | 2020-05-12 | 2020-05-12 | 624 |  |  | -37d | 0d |  |  |  |  | BHS | Blank | NA |  | INT |  |  |  |  |  |  |
| 626 | 3.1.5.4.2.15 | Mur réalisé et accès BS1 disponible | milestone | 0d | 2020-05-19 | 2020-05-19 | 625FS+5d |  |  | -37d | 0d |  |  |  |  | BLC | Blank | NA |  | ET |  |  |  |  |  |  |
| 627 | 3.1.5.4.2.16 | Mise en service Ligne BS1 (B.F. BS1) | milestone | 0d | 2020-05-19 | 2020-05-19 | 621, 626 |  |  | -37d | 0d |  |  |  |  | BHS | Working | BS1 | Working | INT/IS/GA |  |  |  |  |  |  |
| 628 | 3.1.5.4.2.17 | Installation mécanique, électrique et test ligne BS2 |  | 5d | 2020-04-14 | 2020-04-20 | 618SS |  |  | 0d |  |  |  |  |  | BLC | Blank | BS2 |  | GA |  |  |  |  |  |  |
| 629 | 3.1.5.4.2.18 | Mise en service ligne BS2 | milestone | 0d | 2020-04-20 | 2020-04-20 | 628 |  |  | 0d |  |  |  |  |  | BLC | Working | BS2 |  | GA |  |  |  |  |  |  |
| 630 | 3.1.5.4.2.19 | Consignation SAS Lausanne | milestone | 0d | 2020-05-19 | 2020-05-19 | 627 |  |  | -37d | 0d |  |  |  |  | BLC | Stopped | NA | Stopped | GA |  |  |  |  |  |  |
| 631 | 3.1.5.4.2.20 | Demontage SAS Lausanne |  | 5d | 2020-05-20 | 2020-05-27 | 630 |  |  | -37d | 0d |  |  |  |  | BHS | Dismounting | Lausanne | Dismounting | INT |  |  |  |  |  | 1 méca + 1 élec |
| 632 | 3.1.5.4.2.21 | Mise à disposition zone gare de triage pour création des 2 trémies principales | milestone | 0d | 2020-05-27 | 2020-05-27 | 631 |  |  | -37d | 0d |  |  |  |  | BHS | Blank | NA |  | INT |  |  |  |  |  |  |
| 633 | 3.1.5.4.2.22 | Installation ligne HF1 (HBS2), ligne d'acheminement G20, G25 (HBS3) dans couloir derrière 900 |  | 12d | 2020-04-02 | 2020-04-21 | 368, 614 |  |  | 0d |  |  |  |  |  | BHS | Installation | HBS2;HBS3 | Installation | INT | 5-14/G | 2.2 | RZ00 |  |  | 6 méca + 4 élec |
| 634 | 3.1.5.4.2.23 | Mise à disposition couloir Porte C (Faux plafond démontés) pour installation ligne HF1 | milestone | 0d | 2020-02-17 | 2020-02-17 | 636SF |  |  | 0d |  |  |  |  |  | BLC | Blank | NA |  | ET |  |  |  |  |  |  |
| 635 | 3.1.5.4.2.24 | Installation 2 lignes départ HF1-HF2 en même temps que le montage de la ligne C6 (coté sud gare de triage) |  | 10d | 2020-02-17 | 2020-02-28 | 650, 653SS |  |  | 0d |  |  |  |  |  | BHS | installation | HBS2;HBS3 |  | INT | 16-30/E |  | RZ00 |  |  | 4 méca + 4 élec |
| 636 | 3.1.5.4.2.25 | Installation ligne départ HF1 (HBS2) couloir porte C |  | 5d | 2020-02-17 | 2020-02-21 | 635SS |  |  | 0d |  |  |  |  |  | BHS | installation | HBS2 |  | INT | 15-17/E |  | RZ00 |  |  | 2 méca + 1 élec |

Notes:
- 592: Text29: NA
- 593: Meca compris elec / Text29: NA
- 594: Text29: NA
- 595: Text29: ARR05CV0010 - ARR05CV0020 - ARR05CV0030 - ARR05CV0050 - ARR05CV0060 - ARR05CV0070 - ARR05CV0080 - ARR07CV0010 - ARR07CV0020 - ARR07CV0030 - ARR07CV0040 - ARR07CV0060 - ARR07CV0070 - ARR07CV0080
- 596: Text29: ARR07CV0160 - ARR07CV0170 - ARR07CV0180 - ARR07CV0190 - ARR07CV0200 - ARR07VI0200 - ARR07VF0200
- 597: Text29: ARR07CV0090 - ARR07CV0100 - ARR07VS0110 - ARR07CV0110 - ARR07CV0120 - ARR07VI0120 - ARR07CV0120 - ARR07CV0130 - ARR07CV0140
- 598: Text29: ARR07CV0150
- 599: Text29: ARR07CV0210 - ARR07CV0220 - ARR07CV0230 - ARR07CV0240 - ARR07CV0250 - ARR07CV0260 - ARR07CA0270
- 601: Text29: NA
- 602: Text29: NA
- 603: Durée revue à la baisse 5 à 1j / Text29: NA
- 604: Date revue au 22.01.2020 / Text29: NA
- 605: Text29: NA
- 606: Text29: HSB02CV0120 - HSB02CV0130 - HSB02CV0140 - HSB02CV0150 - HSB02CV0160
- 607: Text29: NA
- 608: Text29: NA
- 611: Text29: NA
- 612: Text29: NA
- 613: Text29: 56 mètres
- 614: En lieu et place de la ligne existante / Text29: 6 convoyeurs, 50 mètres
- 615: Text29: NA
- 618: Text29: 3 convoyeurs, 5 mètres + 1 roller
- 619: Text29: NA
- 621: Text29: NA
- 622: Text29: NA
- 624: Text29: NA
- 625: Text29: NA
- 626: Text29: NA
- 627: Text29: NA
- 628: Text29: NA
- 629: Text29: NA
- 630: Text29: NA
- 631: Text29: 9 convoyeurs, 20 mètres
- 632: Text29: NA
- 633: Text29: 20 convoyeurs, 104 mètres + 6 courbes + 1 merge
- 634: Imposition INT / Text29: NA
- 635: Text29: 12 convoyeurs, 65 mètres + 1 merge + 3 courbes
- 636: Text29: 1 convoyeur, 10 mètres

| ID | WBS | Task | Type | Duration | Start | Finish | Predecessors | Total slack | Free slack | Constraint | Text1 | Text12 | Text21 | Text26 | Text29 | Acteur | Coordonnées | Text13 | Etage | Text27 |
| --- | --- | --- | --- | --- | --- | --- | --- | --- | --- | --- | --- | --- | --- | --- | --- | --- | --- | --- | --- | --- |
| 637 | 3.1.5.4.3 | **Travaux Fonction C5 - ARRIVEE** |  | 72d | 2020-01-13 | 2020-04-23 |  | -3d | 0d |  | BHS | Blank | NA | Blank | NA |  |  |  |  |  |
| 638 | 3.1.5.4.3.1 | Consignation Ligne speciaux | milestone | 0d | 2020-01-20 | 2020-01-20 | 550, 366, 642FS+1d | 0d |  |  | BLC | Stopped | NA | Stopped | NA | GA |  |  |  |  |
| 639 | 3.1.5.4.3.2 | Démontage convoyeur de livraison Ligne Spéciaux (1ère partie) |  | 2d | 2020-01-20 | 2020-01-21 | 638FS-1d | 0d |  |  | BHS | Dismounting | Spéciaux |  | S-1; 1 convoyeur, 4 mètres | INT | 19/D | 2.1 | SS01 | 1 méca + 1 élec |
| 640 | 3.1.5.4.3.3 | Démontage convoyeur Ligne Spéciaux (2ème partie) |  | 5d | 2020-01-22 | 2020-01-28 | 639 | 0d |  |  | BHS | Dismounting | Spéciaux |  | S-3 | INT | 20D | 2.1 | SS01 |  |
| 641 | 3.1.5.4.3.4 | JZ21.10LV-Mise à disposition zone RZ00 pour rebouchage trémie Ligne Spé | milestone | 0d | 2020-01-28 | 2020-01-28 | 639, 640 | 0d |  |  | BHS | Blank | NA | Blank | NA | INT | 19/D | 3.2 | RZ00 |  |
| 642 | 3.1.5.4.3.5 | Remplacer les 2 convoyeurs à partir de 13h (prévoir travaux jour et nuit de la ligne ski) dimension 1200 avec arrêt du carrousel 7 |  | 5d | 2020-01-13 | 2020-01-17 | 366 | 0d |  | start no earlier than 2020-01-13 | BLC | Installation | NA |  | 2 convoyeurs 15 mètres | INT |  |  |  | 4 méca + 1 élec |
| 643 | 3.1.5.4.3.6 | Démonter la chute 72 dans IATA |  | 5d | 2020-01-13 | 2020-01-17 | 366FS+4d | 0d |  |  | BLC | Dismounting | NA |  |  | INT |  |  |  | 1 méca + 1 élec |
| 644 | 3.1.5.4.3.7 | Consignation Ligne arrivée 6 | milestone | 0d | 2020-01-27 | 2020-01-27 | 604, 366FS+15d | -3d | 0d |  | BLC | Stopped | NA | Stopped | NA | GA |  |  |  |  |
| 645 | 3.1.5.4.3.8 | Démontage 2 écrans carrousel 6 par NEO Advertising |  | 1d | 2020-01-27 | 2020-01-27 | 655SS-1d | 0d |  |  | BLC | Blank | NA |  | NA | GA |  |  |  |  |
| 646 | 3.1.5.4.3.9 | Consignation Ligne Meyrin | milestone | 0d | 2020-01-27 | 2020-01-27 | 366FS+15d | 9d | 0d |  | BLC | Stopped | NA | Stopped | NA | GA |  |  |  |  |
| 647 | 3.1.5.4.3.10 | Demontage SAS Meyrin |  | 10d | 2020-01-27 | 2020-02-07 | 646SS-1d | 0d |  |  | BHS | Dismounting | Meyrin | Dismounting | 7 convoyeurs, 18 mètres | INT | 16-17/GF |  | RZ00 | 1 méca + 1 élec |
| 648 | 3.1.5.4.3.11 | Démontage ligne arrivée 6 |  | 4d | 2020-01-27 | 2020-01-30 | 644SS-1d | 0d |  |  | BHS | Dismounting | C6 |  | 5 convoyeurs, 15 mètres |  | 22-26/C |  | RZ00 | 1 méca + 1 élec |
| 649 | 3.1.5.4.3.12 | Démontage caisson ligne 6 gare de triage |  | 1d | 2020-01-31 | 2020-01-31 | 648 | 0d |  |  | BLC | Dismounting | NA |  |  | ET |  |  |  |  |
| 650 | 3.1.5.4.3.13 | Mise à disposition mur gare de triage/porte C pour modification mur + création mur CF + création 2 ouvertures + montage HF1 HF2 | milestone | 0d | 2020-02-07 | 2020-02-07 | 647, 649 | 0d |  |  | BLC | Blank | NA |  | NA | INT |  |  |  |  |
| 651 | 3.1.5.4.3.14 | Fin de travaux mur gare de triage/porte C : modification mur + création mur CF + création 2 ouvertures | milestone | 0d | 2020-02-28 | 2020-02-28 | 650FS+15d | 0d |  |  | BHS | Blank | NA |  | NA | ET |  |  |  |  |
| 652 | 3.1.5.4.3.15 | Installation Ligne arrivée C6 et arrivée C4 (partie Nord gare de triage) |  | 10d | 2020-02-03 | 2020-02-14 | 642, 649 | 0d |  |  | BHS | Installation | C6;C4 | Installation | 12 convoyeurs, 55 mètres + 2 courbes | INT | 22-26/C | 3.2 | RZ00 | 3 méca |
| 653 | 3.1.5.4.3.16 | Installation ligne arrivée C6 (partie Sud gare de triage) |  | 10d | 2020-02-17 | 2020-02-28 | 652 | 0d |  |  | BHS | Installation | C6 |  | 9 convoyeurs, 42 mètres + 5 courbes | INT | 17-21/CF | 3.2 | RZ00 | 3 méca |
| 654 | 3.1.5.4.3.17 | Installation électrique ligne arrivée C6 gare de triage |  | 20d | 2020-02-17 | 2020-03-13 | 652 | 13d |  |  | BHS | Installation | C6 |  |  | INT | 17-21/CF | 3.2 | RZ00 | 3 élec |
| 655 | 3.1.5.4.3.18 | Demontage carrousel 6 + ligne d'acheminement |  | 10d | 2020-01-28 | 2020-02-10 | 644 | -3d | 0d |  | BHS | Dismounting | C6 | Dismounting | 1 carrousel + 4 convoyeurs, 18 mètres | INT | 16-17/EI | 3.2 | SS01 | 5 méca + 1 élec |
| 656 | 3.1.5.4.3.19 | Mise à disposition pour finition zone arrivée 6 (sol, affichage...) | milestone | 0d | 2020-02-10 | 2020-02-10 | 655 | -3d | 0d |  | BLC | Blank | NA |  | NA | INT |  |  |  |  |
| 657 | 3.1.5.4.3.20 | Mise à disposition sol pour installation ligne et carrousel 6 | milestone | 0d | 2020-03-02 | 2020-03-02 | 656FS+15d | -3d | 0d |  | BHS | Blank | NA |  | NA | ET |  |  |  |  |
| 658 | 3.1.5.4.3.21 | Installation ligne + carrousel C6 |  | 15d | 2020-03-03 | 2020-03-23 | 657 | -3d | 0d |  | BHS | Installation | C6 |  | 2 convoyeurs 6 mètres + 1 carrousel | INT | 17-27/E+15-17/EI |  | SS01 | 4 méca |
| 659 | 3.1.5.4.3.22 | Installation électrique ligne + carrousel 6 |  | 10d | 2020-03-24 | 2020-04-06 | 658 | -3d | 0d |  | BHS | Installation | C6 |  |  | INT | 17-27/E+15-17/EI |  | SS01 | 4 élec |
| 660 | 3.1.5.4.3.23 | Montage 2 écrans carrousel 6 par NEO Advertising |  | 2d | 2020-04-03 | 2020-04-06 | 659FS-2d | -3d | 0d |  | BLC | Blank | NA |  | NA | GA |  |  |  |  |
| 661 | 3.1.5.4.3.24 | Mise à disposition zone trémie C6 pour création caisson coupe-feu + démontage des faux plafonds | milestone | 0d | 2020-02-07 | 2020-02-07 | 647, 649 | 8d | 0d |  | BLC | Blank | NA |  | NA | INT |  |  |  |  |
| 662 | 3.1.5.4.3.25 | Fin de réalisation caisson coupe-feu ligne arrivée 6 + faux plafonds démontés | milestone | 0d | 2020-02-21 | 2020-02-21 | 661FS+10d | 8d | 5d |  | BHS | Blank | NA |  | NA | ET |  |  |  |  |
| 663 | 3.1.5.4.3.26 | Installation convoyeur trémie C6 + CF + volet AI |  | 20d | 2020-03-02 | 2020-03-27 | 662, 653 | 3d |  |  | BHS | Installation | C6 |  | 2 convoyeurs 14 mètres | INT | 17/G | 3.2 | RZ00 | 1 méca + 1 élec |
| 664 | 3.1.5.4.3.27 | Test Ligne arrivée C6 |  | 10d | 2020-04-07 | 2020-04-22 | 652, 653, 663, 654, 658, 659, 660 | -3d | 0d |  | BHS | Commissioning | C6 | Commissioning | NA | INT |  |  |  | 1 automaticien + 1 élec |
| 665 | 3.1.5.4.3.28 | VABF Ligne arrivée C6 (B.F. LIV n°6) |  | 1d | 2020-04-23 | 2020-04-23 | 664 | -3d | 0d |  | BHS | Blank | C6 | Blank | NA | INT/IS/GA |  |  |  | 1 automaticien |
| 666 | 3.1.5.4.3.29 | Mise en service Ligne arrivée C6 (B.F. LIV n°6) | milestone | 0d | 2020-04-23 | 2020-04-23 | 665 | -3d | 0d |  | BHS | Working | C6 | Working | NA | INT |  |  |  |  |

Notes:
- 638: Activité déplacées avancement prod
- 643: +jours en dur
- 644: +jours en dur livraison matériel. Consignation plûtot le 20.01 nouvel année russe
- 646: +jours en dur livraison matériel
- 648: +jours en dur livraison matériel
- 650: INTEGRER NOUVEAU PHASAGE C6 COUPE-FEU
- 651: INTEGRER NOUVEAU PHASAGE C6 COUPE-FEU
- 652: +jours en dur livraison matériel

| ID | WBS | Task | Type | Duration | Start | Finish | Predecessors | Total slack | Free slack | Constraint | Text1 | Text12 | Text21 | Text26 | Text29 | Acteur | Text27 | Coordonnées | Text13 | Etage |
| --- | --- | --- | --- | --- | --- | --- | --- | --- | --- | --- | --- | --- | --- | --- | --- | --- | --- | --- | --- | --- |
| 667 | 3.1.5.4.4 | **Travaux Fonction C3 - TRI** |  | 30d | 2020-04-17 | 2020-05-29 |  | 0d |  |  | BHS | Blank | NA | Blank | NA |  |  |  |  |  |
| 668 | 3.1.5.4.4.1 | Installation plateforme partielle IATA pour injection Trieur Nord (HBS3-HBS4-HBS5) |  | 10d | 2020-04-17 | 2020-04-30 | 504, 572 | 65d | 0d |  | BHS | Installation | NA |  |  | INT |  |  |  |  |
| 669 | 3.1.5.4.4.2 | Installation Trieur Nord (1/2) |  | 30d | 2020-04-17 | 2020-05-29 | 504 | 0d |  |  | BHS | Installation | NA | Installation | 60 mètres de trieur côté gauche IATA | INT | 2 méca + 2 élec |  |  |  |
| 670 | 3.1.5.5 | **Phase 6** |  | 72d | 2020-03-30 | 2020-07-13 |  | 0d |  |  | BHS | Blank | NA |  | NA |  |  |  |  |  |
| 671 | 3.1.5.5.1 | **Travaux Fonction C1 - ENREGISTREMENTS** |  | 53d | 2020-03-30 | 2020-06-16 |  | 0d |  |  | BHS | Blank | NA | Blank | NA |  |  |  |  |  |
| 672 | 3.1.5.5.1.1 | Arrêt possible Check-In à partir du 30.03.2020 | milestone | 0d | 2020-03-30 | 2020-03-30 |  | 0d |  | must start on 2020-03-30 | BLC | Stopped | NA | Stopped | NA | GA |  |  |  |  |
| 673 | 3.1.5.5.1.2 | Zone disponible pour montage cloison partielle | milestone | 0d | 2020-03-30 | 2020-03-30 | 672 | 8d |  |  | BHS | Blank | NA |  | NA | INT |  |  |  |  |
| 674 | 3.1.5.5.1.3 | Consignation Check-In 0900 | milestone | 0d | 2020-04-02 | 2020-04-02 | 672, 633SS | 0d |  |  | BLC | Stopped | NA | Stopped | NA | GA |  |  |  |  |
| 675 | 3.1.5.5.1.4 | Demontage convoyeur Check-In 0900 |  | 5d | 2020-04-02 | 2020-04-08 | 674 | 0d |  |  | BHS | Dismounting | 900 | Dismounting | 30 convoyeurs, 50 mètres + 16 Check-In | INT | 5 méca + 1 élec | 7-11/G | 2.2 | RZ00 |
| 676 | 3.1.5.5.1.5 | Demontage collecteur banques 0900 + boucle 360 |  | 5d | 2020-04-09 | 2020-04-17 | 675 | 0d |  |  | BHS | Dismounting | 900 | Dismounting | 4 courbes + 1 convoyeur de 28 mètres | INT | 2 méca + 1 élec | 5-11/G | 2.2 | RZ00 |
| 677 | 3.1.5.5.1.6 | Mise à disposition zone pour finir le montage de la cloison et caisson côté publique création coté G25 | milestone | 0d | 2020-04-17 | 2020-04-17 | 676, 673FS+5d | 0d |  |  | BHS | Blank | NA |  | NA | INT |  |  |  |  |
| 678 | 3.1.5.5.1.7 | Mise à disposition zone G17-G20-G25 pour installation ligne (cloison checkin terminée) | milestone | 0d | 2020-05-01 | 2020-05-01 | 677FS+10d | 0d |  |  | BLC | Blank | NA |  | NA | ET |  |  |  |  |
| 679 | 3.1.5.5.1.8 | Installation mécanique collecteur G25 + ligne d'acheminement |  | 6d | 2020-05-04 | 2020-05-11 | 678, 401 | 0d |  |  | BHS | Installation | HBS3 |  | 1 convoyeur, 10 mètres + 1 courbe + 6 Check-In | INT | 3 méca | 8-11/G | 2.2 | RZ00 |
| 680 | 3.1.5.5.1.9 | Installation banque G25 partielle |  | 6d | 2020-05-12 | 2020-05-19 | 679 | 0d |  |  | BLC |  | HBS3 |  |  | ET | A supprimer cette ligne car pas de CI LEO |  |  |  |
| 681 | 3.1.5.5.1.10 | Installation volet ligne G25 |  | 1d | 2020-05-20 | 2020-05-20 | 680 | 0d |  |  | BHS |  | HBS3 |  |  | INT | 2 méca |  |  |  |
| 682 | 3.1.5.5.1.11 | Installation électrique collecteurs + volet |  | 5d | 2020-05-22 | 2020-05-28 | 679, 681 | 0d |  |  | BHS | Installation | HBS3 |  |  | INT | 3 élec | 8-11/G | 2.2 | RZ00 |
| 683 | 3.1.5.5.1.12 | Modification ligne dans local technique pour que G17-G20-G25 depuis le couloir se jette dans la 900 provisoire |  | 3d | 2020-05-20 | 2020-05-25 | 681SS | 3d |  |  | BHS | Installation | HBS3 |  |  | INT |  |  |  |  |
| 684 | 3.1.5.5.1.13 | Test Check-In G25 sur installation existante au Casino |  | 10d | 2020-05-29 | 2020-06-12 | 682, 683 | 0d |  |  | BHS | Commissioning | HBS3 | Commissioning | NA | INT | 1 automaticien + 1 élec |  |  |  |
| 685 | 3.1.5.5.1.14 | VABF Check-In G25 sur installation existante au Casino |  | 2d | 2020-06-15 | 2020-06-16 | 684 | 0d |  |  | BHS | Blank | HBS3 | Blank | NA | INT/IS/GA | 1 automaticien |  |  |  |
| 686 | 3.1.5.5.1.15 | Mise en service Check-In G25 sur installation existante au Casino | milestone | 0d | 2020-06-16 | 2020-06-16 | 685 | 0d |  |  | BHS | Working | HBS3 | Working | NA | INT |  |  |  |  |
| 687 | 3.1.5.5.1.16 | Installation Check-In Hors Format HF1 (HBS2) |  | 5d | 2020-05-26 | 2020-06-02 | 710, 633 | 0d |  |  | BHS | Installation | HF1 | Installation | 2 Check-In HF + 1 merge + 2 convoyeurs 6 mètre + 1 courbe | INT | 4 méca + 4 élec | 11-14/G | 2.2 | RZ00 |
| 688 | 3.1.5.5.2 | **Travaux Fonction C3 - TRI** |  | 30d | 2020-06-02 | 2020-07-13 |  | 0d |  |  | BHS | Blank | NA | Blank | NA |  |  |  |  |  |
| 689 | 3.1.5.5.2.1 | Installation Trieur Nord partiel (suite) |  | 30d | 2020-06-02 | 2020-07-13 | 669 | 0d |  |  | BHS | Installation | NA | Installation | 138 mètres de trieur continuation partie sup/inf milieu IATA | INT | 4 méca + 4 élec |  |  |  |
| 690 | 3.1.5.5.3 | **Travaux Fonction C5 - ARRIVEE** |  | 42d | 2020-04-23 | 2020-06-24 |  | -3d | 0d |  | BHS | Blank | NA | Blank | NA |  |  |  |  |  |
| 691 | 3.1.5.5.3.1 | Consignation Ligne arrivée 5 et transfert 5 | milestone | 0d | 2020-04-23 | 2020-04-23 | 666 | -3d | 0d |  | BLC | Stopped | NA | Stopped | NA | GA |  |  |  |  |
| 692 | 3.1.5.5.3.2 | Démontage Ligne Transfert 5 |  | 2d | 2020-04-24 | 2020-04-27 | 691 | 7d |  |  | BHS | Dismounting | TR5 | Dismounting | 6 convoyeurs + 1 déviateur horizontal, 20 mètres | INT | 2 méca + 1 élec |  |  |  |
| 693 | 3.1.5.5.3.3 | Démontage ligne arrivée 5 gare de triage |  | 5d | 2020-04-24 | 2020-04-30 | 691 | -3d | 0d |  | BHS | Dismounting | C5 | Dismounting | 2 convoyeurs + 1 volet, 11 mètres | INT | 1 méca + 1 élec |  |  |  |
| 694 | 3.1.5.5.3.4 | Démontage caisson ligne 5 gare de triage |  | 1d | 2020-05-01 | 2020-05-01 | 693 | -3d | 0d |  | BLC | Dismounting | NA |  |  | ET |  |  |  |  |
| 695 | 3.1.5.5.3.5 | Installation Ligne arrivée C5 solde (partie Nord gare de triage) |  | 3d | 2020-05-04 | 2020-05-06 | 694 | -3d | 0d |  | BHS | Installation | C5 |  | 4 convoyeurs, 24 mètres | INT | 4 méca |  |  |  |
| 696 | 3.1.5.5.3.6 | Installation ligne arrivée C5 (partie Sud gare de triage) |  | 4d | 2020-05-07 | 2020-05-12 | 695, 692 | 0d |  |  | BHS | Installation | C5 |  | 6 convoyeurs, 22 mètres + 3 courbes | INT | 4 méca |  |  |  |
| 697 | 3.1.5.5.3.7 | Installation 3 lignes départ HBS3, HBS2, HBS5 (G20+G25,HF1+HF2,G30+G35) en même temps que le montage de la ligne C5 (coté sud gare de triage) |  | 6d | 2020-05-07 | 2020-05-14 | 696SS | 0d |  |  | BHS | Installation | HBS2;HBS3;HBS5;C5 |  | 8 convoyeurs, 50 mètres + 5 courbes | INT | 4 méca + 4 élec |  |  |  |
| 698 | 3.1.5.5.3.8 | Installation électrique ligne arrivée C5 gare de triage |  | 5d | 2020-05-07 | 2020-05-13 | 695 | -3d | 0d |  | BHS | Installation | C5 |  |  | INT | 6 élec |  |  |  |
| 699 | 3.1.5.5.3.9 | Modification électrique ligne carrousel |  | 7d | 2020-05-14 | 2020-05-25 | 698 | -3d | 0d |  | BHS | Installation | C5 | Installation |  | INT | 4 élec |  |  | SS01 |
| 700 | 3.1.5.5.3.10 | Mise à disposition zone C5 pour création caisson coupe-feu + démontage des faux plafonds | milestone | 0d | 2020-05-01 | 2020-05-01 | 694 | 0d |  |  | BHS | Blank | NA |  | NA | INT |  |  |  |  |
| 701 | 3.1.5.5.3.11 | Fin de réalisation caisson coupe feu ligne arrivée C5 + faux plafonds démontés | milestone | 0d | 2020-05-15 | 2020-05-15 | 700FS+10d | 0d |  |  | BLC | Blank | NA |  |  | ET |  |  |  |  |
| 702 | 3.1.5.5.3.12 | Installation convoyeur trémie C5 + CF + volet AI |  | 2d | 2020-05-18 | 2020-05-19 | 701, 696 | 0d |  |  | BHS | Installation | C5 |  | 1 convoyeur 1 mètre | INT | 1 méca + 1 élec |  |  |  |
| 703 | 3.1.5.5.3.13 | Test Ligne arrivée C5 |  | 18d | 2020-05-26 | 2020-06-19 | 695, 696, 702, 699, 698 | -3d | 0d |  | BHS | Commissioning | C5 |  | NA | INT | 1 automaticien + 1 élec |  |  |  |
| 704 | 3.1.5.5.3.14 | VABF Ligne arrivée C5 (B.F. LIV n°5) |  | 3d | 2020-06-22 | 2020-06-24 | 703 | -3d | 0d |  | BHS | Blank | C5 |  | NA | INT | 1 automaticien |  |  |  |
| 705 | 3.1.5.5.3.15 | Mise en service Ligne arrivée C5 (B.F. LIV n°5) | milestone | 0d | 2020-06-24 | 2020-06-24 | 704 | -3d | 0d |  | BHS | Working | C5 |  | NA | INT |  |  |  |  |

Notes:
- 674: Si cette ligne est repoussée en cas de non acceptation de travaux car vacance avril,ne pas oublier de repoussée aussi montage HF1 dans le couloir. C'est mieux pour les ouvriers
- 697: G20 et G25= HBS3, HF1 et HF2=HBS2, G30 et G35=HBS5

| ID | WBS | Task | Type | Duration | Start | Finish | Predecessors | Total slack | Free slack | Text1 | Text12 | Text21 | Text26 | Acteur | Coordonnées | Text13 | Etage | Text27 | name 2 |
| --- | --- | --- | --- | --- | --- | --- | --- | --- | --- | --- | --- | --- | --- | --- | --- | --- | --- | --- | --- |
| 706 | 3.1.5.6 | **Phase 7** |  | 81d | 2020-05-01 | 2020-08-25 |  | -16d | 0d | BHS | Blank | NA | Blank |  |  |  |  |  |  |
| 707 | 3.1.5.6.1 | **Travaux Fonction C1 - ENREGISTREMENTS** |  | 36d | 2020-05-04 | 2020-06-24 |  | 0d |  | BHS | Blank | NA | Blank |  |  |  |  |  |  |
| 708 | 3.1.5.6.1.1 | Installation mécanique et électrique ligne au-dessus des collecteurs + G20-G17 |  | 5d | 2020-05-04 | 2020-05-08 | 678 | 0d |  | BHS | Installation | HBS6 |  | INT | 5-7/G | 2.2 | RZ00 | 2 méca + 2 élec |  |
| 709 | 3.1.5.6.1.2 | Installation mécanique collecteur G20 - G17 + ligne d'acheminement (boucle) solde + volet |  | 5d | 2020-05-11 | 2020-05-15 | 708 | 0d |  | BHS | Installation | HBS6 |  | INT | 5-7/G | 2.2 | RZ00 | 6 méca |  |
| 710 | 3.1.5.6.1.3 | Installation convoyeur de Check-In G20 - G17 |  | 5d | 2020-05-18 | 2020-05-25 | 709 | 0d |  | BHS | Installation | NA |  | INT | 5-7/G | 2.2 | RZ00 | 3 méca |  |
| 711 | 3.1.5.6.1.4 | Installation électrique collecteurs + convoyeur de Check-In + volet G20 - G17 |  | 9d | 2020-05-26 | 2020-06-08 | 710 | 0d |  | BHS | Installation | HBS6 |  | INT | 5-7/G | 2.2 | RZ00 | 6 élec |  |
| 712 | 3.1.5.6.1.5 | Test banques G20-G17 sur installation existante au Casino |  | 10d | 2020-06-09 | 2020-06-22 | 711 | 0d |  | BHS | Commissioning | HBS6 |  | INT/IS/GA |  |  |  | 1 automaticien + 1 élec |  |
| 713 | 3.1.5.6.1.6 | VABF banques G20-G17 sur installation existante au Casino |  | 2d | 2020-06-23 | 2020-06-24 | 712 | 0d |  | BHS | Blank | HBS6 |  | INT/IS/GA |  |  |  | 1 automaticien |  |
| 714 | 3.1.5.6.1.7 | Mise en service banques G20-G17 sur installation existante au Casino (sens G20-G25) | milestone | 0d | 2020-06-24 | 2020-06-24 | 713 | 0d |  | BHS | Working | HBS6 |  | INT |  |  |  |  |  |
| 715 | 3.1.5.6.2 | **Travaux Fonction C3 - TRI** |  | 43d | 2020-05-01 | 2020-07-02 |  | 65d |  | BHS | Blank | NA | Blank |  |  |  |  |  |  |
| 716 | 3.1.5.6.2.1 | Installation lignes d'injection Trieur Nord |  | 15d | 2020-05-01 | 2020-05-22 | 668 | 65d | 0d | BHS | Installation | NA | Installation | INT |  |  |  | 3 méca + 2 élec |  |
| 717 | 3.1.5.6.2.2 | Installation MUP HF |  | 33d | 2020-05-01 | 2020-06-18 | 668 | 148d | 0d | BHS | Installation | NA | Installation | INT |  |  |  | 2 méca + 2 élec |  |
| 718 | 3.1.5.6.2.3 | Test MUP HF |  | 10d | 2020-06-19 | 2020-07-02 | 717 | 148d |  | BHS | Commissioning | NA |  | INT |  |  |  | 1 automaticien + 1 élec |  |
| 719 | 3.1.5.6.3 | **Travaux Fonction C4 - EBS** |  | 50d | 2020-05-27 | 2020-08-05 |  | -33d | 0d | BHS | Blank | NA | Blank |  |  |  |  |  | EBS |
| 720 | 3.1.5.6.3.1 | Installation Lignes EBS AIRE C |  | 50d | 2020-05-27 | 2020-08-05 | 610 | -33d | 0d | BHS | Installation | NA | Installation | INT |  |  | SS02 | 8 méca + 8 élec | EBS |
| 721 | 3.1.5.6.4 | **Travaux Fonction C5 - ARRIVEE** |  | 44d | 2020-06-24 | 2020-08-25 |  | -3d | 0d | BHS | Blank | NA | Blank |  |  |  |  |  |  |
| 722 | 3.1.5.6.4.1 | Installation Ligne d'acheminement secteur France au SS01 sans consignation de la ligne existante (dans couloir) |  | 10d | 2020-07-02 | 2020-07-16 | 792SF | 0d |  | BHS | Installation | Secteur France |  | INT | 27-30/AG |  | SS01 | 2 méca |  |
| 723 | 3.1.5.6.4.2 | Consignation Ligne arrivée 4 et Transfert 4 | milestone | 0d | 2020-06-24 | 2020-06-24 | 705 | -3d | 0d | BLC | Stopped | NA | Stopped | GA |  |  |  |  |  |
| 724 | 3.1.5.6.4.3 | Démontage Ligne Transfert 4 |  | 2d | 2020-06-25 | 2020-06-26 | 723 | -3d | 0d | BHS | Dismounting | C4 | Dismounting | INT |  |  |  | 1 méca + 1 élec |  |
| 725 | 3.1.5.6.4.4 | Démontage ligne arrivée 4 gare de triage |  | 5d | 2020-06-29 | 2020-07-03 | 724 | -3d | 0d | BHS | Dismounting | C4 | Dismounting | INT |  |  |  | 1 méca |  |
| 726 | 3.1.5.6.4.5 | Démontage caisson ligne 4 gare de triage |  | 1d | 2020-07-06 | 2020-07-06 | 725 | -3d | 0d | BLC | Dismounting | NA |  | ET |  |  |  |  |  |
| 727 | 3.1.5.6.4.6 | Installation ligne arrivée C4 (partie Sud gare de triage) |  | 6d | 2020-07-07 | 2020-07-14 | 726 | -3d | 0d | BHS | Installation | C4 |  | INT |  |  |  | 3 méca |  |
| 728 | 3.1.5.6.4.7 | Installation ligne départ 4 lignes : HBS3, HBS2, HBS5, HBS6 (G20+G25, HF1+HF2, G30+G35, G10+G15+G17) en même temps que le montage de la ligne C4 (coté sud gare de triage) |  | 6d | 2020-07-07 | 2020-07-14 | 727SS | -3d | 0d | BHS | Installation | HBS2;HBS3;HBS5;HBS6 |  | INT |  |  |  | 4 méca + 4 élec |  |
| 729 | 3.1.5.6.4.8 | Installation électrique ligne arrivée C4 gare de triage |  | 5d | 2020-07-15 | 2020-07-21 | 652, 728 | -3d | 0d | BHS | Installation | C4 |  | INT |  |  |  | 4 élec |  |
| 730 | 3.1.5.6.4.9 | Modification électrique ligne carrousel |  | 5d | 2020-07-22 | 2020-07-28 | 729 | -3d | 0d | BHS | Installation | C4 |  | INT |  |  |  | 4 élec |  |
| 731 | 3.1.5.6.4.10 | Mise à disposition zone C4 pour création caisson coupe-feu + démontage des faux plafonds | milestone | 0d | 2020-07-06 | 2020-07-06 | 726 | 1d | 0d | BHS | Blank | NA |  | INT |  |  |  |  |  |
| 732 | 3.1.5.6.4.11 | Fin de réalisation caisson coupe feu ligne arrivée C4 + faux plafonds démontés | milestone | 0d | 2020-07-20 | 2020-07-20 | 731FS+10d | 1d | 0d | BLC | Blank | NA |  | ET |  |  |  |  |  |
| 733 | 3.1.5.6.4.12 | Installation convoyeur trémie C4 + CF + volet AI |  | 2d | 2020-07-21 | 2020-07-22 | 732, 727 | 1d |  | BHS | Installation | C4 | Installation | INT |  |  |  | 1 méca + 1 élec |  |
| 734 | 3.1.5.6.4.13 | Test Ligne arrivée C4 (B.F. LIV n°4) |  | 18d | 2020-07-29 | 2020-08-21 | 727, 729, 733, 652, 730 | -3d | 0d | BHS | Commissioning | C4 | Commissioning | INT |  |  |  | 1 automaticien + 1 élec |  |
| 735 | 3.1.5.6.4.14 | VABF Ligne arrivée C4 (B.F. LIV n°4) |  | 2d | 2020-08-24 | 2020-08-25 | 734 | -3d | 0d | BHS | Blank | C4 |  | INT/IS/GA |  |  |  | 1 automaticien |  |
| 736 | 3.1.5.6.4.15 | Mise en service Ligne arrivée C4 (B.F. LIV n°4) | milestone | 0d | 2020-08-25 | 2020-08-25 | 735 | -3d | 0d | BHS | Working | C4 |  | INT |  |  |  |  |  |

Notes:
- 706: Text29: NA
- 707: Text29: NA
- 708: Text29: 7 convoyeurs, 20 mètres + 2 courbes
- 709: Text29: 8 convoyeurs, 28 mètres + 2 merges + 1 ATR + 4 courbes
- 710: Text29: 8 Check-In
- 712: Text29: NA
- 713: Text29: NA
- 714: Text29: NA
- 715: Text29: NA
- 716: Text29: 3 lignes d'introduction
- 717: Text29: 10 convoyeurs, 68 mètres
- 719: Text29: NA
- 720: Text29: 172 convoyeurs, 775 mètres + 26 courbes + 6 pushers + 2 élévateurs continue + 4 élévateurs discontinue
- 721: Text29: NA
- 722: Text29: 6 convoyeurs, 44 mètres + 1 courbe
- 723: Text29: NA
- 724: Text29: 2 convoyeurs, 10 mètres
- 725: Text29: 2 convoyeurs + 1 volet 11 mètres
- 727: Partie Nord deja monté avec C6 / Text29: 7 convoyeurs, 28 mètres + 2 courbes
- 728: G20 et G25=HBS3, HF1 et HF2=HBS2, G30 et G35=HBS5, G10,G15,G17 =HBS6 / Text29: 9 convoyeurs, 66 mètres
- 731: Text29: NA
- 732: Text29: NA
- 733: Text29: 1 convoyeur 1 mètre
- 734: Text29: NA
- 735: Text29: NA
- 736: Text29: NA

| ID | WBS | Task | Type | Duration | Start | Finish | Predecessors | Total slack | Free slack | Text1 | Text12 | Text21 | Text26 | Acteur | Text27 | Text14 | Coordonnées | Text13 | Etage |
| --- | --- | --- | --- | --- | --- | --- | --- | --- | --- | --- | --- | --- | --- | --- | --- | --- | --- | --- | --- |
| 737 | 3.1.5.6.5 | **Travaux Fonction C2 - CONTROLE SURETE** |  | 30d | 2020-05-01 | 2020-06-15 |  | 65d |  | BHS | Blank | NA | Blank |  |  |  |  |  |  |
| 738 | 3.1.5.6.5.1 | Installation connexion temporaire Ligne HBS vers injections TN |  | 30d | 2020-05-01 | 2020-06-15 | 716SS | 65d |  | BHS | Installation | NA | Installation | INT | 1 méca + 1 élec |  |  |  |  |
| 739 | 3.1.5.7 | **Phase 8** |  | 232d | 2020-05-25 | 2021-04-29 |  | 19d |  | BHS | Blank | NA | Blank |  |  |  |  |  |  |
| 740 | 3.1.5.7.1 | **Travaux Fonction C2 - CONTROLE SURETE** |  | 105d | 2020-07-03 | 2020-11-27 |  | 0d |  | BHS | Blank | NA | Blank |  |  |  |  |  |  |
| 741 | 3.1.5.7.1.1 | Installation informatique Supervision |  | 30d | 2020-07-31 | 2020-09-11 | 490 | 2d |  | BLC | Blank | NA |  | GA/LEO |  |  |  |  |  |
| 742 | 3.1.5.7.1.2 | Installation des 2 pateformes HF CdF zone levée de doute HBS1 - HBS2 |  | 20d | 2020-07-03 | 2020-07-30 | 505 | 0d |  | BHS | Installation | NA |  | INT |  | New line to separate the plateforme & lines mounting |  |  |  |
| 743 | 3.1.5.7.1.3 | Installation plateforme CdF Nord pour HBS3 et HBS4 (au dessus des lignes HF) |  | 15d | 2020-07-31 | 2020-08-20 | 742 | 0d |  | BHS | Installation | NA |  | INT |  | New line for the missing plateforme |  |  |  |
| 744 | 3.1.5.7.1.4 | Installation ligne HF Cours de France HBS1 - HBS2 + volet (levée de doute) |  | 15d | 2020-08-21 | 2020-09-11 | 742, 743 | 0d |  | BHS | Installation | HBS1;HBS2 | Installation | INT | 3 méca + 3 élec |  | 44-41/BD | 5.2 | SS01 |
| 745 | 3.1.5.7.1.5 | Installation plateforme Cdf pour lignes HF montée IATA (HBS1 - HBS2) |  | 22d | 2020-09-14 | 2020-10-13 | 744 | 43d | 0d | BHS | Installation | NA |  | INT |  |  | 40-28/DE | 5.2 | SS01 |
| 746 | 3.1.5.7.1.6 | Installation lignes HF montée IATA (HBS1-HBS2) + volets contre mur IATA |  | 8d | 2020-10-14 | 2020-10-23 | 745 | 43d | 0d | BHS | Installation | HBS1;HBS2 |  | INT | 2 méca |  | 40-28/DE | 5.2 | SS01 |
| 747 | 3.1.5.7.1.7 | Installation électrique ligne HF CdF (HBS1-HBS2) |  | 15d | 2020-10-26 | 2020-11-13 | 746 | 43d | 0d | BHS | Installation | HBS1;HBS2 |  | INT | 2 élec |  | 40-28/DE | 5.2 | SS01 |
| 748 | 3.1.5.7.1.8 | Installation informatique pour poste ETD ligne HF (HBS1-HBS2) dans CdF |  | 5d | 2020-10-26 | 2020-10-30 | 747SS | 53d | 43d | BLC | Installation | NA |  | GA |  |  |  |  |  |
| 749 | 3.1.5.7.1.9 | Mise à disposition zone pour création mur délimitation Cour de France/extension IATA | milestone | 0d | 2020-11-13 | 2020-11-13 | 747 | 121d | 0d | BHS | Blank | NA |  | INT |  |  |  |  |  |
| 750 | 3.1.5.7.1.10 | Mur délimitant Cour de France/extension IATA réalisé | milestone | 0d | 2020-11-27 | 2020-11-27 | 749FS+10d | 121d | 120d | BLC | Blank | NA |  | ET |  |  |  |  |  |
| 751 | 3.1.5.7.2 | **Travaux Fonction C1 - ENREGISTREMENTS** |  | 43d | 2020-06-24 | 2020-08-24 |  | 0d |  | BHS | Blank | NA |  |  |  |  |  |  |  |
| 752 | 3.1.5.7.2.1 | Consignation banque 0000 et collecteur | milestone | 0d | 2020-06-24 | 2020-06-24 | 714 | 0d |  | GA | Blank | NA |  | GA |  |  |  |  |  |
| 753 | 3.1.5.7.2.2 | Demontage banques 0000 et ligne collecteur |  | 5d | 2020-06-25 | 2020-07-01 | 752 | 0d |  | BHS | Dismounting | NA |  | INT | 4 méca + 4 élec |  | 10-14/G | 2.2 | RZ00 |
| 754 | 3.1.5.7.2.3 | Installation mécanique collecteur G30 + volet |  | 8d | 2020-07-02 | 2020-07-13 | 753 | 0d |  | BHS | Installation | HBS5 |  | INT | 2 méca |  | 11-14/G | 2.2 | RZ00 |
| 755 | 3.1.5.7.2.4 | Installation Check-In G30 + 4 Check-In G25 |  | 10d | 2020-07-14 | 2020-07-27 | 754 | 0d |  | BHS | Installation | HBS5 |  | INT | 4 méca |  | 11-14/G | 2.2 | RZ00 |
| 756 | 3.1.5.7.2.5 | Installation électrique collecteurs + banques + volet G30 |  | 8d | 2020-07-28 | 2020-08-06 | 755 | 0d |  | BHS | Installation | HBS5 |  | INT | 4 élec |  | 11-14/G | 2.2 | RZ00 |
| 757 | 3.1.5.7.2.6 | Test banques G30 sur installation existante au Casino |  | 10d | 2020-08-07 | 2020-08-20 | 756 | 0d |  | BHS | Commissioning | HBS5 |  | INT | 1 automaticien + 1 élec |  |  |  |  |
| 758 | 3.1.5.7.2.7 | VABF banques G30 sur installation existante au Casino |  | 2d | 2020-08-21 | 2020-08-24 | 757 | 0d |  | BHS | Blank | HBS5 |  | INT | 1 automaticien |  |  |  |  |
| 759 | 3.1.5.7.2.8 | Mise en service banques G30 + 4 Check-In G25 sur installation existante au Casino | milestone | 0d | 2020-08-24 | 2020-08-24 | 758 | 0d |  | BHS | Working | HBS5 |  | INT |  |  |  |  |  |
| 760 | 3.1.5.7.3 | **Travaux Fonction C3 - TRI** |  | 232d | 2020-05-25 | 2021-04-29 |  | 19d |  | BHS | Blank | NA | Blank |  |  |  |  |  |  |
| 761 | 3.1.5.7.3.1 | Installation Trieur Nord (suite) |  | 15d | 2020-07-14 | 2020-08-03 | 689 | 0d |  | BHS | Installation | NA | Installation | INT | 4 méca + 4 élec |  |  |  |  |
| 762 | 3.1.5.7.3.2 | Connexion HBS3 IATA |  | 10d | 2020-05-25 | 2020-06-08 | 716 | 70d |  | BHS | Installation | HBS3 |  | INT | 1 méca + 1 élec |  |  |  |  |
| 763 | 3.1.5.7.3.3 | Connexion HBS4 IATA |  | 10d | 2020-05-25 | 2020-06-08 | 716 | 70d | 0d | BHS | Installation | HBS4 |  | INT | 2 méca + 2 élec |  |  |  |  |
| 764 | 3.1.5.7.3.4 | Connexion HBS5 IATA |  | 10d | 2020-06-09 | 2020-06-22 | 763 | 237d | 210d | BHS | Installation | HBS5 |  | INT | 2 méca + 1 élec |  |  |  |  |
| 765 | 3.1.5.7.3.5 | Test HBS5 IATA (pour les autres lignes HBS compris dans les tests complet) |  | 2d | 2021-04-28 | 2021-04-29 | 764, 902 | 27d | 0d | BHS | Commissioning | HBS5 |  | INT | 1 automaticien + 1 élec |  |  |  |  |
| 766 | 3.1.5.7.3.6 | Installation MUP Trieur Nord (extension) |  | 30d | 2020-08-04 | 2020-09-15 | 761 | 0d |  | BHS | Installation | NA | Installation | INT | 3 méca + 3 élec |  |  |  |  |

Notes:
- 737: Text29: NA
- 738: Text29: 10 convoyeurs, 30 mètres + 1 horizontal diverter + 2 courbes
- 739: Text29: NA
- 740: Text29: NA
- 741: Système SCADA/SAC à charger de resp LEO. A CORELER AVEC PLANNING IT AU NIVEAU DE LA DUREE
- 744: Text29: 21 convoyeurs, 74 mètres + ATR + 4 vertical diverter + 2 courbes
- 746: Text29: 4 convoyeurs, 22 mètres
- 749: Text29: NA
- 750: Text29: NA
- 751: Text29: NA
- 752: Text29: NA
- 753: Text29: 31 convoyeurs, 80 mètres + 14 Check-In
- 754: Text29: 4 convoyeurs, 31 mètres
- 755: Text29: 18 Check-In
- 757: Text29: NA
- 758: Text29: NA
- 759: Text29: NA / Text30: Avis Alex : On peut mettre en service G30 une fois que HBS5 est monté
- 760: Text29: NA
- 761: Text29: 80 mètres de trieur final côté droit IATA
- 762: Text29: 9 convoyeurs 15 mètres + 1 ATR
- 763: Text29: 19 convoyeurs 28 mètres + 1 vertical diverter + 1 ATR
- 764: Text29: 15 convoyeurs 24 mètres + 1 ATR
- 765: Text29: NA
- 766: Text29: 27 convoyeurs, 164 mètres + 12 chutes

| ID | WBS | Task | Type | Duration | Start | Finish | Predecessors | Total slack | Free slack | Text1 | name 2 | Text12 | Text21 | Text26 | Acteur | Text27 | Coordonnées | Text13 | Etage |
| --- | --- | --- | --- | --- | --- | --- | --- | --- | --- | --- | --- | --- | --- | --- | --- | --- | --- | --- | --- |
| 767 | 3.1.5.7.3.7 | **Travaux Fonction C4 - EBS** |  | 90d | 2020-08-06 | 2020-12-10 |  | -33d | 0d | BHS | EBS | Blank | NA | Blank |  |  |  |  |  |
| 768 | 3.1.5.7.3.7.1 | Installation plateforme EBS AIRE B |  | 30d | 2020-08-06 | 2020-09-17 | 720 | -33d | 0d | BHS | EBS | Installation | NA | Installation | INT |  |  |  |  |
| 769 | 3.1.5.7.3.7.2 | Installation lignes EBS AIRE B |  | 60d | 2020-09-18 | 2020-12-10 | 768 | -33d | 0d | BHS | EBS | Installation | NA | Installation | INT | 10 méca + 10 élec |  |  |  |
| 770 | 3.1.5.7.3.7.3 | **Travaux Fonction C5 - ARRIVEE** |  | 49d | 2020-08-25 | 2020-11-03 |  | -3d | 0d | BHS |  | Blank | NA | Blank |  |  |  |  |  |
| 771 | 3.1.5.7.3.7.3.1 | Consignation Ligne arrivée 3 et Transfert 3 | milestone | 0d | 2020-08-25 | 2020-08-25 | 736 | -3d | 0d | BLC |  | Stopped | NA |  | GA |  |  |  |  |
| 772 | 3.1.5.7.3.7.3.2 | Démontage Ligne Transfert 3 |  | 2d | 2020-08-26 | 2020-08-27 | 771 | -3d | 0d | BHS |  | Dismounting | TR3 | Dismounting | INT | 1 méca + 1 élec |  |  |  |
| 773 | 3.1.5.7.3.7.3.3 | Démontage ligne arrivée 3 |  | 5d | 2020-08-28 | 2020-09-03 | 772 | -3d | 0d | BHS |  | Dismounting | C3 |  | INT | 1 méca + 1 élec |  |  |  |
| 774 | 3.1.5.7.3.7.3.4 | Démontage caisson ligne 3 |  | 1d | 2020-09-04 | 2020-09-04 | 773 | -3d | 0d | BLC |  | Dismounting | NA |  | ET |  |  |  |  |
| 775 | 3.1.5.7.3.7.3.5 | Installation Ligne arrivée C3 solde (partie Nord gare de triage) |  | 3d | 2020-09-07 | 2020-09-09 | 774 | -3d | 0d | BHS |  | Installation | C3 |  | INT | 2 méca |  |  |  |
| 776 | 3.1.5.7.3.7.3.6 | Installation ligne arrivée C3 (partie Sud gare de triage) |  | 4d | 2020-09-11 | 2020-09-16 | 775 | -3d | 0d | BHS |  | Installation | C3 |  | INT | 2 méca |  |  |  |
| 777 | 3.1.5.7.3.7.3.7 | Installation ligne départ 4 lignes : HBS3, HBS2, HBS5, HBS6 (G20+G25,HF1+HF2,G30+G35, G10+G15+G17) en même temps que le montage de la ligne C3 (coté sud gare de triage) |  | 8d | 2020-09-11 | 2020-09-22 | 776SS | -3d | 0d | BHS |  | Installation | HBS2;HBS3;HBS5;HBS6 |  | INT | 3 méca + 3 élec |  |  |  |
| 778 | 3.1.5.7.3.7.3.8 | Installation électrique ligne arrivée C3 gare de triage |  | 5d | 2020-09-23 | 2020-09-29 | 775, 777 | -3d | 0d | BHS |  | Installation | C3 |  | INT | 2 élec |  |  |  |
| 779 | 3.1.5.7.3.7.3.9 | Modification électrique ligne carrousel |  | 5d | 2020-09-30 | 2020-10-06 | 778 | -3d | 0d | BHS |  | Installation | C3 |  | INT | 4 élec |  |  |  |
| 780 | 3.1.5.7.3.7.3.10 | Mise à disposition zone C3 pour création caisson coupe-feu + démontage des faux plafonds | milestone | 0d | 2020-09-04 | 2020-09-04 | 774 | 6d | 0d | BHS |  | Blank | NA |  | INT |  |  |  |  |
| 781 | 3.1.5.7.3.7.3.11 | Fin de réalisation caisson coupe feu ligne arrivée C3 + faux plafonds démontés | milestone | 0d | 2020-09-21 | 2020-09-21 | 780FS+10d | 6d | 0d | BLC |  | Blank | NA |  | ET |  |  |  |  |
| 782 | 3.1.5.7.3.7.3.12 | Installation convoyeur trémie C3 + CF + volet AI |  | 2d | 2020-09-22 | 2020-09-23 | 781, 776 | 6d |  | BHS |  | Installation | C3 | Installation | INT | 1 méca + 1 élec |  |  |  |
| 783 | 3.1.5.7.3.7.3.13 | Test Ligne arrivée C3 et Transfert 3 |  | 18d | 2020-10-07 | 2020-10-30 | 775, 776, 778, 779, 782 | -3d | 0d | BHS |  | Commissioning | C3;TR3 | Commissioning | INT | 1 automaticien + 1 élec |  |  |  |
| 784 | 3.1.5.7.3.7.3.14 | VABF Ligne arrivée C3 (B.F LIV n°3) et Transfert 3 |  | 2d | 2020-11-02 | 2020-11-03 | 783 | -3d | 0d | BHS |  | Blank | C3;TR3 | Blank | INT/IS/GA | 1 automaticien |  |  |  |
| 785 | 3.1.5.7.3.7.3.15 | Mise en service Ligne arrivée C3 (B.F LIV n°3) et Transfert 3 | milestone | 0d | 2020-11-03 | 2020-11-03 | 784 | -3d | 0d | BHS |  | Working | C3;TR3 | Working | INT |  |  |  |  |
| 786 | 3.1.5.8 | **Phase 9** |  | 140d | 2020-07-16 | 2021-02-09 |  | -21d | 0d | BHS |  | Blank | NA | Blank |  |  |  |  |  |
| 787 | 3.1.5.8.1 | **Travaux Fonction C2 - CONTROLE SURETE** |  | 58d | 2020-07-16 | 2020-10-06 |  | 0d |  | BHS |  | Blank | NA | Blank |  |  |  |  |  |
| 788 | 3.1.5.8.1.1 | Installation Lignes HBS1 et HBS2 (HBS Nord) |  | 28d | 2020-07-16 | 2020-08-24 | 506, 507 | 0d |  | BHS |  | Installation | HBS1;HBS2 | Installation | INT | 2 méca + 2 élec | 30-40 /BD | 5.2 | SS01 |
| 789 | 3.1.5.8.1.2 | Installation Lignes HBS3 et HBS4 (HBS Nord) |  | 28d | 2020-08-25 | 2020-10-02 | 788, 507, 506 | 0d |  | BHS |  | Installation | HB3;HBS4 | Installation | INT | 2 méca + 2 élec | 30-40 /BD | 5.2 | SS01 |
| 790 | 3.1.5.8.1.3 | Installation Lignes HBS1 et HBS2 (HBS Nord) suite |  | 30d | 2020-08-25 | 2020-10-06 | 788 | 61d | 0d | BHS |  | Installation | Ligne EDS | Installation | INT |  |  |  |  |

Notes:
- 767: Text29: NA
- 769: Text29: 222 convoyeurs, 1600 mètres + 12 courbes + 6 pushers + 3 élévateurs discontinue + 1 courbe HELIX
- 770: Text29: NA
- 771: Text29: NA
- 772: Text29: 3 convoyeurs, 10 mètres
- 773: Text29: 2 convoyeurs, 11 mètres + 1 volet
- 774: Text29: NA
- 775: Text29: 5 convoyeurs, 14 mètres
- 776: Text29: 3 convoyeurs, 10 mètres
- 777: G20 et G25=HBS3, HF1 et HF2=HBS2, G30 et G35=HBS5 / Text29: 9 convoyeurs, 42 mètres + 1 vertical diverter
- 780: Text29: NA
- 781: Text29: NA
- 782: Text29: 1 convoyeur, 1 mètre
- 783: Text29: NA
- 784: Text29: NA
- 785: Text29: NA
- 786: Text29: NA
- 787: Text29: NA
- 788: Text29: 24 convoyeurs, 120 mètres + 10 courbes + 2 ATR + 1 EDS
- 789: Text29: 25 convoyeurs, 83 mètres + 8 courbes + 2 ATR + 2 EDS

| ID | WBS | Task | Type | Duration | Start | Finish | Predecessors | Total slack | Free slack | Text1 | Text12 | Text21 | Text26 | Text29 | Acteur | Etage | Text27 | Coordonnées | Text13 | name 2 |
| --- | --- | --- | --- | --- | --- | --- | --- | --- | --- | --- | --- | --- | --- | --- | --- | --- | --- | --- | --- | --- |
| 791 | 3.1.5.8.2 | **Travaux Fonction C5 - ARRIVEE** |  | 140d | 2020-07-16 | 2021-02-09 |  | -33d | 0d | BHS | Blank | NA | Blank | NA |  |  |  |  |  |  |
| 792 | 3.1.5.8.2.1 | Consignation Ligne arrivée Secteur France | milestone | 0d | 2020-07-16 | 2020-07-16 | 506 | 0d |  | BLC | Stopped | NA | Stopped | NA | GA |  |  |  |  |  |
| 793 | 3.1.5.8.2.2 | Démontage Ligne arrivée secteur France SS01 |  | 5d | 2020-07-16 | 2020-07-22 | 792 | 0d |  | BHS | Dismounting | Secteur France | Dismounting | 8 convoyeurs, 55 mètres + 6 courbes | INT | SS01 | 2 méca + 2 élec |  |  |  |
| 794 | 3.1.5.8.2.3 | Démontage ligne arrivée Secteur France |  | 2d | 2020-07-23 | 2020-07-24 | 793 | 0d |  | BHS | Dismounting | Secteur France |  | 3 convoyeurs, 11 mètres | INT | RZ00 | 1 méca + 1 élec |  |  |  |
| 795 | 3.1.5.8.2.4 | Démontage caisson ligne Secteur France |  | 1d | 2020-07-27 | 2020-07-27 | 794 | 0d |  | BHS | Dismounting | NA |  |  | INT |  |  |  |  |  |
| 796 | 3.1.5.8.2.5 | Installation électrique ligne Secteur France |  | 5d | 2020-07-16 | 2020-07-22 | 722 | 38d | 0d | BHS | Installation | Secteur France |  |  | INT |  | 4 élec |  |  |  |
| 797 | 3.1.5.8.2.6 | Modification électrique ligne carrousel |  | 5d | 2020-07-23 | 2020-07-29 | 796 | 38d |  | BHS | Installation | Secteur France |  |  | INT |  | 4 élec |  |  |  |
| 798 | 3.1.5.8.2.7 | Mise à disposition zone Secteur France pour création caisson coupe-feu + démontage des faux plafonds | milestone | 0d | 2020-07-27 | 2020-07-27 | 795 | 0d |  | BHS | Blank | NA |  | NA | INT |  |  |  |  |  |
| 799 | 3.1.5.8.2.8 | Fin de réalisation caisson coupe feu ligne arrivée Secteur France + faux plafonds démontés | milestone | 0d | 2020-08-10 | 2020-08-10 | 798SF+10d | 20d | 0d | BLC | Blank | NA |  | NA | ET |  |  |  |  |  |
| 800 | 3.1.5.8.2.9 | Installation convoyeur trémie Secteur France + CF + volet AI |  | 10d | 2020-08-11 | 2020-08-24 | 799 | 20d |  | BHS | Installation | Secteur France |  | 2 convoyeurs, 11 mètres | INT |  | 1 méca + 1 élec |  |  |  |
| 801 | 3.1.5.8.2.10 | Installation Ligne arrivée secteur France zone HBS SS01 |  | 7d | 2020-09-14 | 2020-09-22 | 483, 793, 799, 744 | 0d |  | BHS | Installation | Secteur France | Installation | 2 convoyeurs, 13 mètres | INT | SS01 | 1 méca + 1 élec | 30-34/AB | 5.2 |  |
| 802 | 3.1.5.8.2.11 | Installation Ligne arrivée Secteur France zone carrousel SS01 |  | 2d | 2020-09-14 | 2020-09-15 | 801SS | 5d |  | BHS | Installation | Secteur France |  | 2 convoyeurs, 6 mètres | INT | SS01 | 1 méca + 1 élec | 30/E |  |  |
| 803 | 3.1.5.8.2.12 | Test Ligne arrivée Secteur France (B.F LIV N SF) |  | 10d | 2020-09-23 | 2020-10-06 | 800, 797, 796, 802, 801, 722 | 0d |  | BHS | Commissioning | Secteur France |  |  | INT |  | 1 automaticien + 1 élec |  |  |  |
| 804 | 3.1.5.8.2.13 | VABF Ligne arrivée Secteur France (B.F LIV N SF) |  | 2d | 2020-10-07 | 2020-10-08 | 803 | 0d |  | BHS | Blank | Secteur France | Blank |  | INT/IS/GA |  | 1 automaticien |  |  |  |
| 805 | 3.1.5.8.2.14 | Mise en service Ligne arrivée Secteur France (B.F LIV N SF) | milestone | 0d | 2020-10-08 | 2020-10-08 | 804 | 0d |  | BHS | Working | Secteur France | Working | NA | INT |  |  |  |  |  |
| 806 | 3.1.5.8.2.15 | Installation plateforme EBS AIRE A |  | 35d | 2020-12-11 | 2021-02-09 | 769, 464 | -33d | 0d | BHS | Installation | NA | Installation |  | INT |  |  |  |  | EBS |
| 807 | 3.1.5.8.3 | **Travaux Fonction C3 - TRI** |  | 10d | 2020-09-16 | 2020-09-29 |  | 0d |  | BHS | Blank | NA | Blank | NA |  |  |  |  |  |  |
| 808 | 3.1.5.8.3.1 | Test Trieur Nord avec 10 MUP |  | 10d | 2020-09-16 | 2020-09-29 | 766, 716, 738, 762, 763, 741 | 0d |  | BHS | Commissioning | NA | Commissioning | NA | INT |  | 1 automaticien + 1 élec |  |  |  |
| 809 | 3.1.5.9 | **Phase 10** |  | 86d | 2020-09-30 | 2021-02-08 |  | -24d | 0d | BHS | Blank | NA | Blank | NA |  |  |  |  |  |  |
| 810 | 3.1.5.9.1 | **Travaux Fonction C2 - CONTROLE SURETE** |  | 86d | 2020-09-30 | 2021-02-08 |  | -24d | 0d | BHS | Blank | NA | Blank | NA |  |  |  |  |  |  |
| 811 | 3.1.5.9.1.1 | Installation Lignes HBS1 et HBS2 (sous la trémie) |  | 10d | 2020-10-07 | 2020-10-20 | 790, 503 | 61d | 51d | BHS | Installation | HBS1;HBS2 | Installation | 12 convoyeurs, 57 mètres + 1 merge + 6 courbes | INT |  | 2 méca + 2 élec |  |  |  |
| 812 | 3.1.5.9.1.2 | Installation plateforme CdF Sud pour lignes HBS (HBS3,4,5,6,7,8) |  | 20d | 2020-10-21 | 2020-11-17 | 492 | -39d | 0d | BHS | Installation | HBS3;HBS4 | Installation |  | INT |  |  |  |  |  |
| 813 | 3.1.5.9.1.3 | Installation plateforme CdF inter 2 zones pour HBS3 et HBS4 |  | 10d | 2020-11-18 | 2020-12-01 | 812 | -39d | 0d | BHS | Installation | HBS3;HBS4 |  |  | INT |  |  |  |  |  |
| 814 | 3.1.5.9.1.4 | Installation Lignes HBS3 et HBS4 sur toutes les plateformes CdF |  | 25d | 2020-12-02 | 2021-01-15 | 812, 813 | -39d | 0d | BHS | Installation | HBS3;HBS4 | Installation |  | INT |  |  |  |  |  |
| 815 | 3.1.5.9.1.5 | Test Check-In Hors Format HF1 (HBS2) |  | 10d | 2021-01-26 | 2021-02-08 | 687, 867 | 0d |  | BHS | Commissioning | HBS2 |  | NA |  |  | 1 automaticien + 1 élec |  |  |  |
| 816 | 3.1.5.9.1.6 | Installation Lignes HBS3 et HBS4 (HBS Nord) |  | 33d | 2020-10-05 | 2020-11-18 | 789 | 17d |  | BHS | Installation | HBS3;HBS4 | Installation | 37 convoyeurs, 80 mètres + 7 courbes + 2 vertical diverter | INT |  | 2 méca + 2 élec |  |  |  |

Notes:
- 811: Attention, dès que l'on monte sous la trémie on ne peut plus rien descendre
- 813: Text14: New line for the missing plateforme in CdF between the north and the south
- 814: Text14: New line to separate the plateforme & lines mounting

| ID | WBS | Task | Type | Duration | Start | Finish | Predecessors | Total slack | Free slack | Constraint | Text1 | Text12 | Text21 | Text26 | Text29 | Acteur | Text27 |
| --- | --- | --- | --- | --- | --- | --- | --- | --- | --- | --- | --- | --- | --- | --- | --- | --- | --- |
| 817 | 3.1.5.9.1.7 | **Travaux Fonction C5 - ARRIVEE** |  | 71d | 2020-09-30 | 2021-01-18 |  | -1d | 0d |  | BHS | Blank | NA | Blank | NA |  |  |
| 818 | 3.1.5.9.1.7.1 | Consignation Ligne arrivée 2 et Transfert 2 | milestone | 0d | 2020-11-03 | 2020-11-03 | 785 | 0d |  |  | BLC | Stopped | NA | Stopped |  | GA |  |
| 819 | 3.1.5.9.1.7.2 | Démontage Ligne Transfert 2 |  | 2d | 2020-11-04 | 2020-11-05 | 818 | 0d |  |  | BHS | Dismounting | TR2 | Dismounting | 2 convoyeurs + 2 courbes, 14 mètres | INT | 3 méca + 1 élec |
| 820 | 3.1.5.9.1.7.3 | Démontage ligne arrivée 2 |  | 5d | 2020-11-06 | 2020-11-12 | 819 | 0d |  |  | BHS | Dismounting | C2 | Dismounting | 1 convoyeur + 1 courbe + 1 volet 8 mètres | INT | 1 méca + 1 élec |
| 821 | 3.1.5.9.1.7.4 | Démontage caisson ligne 2 |  | 1d | 2020-11-13 | 2020-11-13 | 820 | 0d |  |  | BLC | Dismounting | NA |  | NA | ET |  |
| 822 | 3.1.5.9.1.7.5 | Installation Ligne arrivée C2 solde + (partie Nord gare de triage) |  | 3d | 2020-11-16 | 2020-11-18 | 821 | 5d |  |  | BHS | Installation | C2 |  | 7 convoyeurs, 22 mètres + 1 courbe | INT | 2 méca |
| 823 | 3.1.5.9.1.7.6 | Installation ligne arrivée C2 (partie Sud gare de triage) |  | 4d | 2020-11-16 | 2020-11-19 | 821 | 0d |  |  | BHS | Installation | C2 |  |  | ET | 2 méca |
| 824 | 3.1.5.9.1.7.7 | Installation ligne départ 5 lignes : HBS3, HBS2, HBS5, HBS6, HBS7 (G20+G25,HF1+HF2,G30+G35, G10+G15+G17, G40) en même temps que le montage de la ligne C2 (coté sud gare de triage) |  | 8d | 2020-11-16 | 2020-11-25 | 823SS | 0d |  |  | BHS | Installation | HBS2;HBS3;HBS5;HBS6;HBS7 |  | 20 convoyeurs, 96 mètres + 1 courbe + 1 merge + 1 ATR | INT | 4 méca + 4 élec |
| 825 | 3.1.5.9.1.7.8 | Installation électrique ligne de arrivée C2 gare de triage |  | 5d | 2020-11-26 | 2020-12-02 | 822, 824 | 0d |  |  | BHS | Installation | C2 | Installation |  | INT | 3 élec |
| 826 | 3.1.5.9.1.7.9 | Modification électrique ligne carrousel |  | 5d | 2020-12-03 | 2020-12-09 | 825 | 0d |  |  | BHS | Installation | C2 |  |  | INT | 4 élec |
| 827 | 3.1.5.9.1.7.10 | Mise à disposition zone C2 pour création caisson coupe-feu + démontage des faux plafonds | milestone | 0d | 2020-11-13 | 2020-11-13 | 821 | 6d | 0d |  | BHS | Blank | NA |  | NA | INT |  |
| 828 | 3.1.5.9.1.7.11 | Fin de réalisation caisson coupe feu ligne arrivée C2 + faux plafonds démontés | milestone | 0d | 2020-11-27 | 2020-11-27 | 827FS+10d | 6d | 0d |  | BLC | Blank | NA |  |  | ET |  |
| 829 | 3.1.5.9.1.7.12 | Installation convoyeur trémie C2 + CF + volet AI |  | 2d | 2020-11-30 | 2020-12-01 | 828, 823 | 6d |  |  | BHS | Installation | C2 |  | 1 convoyeur, 1 mètre | INT | 1 méca + 1 élec |
| 830 | 3.1.5.9.1.7.13 | Test Ligne arrivée C2 et Transfert 2 |  | 18d | 2020-12-10 | 2021-01-14 | 822, 823, 825, 826, 829 | 0d |  |  | BLC | Commissioning | C2;TR2 |  | NA | ET | 1 automaticien + 1 élec |
| 831 | 3.1.5.9.1.7.14 | VABF Ligne arrivée C2 (B.F LIV n°2) et Transfert 2 |  | 1d | 2021-01-15 | 2021-01-15 | 830 | 0d |  |  | BHS | Installation | C2;TR2 | Installation | NA | INT | 1 automaticien |
| 832 | 3.1.5.9.1.7.15 | Mise en service Ligne arrivée C2 (B.F LIV n°2) et Transfert 2 | milestone | 0d | 2021-01-15 | 2021-01-15 | 831 | 0d |  | start no earlier than 2019-08-05 | BHS | Installation | C2;TR2 | Installation | NA | INT |  |
| 833 | 3.1.5.9.1.7.16 | Consignation Ligne arrivée 1 | milestone | 0d | 2020-11-03 | 2020-11-03 | 785SS | -3d | 0d |  | BLC | Stopped | NA | Stopped | NA | GA |  |
| 834 | 3.1.5.9.1.7.17 | Démontage Ligne Transfert 1 |  | 2d | 2020-11-04 | 2020-11-05 | 833 | -3d | 0d |  | BHS | Dismounting | C1 | Dismounting | 1 convoyeur + 1 volet | INT | 1 méca |
| 835 | 3.1.5.9.1.7.18 | Démontage ligne arrivée 1 |  | 5d | 2020-11-06 | 2020-11-12 | 834 | -3d | 0d |  | BHS | Dismounting | C1 | Dismounting | 1 convoyeur + 1 courbe + 1 volet 8 mètres | INT | 1 méca + 1 élec |
| 836 | 3.1.5.9.1.7.19 | Démontage caisson ligne 1 |  | 1d | 2020-11-13 | 2020-11-13 | 835 | -3d | 0d |  |  | Dismounting |  |  |  | ET |  |
| 837 | 3.1.5.9.1.7.20 | Installation Ligne arrivée C1 (partie Nord gare de triage) |  | 3d | 2020-11-16 | 2020-11-18 | 836 | 2d |  |  | BHS | Installation | C1 |  | 8 convoyeurs, 15 mètres | INT | 2 méca |
| 838 | 3.1.5.9.1.7.21 | Installation ligne arrivée C1 (partie Sud gare de triage) |  | 4d | 2020-11-16 | 2020-11-19 | 836 | -3d | 0d |  | BHS | Installation | C1 |  |  | ET | 2 méca |
| 839 | 3.1.5.9.1.7.22 | Installation ligne départ 5 lignes : HBS3, HBS2, HBS5, HBS6, HBS7 (G20+G25,HF1+HF2,G30+G35, G10+G15+G17, G40) en même temps que le montage de la ligne C2 (coté sud gare de triage) |  | 8d | 2020-11-16 | 2020-11-25 | 838SS | -3d | 0d |  | BHS | Installation | HBS2;HBS3;HBS5;HBS6;HBS7 |  | 13 convoyeurs, 56 mètres | INT | 2 méca + 2 élec |
| 840 | 3.1.5.9.1.7.23 | Installation électrique ligne arrivée C1 gare de triage |  | 5d | 2020-11-26 | 2020-12-02 | 837, 839 | -3d | 0d |  | BHS | Installation | C1 | Installation |  | INT | 2 élec |
| 841 | 3.1.5.9.1.7.24 | Modification électrique ligne carrousel |  | 5d | 2020-12-03 | 2020-12-09 | 840 | -3d | 0d |  | BHS | Installation | C1 |  |  | INT | 4 élec |
| 842 | 3.1.5.9.1.7.25 | Mise à disposition zone C1 pour création caisson coupe-feu + démontage des faux plafonds | milestone | 0d | 2020-11-13 | 2020-11-13 | 836 | 3d | 0d |  | BHS | Blank | NA |  | NA | INT |  |
| 843 | 3.1.5.9.1.7.26 | Fin de réalisation caisson coupe feu ligne arrivée C1 + faux plafonds démontés | milestone | 0d | 2020-11-27 | 2020-11-27 | 842FS+10d | 3d | 0d |  | BLC | Blank | NA |  | NA | ET |  |
| 844 | 3.1.5.9.1.7.27 | Installation convoyeur trémie C1 + CF + volet AI |  | 2d | 2020-11-30 | 2020-12-01 | 838, 843 | 3d |  |  | BHS | Installation | C1 |  | 1 convoyeur, 1 mètre | INT | 1 méca + 1 élec |
| 845 | 3.1.5.9.1.7.28 | Test Ligne arrivée C1 |  | 18d | 2020-12-10 | 2021-01-14 | 837, 838, 840, 841, 844 | -3d | 0d |  | BLC | Commissioning | C1 |  | NA | ET | 1 automaticien + 1 élec |
| 846 | 3.1.5.9.1.7.29 | VABF Ligne arrivée C1 (B.F LIV n°1) |  | 2d | 2021-01-15 | 2021-01-18 | 845 | -3d | 0d |  | BHS | Installation | C1 | Installation | NA | INT | 1 automaticien |
| 847 | 3.1.5.9.1.7.30 | Mise en service Ligne arrivée C1 (B.F LIV n°1) | milestone | 0d | 2021-01-18 | 2021-01-18 | 846 | -3d | 0d | start no earlier than 2019-08-05 | BHS | Installation | C1 | Installation | NA | INT |  |
| 848 | 3.1.5.9.1.7.31 | Fin installation lignes départs dans gare triage au fur et à mesure des lignes arrivées | milestone | 0d | 2021-01-18 | 2021-01-18 | 839, 847 | -3d | 0d |  | BHS | Blank | NA |  | NA | INT |  |

Notes:
- 824: G20 et G25=HBS3, HF1 et HF2=HBS2, G30 et G35=HBS5, G40=HBS7
- 839: G20 et G25=HBS3, HF1 et HF2=HBS2, G30 et G35=HBS5, G40=HBS7

| ID | WBS | Task | Type | Duration | Start | Finish | Predecessors | Total slack | Free slack | Constraint | Text1 | Text12 | Text21 | Text26 | Acteur | Text27 | Text14 | name 2 | Etage | Forte affluence |
| --- | --- | --- | --- | --- | --- | --- | --- | --- | --- | --- | --- | --- | --- | --- | --- | --- | --- | --- | --- | --- |
| 849 | 3.1.5.9.1.7.32 | **Travaux Fonction C3 - TRI** |  | 32d | 2020-09-30 | 2020-11-12 |  | 0d |  |  | BHS | Blank | NA | Blank |  |  |  |  |  |  |
| 850 | 3.1.5.9.1.7.32.1 | Test Trieur Nord avec 10 MUP (suite) |  | 12d | 2020-09-30 | 2020-10-15 | 808 | 0d |  |  | BHS | Commissioning | NA | Commissioning | INT | 1 automaticien + 1 élec |  |  |  |  |
| 851 | 3.1.5.9.1.7.32.2 | Test Trieur Nord avec 10 MUP (suite) |  | 20d | 2020-10-16 | 2020-11-12 | 850 | 0d |  |  | BHS | Commissioning | NA | Commissioning | INT | 1 automaticien + 1 élec |  |  |  |  |
| 852 | 3.1.5.10 | **Phase 11** |  | 111d | 2020-11-19 | 2021-05-06 |  | -13d | 0d |  | BHS | Blank | NA | Blank |  |  |  |  |  |  |
| 853 | 3.1.5.10.1 | **Travaux Fonction C1 - ENREGISTREMENTS** |  | 25d | 2021-01-19 | 2021-02-22 |  | 0d |  |  | BHS | Blank | NA | Blank |  |  |  |  |  |  |
| 854 | 3.1.5.10.1.1 | Installation Check-In Hors Format HF2 (HBS2) + solde convoyeur manquant HF2 |  | 15d | 2021-01-19 | 2021-02-08 | 848, 647 | 0d |  |  | BHS | Installation | HBS2 | Installation | INT | ??? | Voir Margherita pour solde ligne HBS2 |  |  |  |
| 855 | 3.1.5.10.1.2 | Test Check-In Hors Format HF2 (HBS2) |  | 10d | 2021-02-09 | 2021-02-22 | 854, 867 | 0d |  |  | BHS | Commissioning | HBS2 |  | INT |  |  |  |  |  |
| 856 | 3.1.5.10.2 | **Travaux Fonction C2 - CONTROLE SURETE** |  | 66d | 2020-11-19 | 2021-03-02 |  | -13d | 0d |  | BHS | Blank | NA | Blank |  | 1 automaticien + 1 élec |  |  |  |  |
| 857 | 3.1.5.10.2.1 | Test HBS1 et HBS2 (sous la trémie) |  | 20d | 2021-01-12 | 2021-02-08 | 811, 879SS | 83d |  |  | BHS | Commissioning | HBS1 |  | INT | 1 automaticien + 1 élec |  |  |  |  |
| 858 | 3.1.5.10.2.2 | Installation zone controle complementaire (carousel temps supplémentaire) |  | 30d | 2021-01-18 | 2021-02-26 | 812, 814 | -37d | 0d |  | BHS | Installation | NA | Installation | INT | 2 méca + 2 élec |  |  |  |  |
| 859 | 3.1.5.10.2.3 | Installation Lignes AuF HBS5 définitive et HBS6 provisoire (car passerelle existante) (Cours de France) |  | 30d | 2021-01-18 | 2021-02-26 | 812, 492, 432, 814 | 0d |  |  | BHS | Installation | HBS5;HBS6 | Installation | INT | 2 méca + 2 élec |  |  |  |  |
| 860 | 3.1.5.10.2.4 | Installation zone ETD (pour les lignes AuF) |  | 32d | 2021-01-18 | 2021-03-02 | 812, 814 | -39d | 0d | start no earlier than 2020-07-22 | BHS | Installation | ETD | Installation | INT | 2 méca + 2 élec |  |  |  |  |
| 861 | 3.1.5.10.2.5 | Installation informatique Sheraton |  | 30d | 2020-11-19 | 2021-01-11 | 493 | -13d | 0d |  | BLC | Blank | NA |  | GA |  |  |  |  |  |
| 862 | 3.1.5.10.3 | **Travaux Fonction C4 - EBS** |  | 60d | 2021-02-10 | 2021-05-06 |  | -33d | 0d |  | BHS | Blank | NA | Blank |  |  |  | EBS |  |  |
| 863 | 3.1.5.10.3.1 | Installation lignes EBS AIRE A |  | 60d | 2021-02-10 | 2021-05-06 | 806 | -33d | 0d |  | BHS | Installation | NA |  | INT | 10 méca + 10 élec |  |  |  |  |
| 864 | 3.1.5.10.4 | **Travaux Fonction C2 - CONTROLE SURETE** |  | 22d | 2021-01-19 | 2021-02-17 |  | -3d | 0d |  |  | Blank | NA |  |  |  |  |  |  |  |
| 865 | 3.1.5.10.4.1 | Test Ligne HBS3 au RZ00 |  | 5d | 2021-01-19 | 2021-01-25 | 848 | -3d | 0d |  | BHS | Commissioning | HBS3 |  | INT | 1 automaticien + 1 élec |  |  | RZ00 |  |
| 866 | 3.1.5.10.4.2 | Test Ligne HBS5 au RZ00 |  | 5d | 2021-01-26 | 2021-02-01 | 865 | 88d | 61d |  | BHS | Commissioning | HBS5 |  | INT | 1 automaticien + 1 élec |  |  | RZ00 |  |
| 867 | 3.1.5.10.4.3 | Test Ligne HBS2 au RZ00 |  | 5d | 2021-01-19 | 2021-01-25 | 606, 633, 636, 741, 848 | 0d |  |  | BHS | Commissioning | HBS2 |  | INT | 1 automaticien + 1 élec |  |  | RZ00 |  |
| 868 | 3.1.5.10.4.4 | Test Ligne HBS6 au RZ00 |  | 5d | 2021-01-26 | 2021-02-01 | 867 | 181d | 0d |  | BHS | Commissioning | HBS6 |  | INT | 1 automaticien + 1 élec |  |  | RZ00 |  |
| 869 | 3.1.5.10.4.5 | Test Ligne HBS7 au RZ00 |  | 5d | 2021-02-02 | 2021-02-08 | 868 | 181d | 0d |  | BHS | Commissioning | HBS7 |  | INT | 1 automaticien + 1 élec |  |  |  |  |
| 870 | 3.1.5.10.4.6 | Test Ligne HBS8 au RZ00 |  | 5d | 2021-02-09 | 2021-02-15 | 869 | 181d |  |  | BHS | Commissioning | HBS8 |  | INT | 1 automaticien + 1 élec |  |  |  |  |
| 871 | 3.1.5.10.4.7 | Installation Ligne Transfer1 |  | 10d | 2021-01-19 | 2021-02-01 | 847 | 0d |  |  | BHS | Installation | TR1 | Installation | INT | 2 méca + 2 élec |  |  |  | Période 5 partielle |
| 872 | 3.1.5.10.4.8 | Test Ligne Transfer1 (B.F. Ligne AuF Tr1) |  | 10d | 2021-02-02 | 2021-02-15 | 871 | 0d |  |  | BHS | Commissioning | TR1 | Commissioning | INT | 1 automaticien + 1 élec |  |  |  |  |
| 873 | 3.1.5.10.4.9 | VABF Ligne Transfer1 (B.F. Ligne AuF Tr1) |  | 2d | 2021-02-16 | 2021-02-17 | 872 | 0d |  |  | BHS | Blank | TR1 | Blank | INT/IS/GA | 1 automaticien |  |  |  |  |
| 874 | 3.1.5.10.4.10 | Mise en service Ligne Transfer1 (B.F. Ligne AuF Tr1) | milestone | 0d | 2021-02-17 | 2021-02-17 | 873 | 0d |  |  | BHS | Working | TR1 | Working | INT |  |  |  |  |  |

Notes:
- 849: Text29: NA
- 850: Text29: NA
- 852: Text29: NA
- 853: Text29: NA
- 854: Text29: 1 Check-In HF
- 855: Text29: NA
- 856: Text29: NA
- 857: Text29: NA
- 858: Text29: 7 convoyeurs, 19 mètres + 1 carrousel + 2 courbes + 1 pusher
- 859: Text29: 15 convoyeurs, 62 mètres + 4 courbes
- 860: Text29: 34 convoyeurs, 98 mètres + 4 courbes + 4 rollers
- 861: A corréler avec planning IT au niveau de la durée
- 862: Text29: NA
- 863: Text29: 242 convoyeurs, 1173 mètres + 19 courbes + 2 élévateurs continue + 8 élévateurs discontinue + 4 vertical diverter + 1 merge + 14 pushers + 2 ATR
- 864: Text29: NA
- 865: Text29: NA
- 866: Text29: NA
- 867: Text29: NA
- 868: Text29: NA
- 869: Text29: NA
- 870: Text29: NA
- 871: Text29: 4 convoyeurs, 28 mètres + 2 courbes
- 872: Text29: NA
- 873: Text29: NA
- 874: Text29: NA

| ID | WBS | Task | Type | Duration | Start | Finish | Predecessors | Total slack | Free slack | Text1 | Text12 | Text21 | Text26 | Acteur | Text27 | Etage | name 2 | Text13 | Text17 | Text18 |
| --- | --- | --- | --- | --- | --- | --- | --- | --- | --- | --- | --- | --- | --- | --- | --- | --- | --- | --- | --- | --- |
| 875 | 3.1.5.11 | **Phase 12** |  | 141d | 2021-01-12 | 2021-08-02 |  | -33d | 0d | BHS | Blank | NA | Blank |  |  |  |  |  |  |  |
| 876 | 3.1.5.11.1 | **Travaux Fonction C2 - CONTROLE SURETE** |  | 54d | 2021-01-12 | 2021-03-26 |  | -13d | 0d | BHS | Blank | NA | Blank |  |  |  |  |  |  |  |
| 877 | 3.1.5.11.1.1 | Test HBS5 HBS6 CdF |  | 5d | 2021-03-01 | 2021-03-05 | 859 | 64d | 37d | BHS | Commissioning | HBS5;HBS6 |  | INT | 1 automaticien + 1 élec |  |  |  |  |  |
| 878 | 3.1.5.11.1.2 | Test Lignes HBS3 et HBS4 SS01 |  | 20d | 2021-01-12 | 2021-02-08 | 816, 861, 741 | -13d | 0d | BHS | Commissioning | HBS3;HBS4 | Commissioning | INT | 1 automaticien + 1 élec | SS01 |  |  |  |  |
| 879 | 3.1.5.11.1.3 | Test Lignes HBS1 et HBS2 SS01 |  | 10d | 2021-01-12 | 2021-01-25 | 790, 861, 741, 811, 747, 748 | 10d | 0d | BHS | Commissioning | HBS1/HBS2 | Commissioning | INT | 1 automaticien + 1 élec |  |  |  |  |  |
| 880 | 3.1.5.11.1.4 | Test COMPLET pour mise en service HF1 (HBS2) |  | 10d | 2021-02-09 | 2021-02-22 | 879, 867, 718, 815 | 0d |  | BHS | Commissioning | HBS2 | Commissioning | INT | 1 automaticien + 1 élec |  |  |  |  |  |
| 881 | 3.1.5.11.1.5 | Test COMPLET pour mise en service HF2 (HBS2) |  | 10d | 2021-02-09 | 2021-02-22 | 867, 879, 718, 854 | 0d |  | BHS | Commissioning | HBS2 |  | INT | 1 automaticien + 1 élec |  |  |  |  |  |
| 882 | 3.1.5.11.1.6 | VABF COMPLET pour mise en service HF1 (HBS2) |  | 10d | 2021-02-23 | 2021-03-08 | 880 | 0d |  | BHS | Blank | HBS2 | Blank | INT/IS/GA | 1 automaticien |  |  |  |  |  |
| 883 | 3.1.5.11.1.7 | VABF COMPLET pour mise en service HF2 (HBS2) |  | 10d | 2021-02-23 | 2021-03-08 | 881 | 0d |  | BHS | Blank | HBS2 |  | INT/IS/GA | 1 automaticien |  |  |  |  |  |
| 884 | 3.1.5.11.1.8 | Test Lignes ETD |  | 10d | 2021-03-03 | 2021-03-16 | 860, 858, 812, 861, 741, 814 | -39d | 0d | BHS | Commissioning | ETD | Commissioning | INT | 1 automaticien + 1 élec |  |  |  |  |  |
| 885 | 3.1.5.11.1.9 | Installation Lignes AuF HBS5 et HBS6 (HBS Sud) |  | 20d | 2021-03-01 | 2021-03-26 | 859, 491 | 44d | 0d | BHS | Installation | HBS5;HBS6 | Installation | INT | 4 méca + 4 élec |  |  |  |  |  |
| 886 | 3.1.5.11.2 | **Travaux Fonction C4 - EBS** |  | 60d | 2021-05-07 | 2021-08-02 |  | -33d | 0d | BHS | Blank | NA |  | INT |  |  | EBS |  |  |  |
| 887 | 3.1.5.11.2.1 | Test EBS SS01 et SS02 |  | 60d | 2021-05-07 | 2021-08-02 | 863 | -33d | 0d | BHS | Commissioning | EBS | Installation | INT | 1 automaticien + 1 élec |  | EBS |  |  |  |
| 888 | 3.1.5.12 | **Phase 13** |  | 50d | 2021-03-01 | 2021-05-11 |  | 0d |  | BHS | Blank | NA | Blank |  |  |  |  |  |  |  |
| 889 | 3.1.5.12.1 | **Travaux Fonction C2 - CONTROLE SURETE** |  | 50d | 2021-03-01 | 2021-05-11 |  | 0d |  | BHS | Blank | NA | Blank |  |  |  |  |  |  |  |
| 890 | 3.1.5.12.1.1 | Test HBS5 HBS6 SS01 |  | 5d | 2021-03-29 | 2021-04-06 | 885 | 44d | 17d | BHS | Commissioning | HBS5;HBS6 |  | INT | 1 automaticien + 1 élec | SS01 |  |  |  |  |
| 891 | 3.1.5.12.1.2 | Installation Lignes AuF HBS7 avec connection provisoire et HBS8 (Cours de France) |  | 20d | 2021-03-01 | 2021-03-26 | 859 | 0d |  | BHS | Installation | HBS7;HBS8 | Installation | INT | 2 méca + 2 élec |  |  |  |  |  |
| 892 | 3.1.5.12.1.3 | Mise en service HF1 (HBS2) | milestone | 0d | 2021-03-08 | 2021-03-08 | 882 | 0d |  | BHS | Working | HBS2 | Working | INT |  |  |  |  |  |  |
| 893 | 3.1.5.12.1.4 | Mise en service HF2 (HBS2) | milestone | 0d | 2021-03-08 | 2021-03-08 | 883 | 0d |  |  | Working | HBS2 |  | INT |  |  |  |  |  |  |
| 894 | 3.1.5.12.1.5 | Consignation HF4000 | milestone | 0d | 2021-05-07 | 2021-05-07 | 893, 918SS, 892 | 0d |  | GA | Blank | HF4000 |  | GA |  |  |  |  |  |  |
| 895 | 3.1.5.12.1.6 | Démontage HF4000 à la remise en service de HF2 |  | 2d | 2021-05-10 | 2021-05-11 | 894 | 0d |  | BHS | Dismounting | HF4000 |  | INT |  | B C |  | RZ00 | BHS | 45-48/EH |
| 896 | 3.1.5.13 | **Phase 14** |  | 57d | 2021-03-17 | 2021-06-09 |  | -39d | 0d | BHS | Blank | NA | Blank |  |  |  |  |  |  |  |
| 897 | 3.1.5.13.1 | **Travaux Fonction C5 - ARRIVEE** |  | 18d | 2021-05-10 | 2021-06-04 |  | 0d |  | BHS | Blank | NA | Blank |  |  |  |  |  |  |  |
| 898 | 3.1.5.13.1.1 | Demontage lignes provisoire 0900 zone gare de triage |  | 18d | 2021-05-10 | 2021-06-04 | 908, 714 | 0d |  | BHS | Dismounting | 900 | Dismounting | INT | 1 méca + 1 élec |  |  |  |  |  |

Notes:
- 875: Text29: NA
- 876: Text29: NA
- 877: Text29: NA
- 878: Text29: NA
- 879: Text29: NA
- 880: Text29: NA
- 881: Text29: NA
- 882: Text29: NA
- 883: Text29: NA
- 884: Text29: NA
- 885: Text29: 64 convoyeurs, 144 mètres + 13 courbes + 2 vertical diverter + 1 courbe HELIX + 2 ATR + 2 EDS
- 886: Text29: NA
- 888: Text29: NA
- 889: Text29: NA
- 890: Text29: NA
- 891: Text29: 21 convoyeurs, 69 mètres + 2 horizontal diverter + 1 vertical diverter
- 892: Text29: NA
- 893: Text29: NA
- 894: Text29: NA
- 895: Attention, peut être que VCS aura besoin de la zone avant le démontage 3000 pour création locaux
- 896: Text29: NA
- 897: Text29: NA
- 898: Text29: 10 convoyeurs, 75 mètres + 1 courbe

| ID | WBS | Task | Type | Duration | Start | Finish | Predecessors | Total slack | Free slack | Text1 | Forte affluence | Text12 | Text21 | Text26 | Acteur | Text27 | name 2 | Etage | Coordonnées | Text13 |
| --- | --- | --- | --- | --- | --- | --- | --- | --- | --- | --- | --- | --- | --- | --- | --- | --- | --- | --- | --- | --- |
| 899 | 3.1.5.13.2 | **Travaux Fonction C3 - TRI** |  | 51d | 2021-03-17 | 2021-06-01 |  | -39d | 0d | BHS | Période 3 partielle | Blank | NA | Blank |  |  |  |  |  |  |
| 900 | 3.1.5.13.2.1 | Test COMPLET pour mise en service groupe de Check-In sur Trieur Nord inclu HBS3 et HBS4 |  | 22d | 2021-03-17 | 2021-04-19 | 851, 878, 884, 865, 861, 741 | -39d | 0d | BHS |  | Commissioning | Trieur Nord | Commissioning | INT | 1 automaticien + 1 élec |  |  |  |  |
| 901 | 3.1.5.13.2.2 | VABF COMPLET pour mise en service groupe de Check-In sur Trieur Nord inclu HBS3 et HBS4 |  | 6d | 2021-04-20 | 2021-04-27 | 900 | -39d | 0d | BHS |  | Blank | Trieur Nord | Blank | INT/IS/GA | 1 automaticien |  |  |  |  |
| 902 | 3.1.5.13.2.3 | Installation opérationnelle pour mise en service groupe de Check-In sur Trieur Nord inclu HBS3 et HBS4 | milestone | 0d | 2021-04-27 | 2021-04-27 | 901, 490FS-120d | -39d | 0d | BHS |  | Working | Trieur Nord | Working | INT |  |  |  |  |  |
| 903 | 3.1.5.13.2.4 | Demontage Trieur Selex et MUP |  | 15d | 2021-05-10 | 2021-06-01 | 908 | -39d | 0d | BHS | Période 3 partielle | Dismounting | NA | Dismounting | INT | 5 méca + 1 élec |  |  |  |  |
| 904 | 3.1.5.13.3 | **Travaux Fonction C1 - ENREGISTREMENTS** |  | 29d | 2021-04-28 | 2021-06-09 |  | -39d | 0d | BHS |  | Blank | NA | Blank |  |  |  |  |  |  |
| 905 | 3.1.5.13.3.1 | Connexion du Check-In G20 - G25 au nouveau BLC |  | 2d | 2021-04-28 | 2021-04-29 | 902, 759 | -39d | 0d | BHS |  | Installation | HBS3 |  | INT |  |  |  |  |  |
| 906 | 3.1.5.13.3.2 | Test Check-In G20 - G25 au nouveau BLC |  | 5d | 2021-04-30 | 2021-05-06 | 905 | -39d | 0d | BHS |  | Commissioning | HBS3 |  | INT | 1 automaticien + 1 élec |  |  |  |  |
| 907 | 3.1.5.13.3.3 | VABF Check-In G20 - G25 au nouveau BLC |  | 1d | 2021-05-07 | 2021-05-07 | 906 | -39d | 0d |  |  | Blank | HBS3 |  |  | 1 automaticien |  |  |  |  |
| 908 | 3.1.5.13.3.4 | Mise en service Check-In G20 - G25 et TRIEUR NORD au nouveau BLC | milestone | 0d | 2021-05-07 | 2021-05-07 | 907 | -39d | 0d |  |  | Working | NA |  |  |  |  |  |  |  |
| 909 | 3.1.5.13.3.5 | Installation Check-In HF3 (HBS1) et connection au RZ00 + CF |  | 11d | 2021-05-26 | 2021-06-09 | 921SS | 0d |  | BHS |  | Installation | HBS1 | Installation | INT | 2 méca + 1 élec |  |  |  |  |
| 910 | 3.1.5.14 | **Phase 15** |  | 79d | 2021-03-29 | 2021-07-21 |  | 0d |  | BHS |  | Blank | NA | Blank |  |  |  |  |  |  |
| 911 | 3.1.5.14.1 | **Travaux Fonction C2 - CONTROLE SURETE** |  | 20d | 2021-04-30 | 2021-05-31 |  | 27d |  | BHS |  | Blank | NA |  | INT |  |  |  |  |  |
| 912 | 3.1.5.14.1.1 | Test COMPLET pour mise en service lignes HBS5 HBS6 |  | 20d | 2021-04-30 | 2021-05-31 | 765, 866, 861, 890, 877 | 27d | 0d | BHS |  | Commissioning | HBS5/HBS6 |  | INT | 1 automaticien + 1 élec |  |  |  |  |
| 913 | 3.1.5.14.2 | VABF COMPLET pour mise en service lignes HBS5 HBS6 |  | 10d | 2021-06-01 | 2021-06-14 | 912 | 27d |  |  |  | Blank | HBS5/HBS6 |  |  | 1 automaticien |  |  |  |  |
| 914 | 3.1.5.14.3 | Installation Lignes AuF HBS7 et HBS8 (HBS Sud) |  | 45d | 2021-03-29 | 2021-06-03 | 891, 491 | 0d |  | BHS | Période 3 partielle | Installation | HBS7;HBS8 | Installation | INT | 2 méca + 2 élec |  |  |  |  |
| 915 | 3.1.5.14.4 | **Travaux Fonction C4 - EBS** |  | 10d | 2021-06-02 | 2021-06-15 |  | 1d |  | BHS |  | Blank | NA |  | INT |  | EBS |  |  |  |
| 916 | 3.1.5.14.4.1 | Installation connexions EBS entrée (RZ00 extension IATA) avec élévateur |  | 10d | 2021-06-02 | 2021-06-15 | 750, 932SS | 1d |  | BHS |  | Installation | NA |  | INT | 3 méca + 2 élec | EBS | RZ00 |  |  |
| 917 | 3.1.5.14.5 | **Travaux Fonction C1 - ENREGISTREMENTS** |  | 27d | 2021-05-07 | 2021-06-17 |  | 0d |  | BHS |  | Blank | NA | Blank |  |  |  |  |  |  |
| 918 | 3.1.5.14.5.1 | Consignation banque 3000 et collecteur | milestone | 0d | 2021-05-07 | 2021-05-07 | 908, 893, 892 | 0d |  | BLC |  | Blank | NA |  | GA |  |  |  |  |  |
| 919 | 3.1.5.14.5.2 | Demontage banques 3000 et ligne collecteur |  | 5d | 2021-05-10 | 2021-05-17 | 918 | 0d |  | BHS |  | Dismounting | NA |  | INT | 6 méca + 2 élec |  | RZ00 | 29-31/G | 2.2 |
| 920 | 3.1.5.14.5.3 | Installation mécanique collecteur G55 + ligne d'acheminement + volet |  | 5d | 2021-05-18 | 2021-05-25 | 919 | 0d |  | BHS |  | Installation | HBS4 |  | INT | 4 méca |  | RZ00 | 27-30/G | 2.2 |
| 921 | 3.1.5.14.5.4 | Installation Check-In G55 |  | 5d | 2021-05-26 | 2021-06-01 | 920 | 0d |  | BHS |  | Installation | NA |  | INT | 2 méca |  | RZ00 | 27-30/G | 2.2 |
| 922 | 3.1.5.14.5.5 | Installation électrique collecteurs + convoyeur Check-In + volet G55 |  | 5d | 2021-06-02 | 2021-06-08 | 921 | 0d |  | BHS |  | Installation | HBS4 |  | INT | 4 élec |  | RZ00 | 27-30/G | 2.2 |
| 923 | 3.1.5.14.5.6 | Test banques G55 sur installation BLC |  | 5d | 2021-06-09 | 2021-06-15 | 922 | 0d |  | BHS |  | Commissioning | HBS4 |  | INT | 1 automaticien + 1 élec |  |  |  |  |
| 924 | 3.1.5.14.5.7 | VABF banques G55 sur installation BLC |  | 2d | 2021-06-16 | 2021-06-17 | 923 | 0d |  | BHS |  | Blank | HBS4 |  | INT | 1 automaticien |  |  |  |  |
| 925 | 3.1.5.14.5.8 | Mise en service banques G55 sur installation BLC | milestone | 0d | 2021-06-17 | 2021-06-17 | 924 | 0d |  | BHS |  | Working | HBS4 |  | INT |  |  |  |  |  |

Notes:
- 899: Text29: NA
- 900: Text29: NA
- 901: Text29: NA
- 902: Text29: NA
- 904: Text29: NA
- 906: Text29: NA
- 907: Text29: NA
- 908: Text29: NA
- 909: Text29: 3 convoyeurs, 10 mètres + 1 courbe + 1 merge + 2 Check-In HF
- 910: Text29: NA
- 911: Text29: NA
- 912: Text29: NA
- 913: Text29: NA
- 914: Text29: 61 convoyeurs, 150 mètres + 3 courbes + 2 vertical diverter + 2 ATR + 2 EDS
- 915: Text29: NA
- 916: Text29: 12 convoyeurs, 28 mètres + 9 courbes + 1 chute
- 917: Text29: NA
- 918: Text29: NA
- 919: Text29: 29 convoyeurs, 90 mètres + 9 Check-In
- 920: Text29: 7 convoyeurs, 36 mètres + 2 courbes + 1 ATR
- 921: Text29: 4 Check-In
- 923: Text29: NA
- 924: Text29: NA
- 925: Text29: NA

| ID | WBS | Task | Type | Duration | Start | Finish | Predecessors | Total slack | Free slack | Text1 | Text12 | Text21 | Text26 | Text29 | Acteur | Text27 | name 2 | Etage |
| --- | --- | --- | --- | --- | --- | --- | --- | --- | --- | --- | --- | --- | --- | --- | --- | --- | --- | --- |
| 926 | 3.1.5.14.6 | **Travaux Fonction C2 - CONTROLE SURETE** |  | 20d | 2021-06-10 | 2021-07-07 |  | 0d |  | BHS | Blank | NA | Blank | NA |  |  |  |  |
| 927 | 3.1.5.14.6.1 | Test COMPLET Check-In HF3 (HBS1) |  | 15d | 2021-06-10 | 2021-06-30 | 909, 879, 857, 718 | 0d |  | BHS | Commissioning | HBS1 |  | NA | INT/IS/GA | 1 automaticien + 1 élec |  |  |
| 928 | 3.1.5.14.6.2 | VABF COMPLET Check-In HF3 (HBS1) |  | 5d | 2021-07-01 | 2021-07-07 | 927 | 0d |  | BHS | Blank | HBS1 | Blank | NA | INT/IS/GA | 1 automaticien |  |  |
| 929 | 3.1.5.14.6.3 | Mise en service Check-In HF3 (HBS1) | milestone | 0d | 2021-07-07 | 2021-07-07 | 928 | 0d |  | BHS | Working | HBS1 | Working | NA | INT |  |  |  |
| 930 | 3.1.5.14.7 | **Travaux Fonction C3 - TRI** |  | 79d | 2021-03-29 | 2021-07-21 |  | 0d |  | BHS | Blank | NA | Blank | NA |  |  |  |  |
| 931 | 3.1.5.14.7.1 | Installation MUP Trieur Nord (2eme partie) |  | 37d | 2021-03-29 | 2021-05-21 | 914SS | 0d |  | BHS | Installation | NA | Installation |  | INT |  |  |  |
| 932 | 3.1.5.14.7.2 | Installation MUP Trieur Nord (4 latérals IATA) |  | 30d | 2021-06-02 | 2021-07-13 | 903 | -39d | 0d | BHS | Installation | NA | Installation | 9 convoyeurs + 8 compteur + 4 chutes latérales + 4 chutes | INT |  |  |  |
| 933 | 3.1.5.14.7.3 | Test MUP Trieur Nord (4 latérals IATA) |  | 5d | 2021-07-14 | 2021-07-20 | 932 | 0d |  | BHS | Commissioning | NA | Commissioning | NA | INT | 1 automaticien + 1 élec |  |  |
| 934 | 3.1.5.14.7.4 | VABF MUP Trieur Nord (4 latérals IATA) |  | 1d | 2021-07-21 | 2021-07-21 | 933 | 0d |  | BHS | Blank | NA | Blank | NA | INT/IS/GA | 1 automaticien |  |  |
| 935 | 3.1.5.14.7.5 | Mise en service MUP Trieur Nord (4 latérals IATA) | milestone | 0d | 2021-07-21 | 2021-07-21 | 934 | 0d |  | BHS | Working | NA | Working | NA | INT |  |  |  |
| 936 | 3.1.5.15 | **Phase 16** |  | 93d | 2021-06-04 | 2021-10-13 |  | -11d | 0d | BHS | Blank | NA | Blank | NA |  |  |  |  |
| 937 | 3.1.5.15.1 | **Travaux Fonction C2 - CONTROLE SURETE** |  | 35d | 2021-06-04 | 2021-07-22 |  | 0d |  | BHS | Blank | NA | Blank | NA |  |  |  |  |
| 938 | 3.1.5.15.1.1 | Test Lignes HBS7 et HBS8 SS01 |  | 35d | 2021-06-04 | 2021-07-22 | 914, 891, 861 | 0d |  | BHS | Commissioning | HBS7;HBS8 | Commissioning | NA | INT |  |  |  |
| 939 | 3.1.5.15.2 | **Travaux Fonction C3 - TRI** |  | 15d | 2021-09-07 | 2021-09-29 |  | -39d | 0d | BHS | Blank | NA | Blank | NA |  |  |  |  |
| 940 | 3.1.5.15.2.1 | Consignation carrousel existant | milestone | 0d | 2021-09-07 | 2021-09-07 | 950 | -39d | 0d | BLC | Stopped | NA | Stopped | NA | GA |  |  |  |
| 941 | 3.1.5.15.2.2 | Demontage carrousel EBS actuel |  | 8d | 2021-09-08 | 2021-09-20 | 940 | -39d | 0d | BHS | Dismounting | EBS | Dismounting | 1 carrousel de 56 mètres | INT | 5 méca + 1 élec | EBS |  |
| 942 | 3.1.5.15.2.3 | Installation plateforme injections Trieur Sud |  | 15d | 2021-09-08 | 2021-09-29 | 950 | -36d | 0d | BHS | Installation | NA | Installation |  | INT |  |  |  |
| 943 | 3.1.5.15.2.4 | Démontage plateforme ULD dans IATA |  | 15d | 2021-09-08 | 2021-09-29 | 941SS | -36d | 0d | BHS | Dismounting | NA |  |  | INT |  |  |  |
| 944 | 3.1.5.15.3 | **Travaux Fonction C4 - EBS** |  | 40d | 2021-07-14 | 2021-09-07 |  | -39d | 0d | BHS | Blank | NA | Blank | NA |  |  | EBS |  |
| 945 | 3.1.5.15.3.1 | Installation plateforme sortie EBS MEZZANINE IATA |  | 10d | 2021-07-14 | 2021-07-27 | 932 | -39d | 0d | BHS | Installation | NA |  |  |  |  |  | RZ00 |
| 946 | 3.1.5.15.3.2 | Installation connexions sortie EBS MEZZANINE IATA avec élévateur |  | 10d | 2021-07-28 | 2021-08-10 | 945 | -39d | 0d | BHS | Installation | NA |  |  |  |  |  |  |
| 947 | 3.1.5.15.3.3 | Installation ligne inter-trieur TN vers TS (coté Est) |  | 10d | 2021-08-11 | 2021-08-24 | 946 | 39d |  | BHS | Installation | NA |  |  |  |  |  |  |
| 948 | 3.1.5.15.3.4 | Test EBS vers Trieur Nord (B.F. EBS; B.F. CONNEXIONS) |  | 15d | 2021-08-11 | 2021-08-31 | 916, 946, 887 | -39d | 0d | BHS | Commissioning | EBS | Commissioning | NA | INT | 1 automaticien + 1 élec | EBS |  |
| 949 | 3.1.5.15.3.5 | VABF EBS vers Trieur Nord (B.F. EBS; B.F. CONNEXIONS) |  | 5d | 2021-09-01 | 2021-09-07 | 948 | -39d | 0d | BHS | Blank | EBS | Blank | NA | INT/IS/GA | 1 automaticien | EBS |  |
| 950 | 3.1.5.15.3.6 | Mise en service EBS vers Trieur Nord (B.F. EBS; B.F. CONNEXIONS) | milestone | 0d | 2021-09-07 | 2021-09-07 | 949 | -39d | 0d | BHS | Working | EBS | Working | NA | INT |  | EBS |  |

Notes:
- 942: Pour gagner du temps, on peut changer de predecesseurs et mettre après MES MUP 4 latérals

| ID | WBS | Task | Type | Duration | Start | Finish | Predecessors | Total slack | Free slack | Constraint | Text1 | Text12 | Text21 | Text26 | Acteur | Coordonnées | Etage | Forte affluence | Text27 | name 2 |
| --- | --- | --- | --- | --- | --- | --- | --- | --- | --- | --- | --- | --- | --- | --- | --- | --- | --- | --- | --- | --- |
| 951 | 3.1.5.15.4 | **Travaux Fonction C1 - ENREGISTREMENTS** |  | 59d | 2021-07-21 | 2021-10-13 |  | 0d |  |  | BHS | Blank | NA | Blank |  |  |  |  |  |  |
| 952 | 3.1.5.15.4.1 | Consignation banque 2500 et collecteur | milestone | 0d | 2021-07-21 | 2021-07-21 | 925, 913, 935 | 0d |  |  | BLC | Stopped | NA | Stopped | GA | 17-21/G | RZ00 |  |  |  |
| 953 | 3.1.5.15.4.2 | Demontage banques 2500 et ligne collecteur |  | 7d | 2021-07-22 | 2021-07-30 | 952 | 0d |  |  | BHS | Dismounting | NA | Dismounting | INT | 17-21/G | RZ00 | Période 4 | 6 méca + 2 élec |  |
| 954 | 3.1.5.15.4.3 | Installation mécanique collecteur G35 + G40 partielle + ligne d'acheminement + volet |  | 6d | 2021-08-02 | 2021-08-09 | 953 | 0d |  |  | BHS | Installation | HBS5 | Installation | INT | 17-21/G | RZ00 |  | 12 méca |  |
| 955 | 3.1.5.15.4.4 | Installation Check-In G35 + G40 partielle (fonctionnement dans le sens G35) |  | 8d | 2021-08-10 | 2021-08-19 | 954, 413 | 0d |  |  | BHS | Installation | HBS5 |  | INT | 17-21/G | RZ00 |  |  |  |
| 956 | 3.1.5.15.4.5 | Installation électrique collecteurs + convoyeur Check-In + volet G35 + G40 partielle |  | 8d | 2021-08-20 | 2021-08-31 | 955, 912 | 0d |  |  | BHS | Installation | HBS5 |  | INT | 17-21/G | RZ00 |  |  |  |
| 957 | 3.1.5.15.4.6 | Test banques G35 + G40 partielle(fonctionnement dans le sens G35) sur BLC (lignes HBS5 + HBS6) |  | 25d | 2021-09-01 | 2021-10-06 | 956 | 0d |  |  |  | Commissioning | HBS5 | Commissioning | INT |  |  |  | 1 automaticien + 1 élec |  |
| 958 | 3.1.5.15.4.7 | VABF banques G35 + G40 partielle(fonctionnement dans le sens G35) sur BLC (lignes HBS5 + HBS6) |  | 5d | 2021-10-07 | 2021-10-13 | 957 | 0d |  |  |  | Blank | HBS5 | Blank | INT |  |  |  | 1 automaticien |  |
| 959 | 3.1.5.15.4.8 | Mise en service banques G35 + G40 partielle(fonctionnement dans le sens G35) sur BLC (lignes HBS5 + HBS6) | milestone | 0d | 2021-10-13 | 2021-10-13 | 958 | 0d |  |  |  | Working | HBS5 | Working | INT |  |  |  |  |  |
| 960 | 3.1.5.16 | **Phase 17** |  | 75d | 2021-09-08 | 2021-12-22 |  | -36d | 0d |  | BHS | Blank | NA | Blank |  |  |  |  |  |  |
| 961 | 3.1.5.16.1 | **Travaux Fonction C3 - TRI** |  | 75d | 2021-09-08 | 2021-12-22 |  | -36d | 0d |  | BHS | Blank | NA | Blank |  |  |  |  |  |  |
| 962 | 3.1.5.16.1.1 | Installation portiques + Trieur Sud (partiel) |  | 20d | 2021-09-30 | 2021-10-27 | 942, 943 | -36d | 0d | start no earlier than 2021-03-11 | BHS | Installation | Trieur Sud | Installation | INT |  |  |  | 5 méca + 5 élec |  |
| 963 | 3.1.5.16.1.2 | Installation ligne d'injection HBS8 sur Trieur Sud (connexion IATA) |  | 20d | 2021-09-30 | 2021-10-27 | 942 | -6d | 0d |  | BHS | Installation | NA | Installation | INT |  |  |  | 2 méca + 2 élec |  |
| 964 | 3.1.5.16.1.3 | Installation plateforme + Lignes EBS vers Trieur Sud |  | 40d | 2021-09-21 | 2021-11-15 | 941 | -39d | 0d |  | BHS | Installation | EBS | Installation | INT |  |  |  | 1 méca + 1 élec | EBS |
| 965 | 3.1.5.16.1.4 | Installation MUP chute Trieur Nord coté Est (2 chutes sur 6 A éliminer) |  | 15d | 2021-09-08 | 2021-09-29 | 950 | 0d |  |  | BHS | Installation | NA | Installation | INT |  |  | Période 5 partielle | 3 méca + 3 élec |  |
| 966 | 3.1.5.16.1.5 | Test MUP chute Trieur Nord coté Est (2 chutes sur 6 A éliminer) |  | 6d | 2021-09-30 | 2021-10-07 | 965 | 0d |  |  | BHS | Commissioning | NA | Commissioning | INT |  |  |  | 1 automaticien + 1 élec |  |
| 967 | 3.1.5.16.1.6 | VABF MUP chute Trieur Nord coté Est (2 chutes sur 6 A éliminer) |  | 1d | 2021-10-08 | 2021-10-08 | 966 | 0d |  |  | BHS | Blank | NA | Blank | INT/IS/GA |  |  |  | 1 automaticien |  |
| 968 | 3.1.5.16.1.7 | Mise en service MUP chute Trieur Nord coté Est (2 chutes sur 6) | milestone | 0d | 2021-10-08 | 2021-10-08 | 967 | 0d |  |  | BHS | Working | NA | Working | INT |  |  |  |  |  |
| 969 | 3.1.5.16.1.8 | Installation ligne inter-trieur TS vers TN (coté Est) |  | 10d | 2021-11-16 | 2021-11-29 | 973SS | -29d | 0d |  | BHS | Installation | EBS |  | INT |  |  |  |  |  |
| 970 | 3.1.5.16.1.9 | Test des 2 lignes inter-trieur coté Est |  | 10d | 2021-12-09 | 2021-12-22 | 977SS, 969, 947 | -36d | 0d |  | BHS | Commissioning | NA |  | INT |  |  |  | 1 automaticien + 1 élec |  |
| 971 | 3.1.5.17 | **Phase 18** |  | 73d | 2021-10-13 | 2022-02-02 |  | -27d | 0d |  | BHS | Blank | NA | Blank |  |  |  |  |  |  |
| 972 | 3.1.5.17.1 | **Travaux Fonction C4 - EBS** |  | 50d | 2021-11-16 | 2022-02-02 |  | -39d | 0d |  | BHS | Blank | NA | Blank |  |  |  |  |  | EBS |
| 973 | 3.1.5.17.1.1 | Installation Lignes EBS vers Trieur Sud (suite) |  | 45d | 2021-11-16 | 2022-01-26 | 964 | -39d | 0d |  | BHS | Installation | EBS | Installation | INT |  |  |  |  | EBS |
| 974 | 3.1.5.17.1.2 | Test Lignes EBS sans Trieur Sud |  | 5d | 2022-01-27 | 2022-02-02 | 973 | -39d | 0d |  | BHS | Commissioning | EBS | Commissioning | INT |  |  |  | 1 automaticien + 1 élec | EBS |

Notes:
- 951: Text29: NA
- 953: Text29: 20 convoyeurs, 160 mètres + 9 courbes + 15 Check-In
- 954: Text29: 7 convoyeurs, 30 mètres + 3 courbes + 1 ATR + 12 Check-In
- 957: Text29: NA
- 958: Text29: NA
- 959: Text29: NA
- 960: Text29: NA
- 961: Text29: NA
- 962: Text29: 130 mètres de trieur
- 963: Text29: 9 convoyeurs 15 mètres + 1 ATR + 1 introduction
- 964: Text29: 8 convoyeurs 30 mètres + 2 courbes + 1 introduction + 1 chute + 1 merge
- 965: Text29: 17 convoyeurs 75 mètres + 2 courbes + 12 chutes
- 966: Text29: NA
- 967: Text29: NA
- 968: Text29: NA
- 971: Text29: NA
- 972: Text29: NA
- 974: Text29: NA

| ID | WBS | Task | Type | Duration | Start | Finish | Predecessors | Total slack | Free slack | Constraint | Text12 | Text21 | Text1 | Acteur | Text26 | Text27 |
| --- | --- | --- | --- | --- | --- | --- | --- | --- | --- | --- | --- | --- | --- | --- | --- | --- |
| 975 | 3.1.5.17.2 | **Travaux Fonction C3 - TRI** |  | 40d | 2021-10-28 | 2021-12-22 |  | -36d | 0d |  | Blank | NA |  |  |  |  |
| 976 | 3.1.5.17.2.1 | Installation Trieur Sud, MUP 5 latérales côté ville et lignes d'injection (suite A éliminer) |  | 30d | 2021-10-28 | 2021-12-08 | 962 | -36d | 0d |  | Installation | Trieur Sud | BHS | INT | Installation | 8 méca + 8 élec |
| 977 | 3.1.5.17.2.2 | Test Trieur Sud + MUP 5 latérales côté ville (Une ligne d'injection A éliminer) |  | 10d | 2021-12-09 | 2021-12-22 | 976, 963 | -36d | 0d |  | Commissioning | Trieur Sud | BHS | INT | Commissioning | 1 automaticien + 1 élec |
| 978 | 3.1.5.17.3 | **Travaux Fonction C1 - ENREGISTREMENTS** |  | 46d | 2021-10-13 | 2021-12-16 |  | 0d |  |  | Blank | NA | BHS |  | Blank |  |
| 979 | 3.1.5.17.3.1 | Consignation Check-In et collecteur 5000 | milestone | 0d | 2021-10-13 | 2021-10-13 | 959, 508, 968 | 0d |  |  | Stopped | NA | BLC | GA | Stopped |  |
| 980 | 3.1.5.17.3.2 | Demontage Check-In et collecteur 5000 (Secteur France) |  | 4d | 2021-10-14 | 2021-10-19 | 979 | 0d |  |  | Dismounting | HBS8 | BHS | INT | Dismounting | 5 méca + 1 élec |
| 981 | 3.1.5.17.3.3 | Fin de démontage équipement pour intervention archi - Réalisation trémie au SF | milestone | 0d | 2021-10-19 | 2021-10-19 | 980 | 0d |  | start no earlier than 2020-08-04 | Blank | NA | BLC | INT |  |  |
| 982 | 3.1.5.17.3.4 | Installation mécanique collecteur G60 + ligne d'acheminement + volet |  | 7d | 2021-11-17 | 2021-11-25 | 980, 509 | 0d |  |  | Installation | NA | BHS | INT | Installation | 6 méca |
| 983 | 3.1.5.17.3.5 | Installation convoyeurs Check-In G60 |  | 7d | 2021-11-26 | 2021-12-06 | 982, 413 | 0d |  |  | Installation | HBS8 | BHS | INT |  | 3 méca |
| 984 | 3.1.5.17.3.6 | Installation électrique collecteurs + convoyeur Check-In + volet G60 |  | 8d | 2021-11-26 | 2021-12-07 | 983SS | 0d |  |  | Installation | HBS8 | BHS | INT |  | 6 élec |
| 985 | 3.1.5.17.3.7 | Test banques G60 sur installation BLC |  | 5d | 2021-12-08 | 2021-12-14 | 984, 805 | 0d |  |  | Commissioning | HBS8 | BHS | INT |  | 1 automaticien + 1 élec |
| 986 | 3.1.5.17.3.8 | VABF banques G60 (B.F. G60 - (HBS8)) sur installation BLC |  | 2d | 2021-12-15 | 2021-12-16 | 985 | 0d |  |  | Blank | HBS8 | BHS | INT |  | 1 automaticien |
| 987 | 3.1.5.17.3.9 | Mise en service banques G60 (B.F. G60 - (HBS8)) sur BLC | milestone | 0d | 2021-12-16 | 2021-12-16 | 986 | 0d |  |  | Working | HBS8 | BHS | INT |  |  |
| 988 | 3.1.5.18 | **Phase 19** |  | 69d | 2021-12-23 | 2022-04-07 |  | -36d | 0d |  | Blank | NA | BHS |  | Blank |  |
| 989 | 3.1.5.18.1 | **Travaux Fonction C3 - TRI** |  | 66d | 2021-12-23 | 2022-04-04 |  | -36d | 0d |  | Blank | NA | BHS |  | Blank |  |
| 990 | 3.1.5.18.1.1 | Installation MUP chute Trieur Sud coté Est (n.8) |  | 40d | 2022-01-27 | 2022-03-23 | 973 | -36d | 0d |  | Installation | NA | BHS |  |  |  |
| 991 | 3.1.5.18.1.2 | Test MUP chute Trieur Sud coté Est (n.8) |  | 6d | 2022-03-24 | 2022-03-31 | 990, 994 | -36d | 0d |  | Commissioning | NA | BHS | INT |  | 1 automaticien + 1 élec |
| 992 | 3.1.5.18.1.3 | VABF MUP chute Trieur Sud coté Est (n.8) |  | 2d | 2022-04-01 | 2022-04-04 | 991 | -36d | 0d |  | Blank | NA | BHS | INT |  | 1 automaticien |
| 993 | 3.1.5.18.1.4 | Mise en service MUP chute Trieur Sud coté Est (n.8) | milestone | 0d | 2022-04-04 | 2022-04-04 | 992 | -36d | 0d |  | Working | NA | BHS | INT |  |  |
| 994 | 3.1.5.18.1.5 | Test COMPLET pour mise en service groupe de Check-In sur Trieur Sud (Une ligne d'injection) |  | 15d | 2021-12-23 | 2022-01-21 | 977, 938, 869, 870, 970 | -36d | 0d |  | Commissioning | Trieur Sud | BHS | INT | Commissioning |  |
| 995 | 3.1.5.18.1.6 | VABF COMPLET pour mise en service groupe de Check-In sur Trieur Sud (Une ligne d'injection) |  | 5d | 2022-01-24 | 2022-01-28 | 994 | -36d | 0d |  | Blank | Trieur Sud | BHS | INT/IS/GA | Blank |  |
| 996 | 3.1.5.18.1.7 | Installation opérationnelle pour mise en service groupe de Check-In sur Trieur Sud (Une ligne d'injection) | milestone | 0d | 2022-01-28 | 2022-01-28 | 995 | -36d | 0d |  | Working | Trieur Sud | BHS | INT | Working |  |
| 997 | 3.1.5.18.2 | **Travaux Fonction C1 - ENREGISTREMENTS** |  | 26d | 2022-03-02 | 2022-04-07 |  | -39d | 0d |  | Blank | NA | BHS |  | Blank |  |
| 998 | 3.1.5.18.2.1 | Consignation Check-In et collecteur 1000 | milestone | 0d | 2022-03-02 | 2022-03-02 | 987, 1010, 996 | -39d | 0d |  | Stopped | NA | BLC | GA | Stopped |  |
| 999 | 3.1.5.18.2.2 | Démontage collecteur+check-In 1000 (la ligne derrière le mur sera démonté en même temps que la ligne 0000)) |  | 5d | 2022-03-03 | 2022-03-09 | 998 | -39d | 0d |  | Dismounting | NA | BHS | INT | Dismounting | 6 méca + 1 élec |
| 1000 | 3.1.5.18.2.3 | Démontage ligne pointe d'injection trieur au IATA |  | 5d | 2022-03-03 | 2022-03-09 | 998SS | 0d |  |  | Installation | HBS4 | BHS | INT | Installation |  |
| 1001 | 3.1.5.18.2.4 | Installation mécanique collecteur G50 + ligne d'acheminement |  | 7d | 2022-03-10 | 2022-03-18 | 999 | -39d | 0d |  | Installation | HBS4 | BHS | INT |  | 4 méca |
| 1002 | 3.1.5.18.2.5 | Installation Check-In G50 |  | 7d | 2022-03-21 | 2022-03-29 | 1001 | -39d | 0d |  | Installation | HBS4 | BHS | INT |  | 2 méca |
| 1003 | 3.1.5.18.2.6 | Installation électrique collecteurs + Check-In |  | 7d | 2022-03-21 | 2022-03-29 | 1001SS, 1002SS | -39d | 0d |  | Installation | HBS4 | BHS | INT |  | 6 élec |
| 1004 | 3.1.5.18.2.7 | Test Check-In G50 sur installation BLC |  | 5d | 2022-03-30 | 2022-04-05 | 1003, 1001 | -39d | 0d |  | Commissioning | HBS4 | BHS | INT | Commissioning | 1 automaticien + 1 élec |
| 1005 | 3.1.5.18.2.8 | VABF Check-In G50 (B.F. G50 - (HBS4)) sur installation BLC |  | 2d | 2022-04-06 | 2022-04-07 | 1004 | -39d | 0d |  | Blank | HBS4 | BHS | INT/IS/GA | Blank | 1 automaticien |
| 1006 | 3.1.5.18.2.9 | Mise en service Check-In G50 (B.F. G50 - (HBS4)) sur BLC | milestone | 0d | 2022-04-07 | 2022-04-07 | 1005 | -39d | 0d |  | Working | HBS4 | BHS | INT | Working |  |

Notes:
- 976: Text29: 13 convoyeurs, 65 mètres + 1 courbe + 170 mètres de trieur + 2 introduction + 24 chutes
- 978: Text29: NA
- 980: Text29: 14 Check-In + 25 mètres de convoyeurs
- 981: IMP ET
- 982: Text29: 15 convoyeurs, 52 mètres + 8 courbes + 1 vertical diverter + 1 merge + 1 ATR
- 983: Text29: 8 Check-In
- 985: Text29: NA
- 986: Text29: NA
- 987: Text29: NA
- 988: Text29: NA
- 989: Text29: NA
- 991: Text29: NA
- 992: Text29: NA
- 993: Text29: NA
- 994: Text29: NA
- 995: Text29: NA
- 997: Text29: NA
- 998: G2000 tourne sens G2500 / Text29: NA
- 999: Text29: 12 Check-In + 7 convoyeurs 60 mètres + 2 courbes + 1 volet
- 1001: Text29: 6 convoyeurs de 26 mètres + 2 courbes + 1 ATR + 1 merge
- 1002: Text29: 6 Check-In
- 1004: Text29: NA
- 1005: Text29: NA
- 1006: Text29: NA

| ID | WBS | Task | Type | Duration | Start | Finish | Predecessors | Total slack | Free slack | Text1 | name 2 | Text12 | Text21 | Text26 | Text29 | Acteur | Text27 | Forte affluence |
| --- | --- | --- | --- | --- | --- | --- | --- | --- | --- | --- | --- | --- | --- | --- | --- | --- | --- | --- |
| 1007 | 3.1.5.18.3 | **Travaux Fonction C4 - EBS** |  | 30d | 2022-02-03 | 2022-03-16 |  | -39d | 0d | BHS | EBS | Blank | NA | Blank | NA |  |  |  |
| 1008 | 3.1.5.18.3.1 | TEST Lignes EBS sur Trieur Sud (B.F. Connexions) |  | 15d | 2022-02-03 | 2022-02-23 | 974, 996 | -39d | 0d | BHS | EBS | Commissioning | EBS | Commissioning | NA | INT | 1 automaticien + 1 élec |  |
| 1009 | 3.1.5.18.3.2 | VABF Lignes EBS sur Trieur Sud (B.F. Connexions) |  | 5d | 2022-02-24 | 2022-03-02 | 1008 | -39d | 0d | BHS | EBS | Blank | EBS | Blank | NA | INT/IS/GA | 1 automaticien |  |
| 1010 | 3.1.5.18.3.3 | Mise en service Lignes EBS sur Trieur Sud (B.F. Connexions) | milestone | 0d | 2022-03-02 | 2022-03-02 | 1009 | -39d | 0d | BHS | EBS | Working | EBS | Working | NA | INT |  |  |
| 1011 | 3.1.5.18.3.4 | Démontage ligne SAS HF T1+ |  | 5d | 2022-03-10 | 2022-03-16 | 929, 1027SS-73d | -39d | 0d | BHS |  | Dismounting | NA |  |  | INT |  |  |
| 1012 | 3.1.5.19 | **Phase 20** |  | 69d | 2022-04-01 | 2022-07-12 |  | -39d | 0d | BHS |  | Blank | NA | Blank | NA |  |  |  |
| 1013 | 3.1.5.19.1 | **Travaux Fonction C1 - ENREGISTREMENTS** |  | 25d | 2022-04-01 | 2022-05-09 |  | -39d | 0d | BHS |  | Blank | NA | Blank | NA |  |  |  |
| 1014 | 3.1.5.19.1.1 | Installation boucle de connexion T1+ |  | 25d | 2022-04-01 | 2022-05-09 | 496, 1011 | -39d | 0d | BHS |  | Installation | NA | Installation | 12 convoyeurs 50 mètres + 2 courbes | INT | 1 méca + 1 élec | Période 6 partielle |
| 1015 | 3.1.5.19.2 | **Travaux Fonction C3 - TRI** |  | 37d | 2022-05-19 | 2022-07-12 |  | -39d | 0d | BHS |  | Blank | NA | Blank | NA |  |  |  |
| 1016 | 3.1.5.19.2.1 | Consignation Trieur Crisplant, Lignes et Convoyage | milestone | 0d | 2022-05-19 | 2022-05-19 | 1038SS | -39d | 0d | BLC |  | Stopped | NA | Stopped | NA | GA |  |  |
| 1017 | 3.1.5.19.2.2 | Démontage local ancienne Supervision Informatique et local informatique | milestone | 0d | 2022-06-10 | 2022-06-10 | 1016FS+15d | 0d |  | BLC |  | Blank | NA |  | NA |  |  |  |
| 1018 | 3.1.5.19.2.3 | Installation MUP chute Trieur Nord coté Est (4 chutes sur 6) |  | 15d | 2022-06-13 | 2022-07-01 | 1017 | 0d |  | BHS |  | Installation | NA | Installation |  | INT |  | Période 5 partielle |
| 1019 | 3.1.5.19.2.4 | Test MUP chute Trieur Nord coté Est (4 chutes sur 6) |  | 6d | 2022-07-04 | 2022-07-11 | 1018 | 0d |  | BHS |  | Commissioning | NA | Commissioning | NA | INT |  |  |
| 1020 | 3.1.5.19.2.5 | VABF MUP chute Trieur Nord coté Est (4 chutes sur 6) |  | 1d | 2022-07-12 | 2022-07-12 | 1019 | 0d |  | BHS |  | Blank | NA | Blank | NA | INT/IS/GA |  |  |
| 1021 | 3.1.5.19.2.6 | Mise en service MUP chute Trieur Nord coté Est (4 chutes sur 6) | milestone | 0d | 2022-07-12 | 2022-07-12 | 1020 | 0d |  | BHS |  | Working | NA | Working | NA | INT |  |  |
| 1022 | 3.1.5.19.2.7 | Demontage Lignes d'injections Trieur Crisplant |  | 5d | 2022-05-19 | 2022-05-25 | 1016 | -39d | 0d | BHS |  | Dismounting | NA |  | 40 convoyeurs de 120 mètres | INT | 9 méca + 1 élec |  |
| 1023 | 3.1.5.19.2.8 | Demontage Trieur Crisplant |  | 33d | 2022-05-19 | 2022-07-06 | 1016 | 0d |  | BHS |  | Dismounting | NA | Dismounting | 108 convoyeurs de 360 mètres | INT | 5 méca + 1 élec |  |
| 1024 | 3.1.5.19.2.9 | Demontage et mise sur palette convoyeurs de toutes les lignes dans la passerelle |  | 10d | 2022-05-19 | 2022-06-02 | 1016 | 0d |  | BHS |  | Dismounting | NA |  | 28 convoyeurs de 250 mètres | INT | 9 méca + 1 élec |  |
| 1025 | 3.1.5.19.2.10 | Mise à disposition pour démontage passerelle | milestone | 0d | 2022-06-02 | 2022-06-02 | 1024 | 0d |  | BHS |  | Blank | NA |  | NA | INT |  |  |
| 1026 | 3.1.5.19.2.11 | Installation 2 lignes de connexion vers injections Trieur Nord et Sud |  | 20d | 2022-05-27 | 2022-06-24 | 1022 | -39d | 0d | BHS |  | Installation | NA | Installation | 10 convoyeurs de 37 mètres + 1 vertical diverter | INT | 1 méca + 1 élec |  |
| 1027 | 3.1.5.19.2.12 | Installation BLC pouvant recevoir tous les Check-In T1 et T1+ | milestone | 0d | 2022-06-24 | 2022-06-24 | 1026 | -39d | 0d | BHS |  | Installation | NA |  | NA | INT |  |  |
| 1028 | 3.1.5.19.3 | **Travaux Fonction C1 - ENREGISTREMENTS** |  | 56d | 2022-04-07 | 2022-06-30 |  | -39d | 0d | BHS |  | Blank | NA | Blank | NA |  |  |  |
| 1029 | 3.1.5.19.3.1 | Consignation banque et Collecteur 2000 | milestone | 0d | 2022-04-07 | 2022-04-07 | 1006, 996, 993 | -39d | 0d | BLC |  | Stopped | NA | Stopped | NA | GA |  |  |
| 1030 | 3.1.5.19.3.2 | Demontage banques 2000 et ligne collecteur |  | 5d | 2022-04-08 | 2022-04-14 | 1029 | -39d | 0d | BHS |  | Dismounting | HBS7 |  |  | INT |  |  |
| 1031 | 3.1.5.19.3.3 | Installation mécanique collecteur G40 + ligne d'acheminement |  | 7d | 2022-04-19 | 2022-04-27 | 1030 | -39d | 0d | BHS |  | Installation | HBS7 | Dismounting |  | INT |  |  |
| 1032 | 3.1.5.19.3.4 | Installation Check-In G40 |  | 7d | 2022-04-28 | 2022-05-06 | 1031 | -39d | 0d | BHS |  | Installation | HBS7 | Installation |  | INT |  |  |
| 1033 | 3.1.5.19.3.5 | Installation électrique collecteurs + banques |  | 7d | 2022-04-28 | 2022-05-06 | 1032SS | -39d | 0d |  |  | Installation | HBS7 |  |  | INT |  |  |
| 1034 | 3.1.5.19.3.6 | Test banques G40 sur installation BLC |  | 7d | 2022-05-09 | 2022-05-17 | 1031, 1033 | -39d | 0d | BHS |  | Commissioning | HBS7 | Commissioning | NA | INT | 1 automaticien + 1 élec |  |
| 1035 | 3.1.5.19.3.7 | VABF banques G40 (B.F. G40 - (HBS7)) sur installation BLC |  | 1d | 2022-05-18 | 2022-05-18 | 1034 | -39d | 0d | BHS |  | Blank | HBS7 | Blank | NA | INT/IS/GA | 1 automaticien |  |
| 1036 | 3.1.5.19.3.8 | Mise en service banques G40 (B.F. G40 - (HBS7)) sur BLC | milestone | 0d | 2022-05-18 | 2022-05-18 | 1035 | -39d | 0d | BHS |  | Working | HBS7 | Working | NA | INT |  |  |

| ID | WBS | Task | Type | Duration | Start | Finish | Predecessors | Total slack | Free slack | Text1 | Text12 | Text21 | Text26 | Text29 | Acteur | Text14 | Text27 | Forte affluence |
| --- | --- | --- | --- | --- | --- | --- | --- | --- | --- | --- | --- | --- | --- | --- | --- | --- | --- | --- |
| 1037 | 3.1.5.19.3.9 | **Travaux Fonction C1 - ENREGISTREMENTS** |  | 34d | 2022-05-10 | 2022-06-28 |  | -39d | 0d | BHS | Blank | NA | Blank | NA |  |  |  |  |
| 1038 | 3.1.5.19.3.9.1 | Connexion du Check-In G30 au nouveau BLC |  | 8d | 2022-05-19 | 2022-05-31 | 1036, 913 | -39d | 0d | BHS | Installation | HBS5 | Commissioning |  | INT |  |  |  |
| 1039 | 3.1.5.19.3.9.2 | Connexion du Check-In G17 au nouveau BLC |  | 8d | 2022-06-01 | 2022-06-13 | 1038 | -35d | 0d | BHS |  | HBS6 |  |  | INT | New line missing in the past in the couloir porte C |  |  |
| 1040 | 3.1.5.19.3.9.3 | Test Check-In G30 au nouveau BLC |  | 2d | 2022-06-01 | 2022-06-02 | 1038 | -24d | 0d | BHS | Commissioning | HBS5 | Blank | NA | INT/IS/GA |  | 1 automaticien + 1 élec |  |
| 1041 | 3.1.5.19.3.9.4 | VABF Check-In G30 au nouveau BLC |  | 2d | 2022-06-03 | 2022-06-07 | 1040 | -24d | 0d | BHS | Blank | HBS5 | Working | NA | INT |  | 1 automaticien |  |
| 1042 | 3.1.5.19.3.9.5 | Mise en service Check-In G30 au nouveau BLC | milestone | 0d | 2022-06-07 | 2022-06-07 | 1041 | -24d | 0d | BHS | Working | HBS5 |  | NA | INT |  |  |  |
| 1043 | 3.1.5.19.3.9.6 | Demontage provisoire de 2 banques T1+ |  | 2d | 2022-05-10 | 2022-05-11 | 1014 | -39d | 0d | BHS | Dismounting | NA | Dismounting |  | INT |  |  |  |
| 1044 | 3.1.5.19.3.9.7 | Installation ligne provisoire T1+ |  | 25d | 2022-05-12 | 2022-06-17 | 1043 | -39d | 0d | BHS | Installation | NA | Installation |  | INT |  |  | Période 6 partielle |
| 1045 | 3.1.5.19.3.9.8 | Test T1+ avec ligne provisoire |  | 6d | 2022-06-20 | 2022-06-27 | 1014, 1044, 1043, 1039 | -39d | 0d | BHS | Commissioning | NA | Commissioning | NA | INT |  | 1 automaticien + 1 élec |  |
| 1046 | 3.1.5.19.3.9.9 | VABF T1+ avec ligne provisoire |  | 1d | 2022-06-28 | 2022-06-28 | 1045 | -39d | 0d | BHS |  | NA |  | NA | INT |  | 1 automaticien |  |
| 1047 | 3.1.5.19.3.9.10 | Mise en service T1+ avec ligne provisoire | milestone | 0d | 2022-06-28 | 2022-06-28 | 1046, 1027 | -39d | 0d | BHS | Working | NA | Working | NA | INT |  |  |  |
| 1048 | 3.1.5.19.3.10 | **Travaux Fonction C3 - TRI** |  | 4d | 2022-06-27 | 2022-06-30 |  | 0d |  | BHS | Blank | NA | Blank | NA |  |  |  | Période 5 partielle |
| 1049 | 3.1.5.19.3.10.1 | Test 2 lignes de connexions entre 4 injections du Tnord et Tsud (B.F. INTER-TRI + MCS) |  | 3d | 2022-06-27 | 2022-06-29 | 1026 | 0d |  | BHS | Commissioning | NA | Commissioning | NA | INT |  | 1 automaticien + 1 élec |  |
| 1050 | 3.1.5.19.3.10.2 | VABF 2 lignes de connexions entre 4 injections du Tnord et Tsud (B.F. INTER-TRI + MCS) |  | 1d | 2022-06-30 | 2022-06-30 | 1049 | 0d |  | BHS | Blank | NA | Blank | NA | INT/IS/GA |  | 1 automaticien |  |
| 1051 | 3.1.5.19.3.10.3 | Mise en service 2 lignes de connexions entre 4 injections du Tnord et Tsud (B.F. INTER-TRI + MCS) | milestone | 0d | 2022-06-30 | 2022-06-30 | 1050 | 0d |  | BHS | Working | NA | Working | NA | INT |  |  |  |
| 1052 | 3.1.5.20 | **Phase 21** |  | 70d | 2022-07-01 | 2022-10-10 |  | 0d |  | BHS | Blank | NA | Blank | NA |  |  |  |  |
| 1053 | 3.1.5.20.1 | **Travaux Fonction C3 - TRI** |  | 70d | 2022-07-01 | 2022-10-10 | 531 | 0d |  | BHS | Blank | NA | Blank | NA |  |  |  |  |
| 1054 | 3.1.5.20.1.1 | Installation ligne de connection Trieur Nord et Sud sur Injection 3 |  | 70d | 2022-07-01 | 2022-10-10 | 1051 | 0d |  | BHS | Installation | NA | Installation |  | INT |  |  |  |
| 1055 | 3.1.5.20.1.2 | Installation MCS et ligne de retour avec elevateur |  | 70d | 2022-07-01 | 2022-10-10 | 1051 | 0d |  | BHS | Installation | NA | Installation |  | INT |  |  |  |
| 1056 | 3.1.5.20.1.3 | Connexion HBS6 en configuration finale sur les injections des trieurs |  | 70d | 2022-07-01 | 2022-10-10 | 1051 | 0d |  | BHS | Installation | NA | Installation |  | INT |  |  |  |
| 1057 | 3.1.5.21 | **Phase 22** |  | 47d | 2022-10-11 | 2022-12-14 |  | 0d |  | BHS | Blank | NA | Blank | NA |  |  |  |  |
| 1058 | 3.1.5.21.1 | **Travaux Fonction C3 - TRI** |  | 47d | 2022-10-11 | 2022-12-14 |  | 0d |  | BHS | Blank | NA | Blank | NA |  |  |  |  |
| 1059 | 3.1.5.21.1.1 | Installation definitive injection Trieur Nord |  | 20d | 2022-10-11 | 2022-11-07 | 1054 | 23d |  | BHS | Installation | NA | Installation |  | INT |  |  |  |
| 1060 | 3.1.5.21.1.2 | Installation ligne de connection Trieur Nord et Sud |  | 23d | 2022-10-11 | 2022-11-10 | 1054 | 20d |  | BHS | Installation | NA | Installation |  | INT |  |  |  |
| 1061 | 3.1.5.21.1.3 | Installation lignes de reinjection sur les Trieurs |  | 23d | 2022-10-11 | 2022-11-10 | 1054 | 0d |  | BHS | Installation | NA | Installation |  | INT |  |  |  |
| 1062 | 3.1.5.21.1.4 | Installation MUP |  | 23d | 2022-11-11 | 2022-12-13 | 1061 | 0d |  | BHS | Installation | NA | Installation |  | INT |  |  |  |
| 1063 | 3.1.5.21.1.5 | Connexion HBS7 en configuration finale sur les injections des trieurs |  | 23d | 2022-10-11 | 2022-11-10 | 1056 | 0d |  | BHS | Installation | HBS7 | Installation |  | INT |  |  |  |
| 1064 | 3.1.5.21.1.6 | Connexion HBS6 et HBS7 finale dans Cours De France (passerelle démontée) |  | 20d | 2022-11-11 | 2022-12-08 | 497 | 0d |  | BHS | Installation |  |  |  | BHS |  |  |  |
| 1065 | 3.1.5.21.1.7 | Test injection 3 sur trieur Sud |  | 3d | 2022-12-09 | 2022-12-13 | 1059, 1064, 1060, 1061, 1063, 1054, 1055, 1056 | 0d |  | BHS | Commissioning | NA | Commissioning | NA | INT |  |  |  |
| 1066 | 3.1.5.21.1.8 | VABF injection 3 sur trieur Sud |  | 1d | 2022-12-14 | 2022-12-14 | 1065 | 0d |  | BHS | Blank | NA | Blank | NA | INT/IS/GA |  |  |  |
| 1067 | 3.1.5.21.1.9 | Mise en service injection 3 sur trieur Sud | milestone | 0d | 2022-12-14 | 2022-12-14 | 1066 | 0d |  | BHS | Working | NA | Working | NA | INT |  |  |  |
| 1068 | 3.1.5.21.1.10 | Test Ligne MCS (B.F. MCS) |  | 3d | 2022-10-11 | 2022-10-13 | 1055 | 0d |  | BHS | Commissioning | NA | Commissioning |  | INT |  | 1 automaticien + 1 élec |  |
| 1069 | 3.1.5.21.1.11 | VABF Ligne MCS (B.F. MCS) |  | 1d | 2022-10-14 | 2022-10-14 | 1068 | 0d |  | BHS | Blank | NA | Blank |  | INT/IS/GA |  | 1 automaticien |  |
| 1070 | 3.1.5.21.1.12 | Mise en service Ligne MCS (B.F. MCS) | milestone | 0d | 2022-10-14 | 2022-10-14 | 1069 | 0d |  | BHS | Working | NA | Working |  | INT |  |  |  |

| ID | WBS | Task | Type | Duration | Start | Finish | Predecessors | Total slack | Text1 | Text12 | Text21 | Text26 | Text29 | Acteur | name 2 | Text27 | Forte affluence |
| --- | --- | --- | --- | --- | --- | --- | --- | --- | --- | --- | --- | --- | --- | --- | --- | --- | --- |
| 1071 | 3.1.5.22 | **Phase 23** |  | 59d | 2022-11-11 | 2023-02-09 |  | 0d | BHS | Blank | NA | Blank | NA |  |  |  |  |
| 1072 | 3.1.5.22.1 | **Travaux Fonction C3 - TRI** |  | 59d | 2022-11-11 | 2023-02-09 |  | 0d | BHS | Blank | NA | Blank | NA |  |  |  |  |
| 1073 | 3.1.5.22.1.1 | Demontage ligne provisoire de connection Trieur Sud |  | 18d | 2022-11-11 | 2022-12-06 | 1063 | 0d | BHS | Dismounting | NA | Dismounting |  | INT |  |  |  |
| 1074 | 3.1.5.22.1.2 | Installation sortie Trieur Sud vers EBS |  | 35d | 2022-12-15 | 2023-02-09 | 1066 | 0d | BHS | Installation | NA | Installation |  | INT | EBS |  |  |
| 1075 | 3.1.5.22.1.3 | Connexion HBS8 en configuration finale sur les injections des trieurs |  | 35d | 2022-12-15 | 2023-02-09 | 1066 | 0d | BHS | Installation | NA | Installation |  | INT |  |  |  |
| 1076 | 3.1.5.22.1.4 | Test n.4 MUP |  | 2d | 2022-12-14 | 2022-12-15 | 1062 | 0d | BHS | Commissioning | NA | Commissioning | NA | INT |  | 1 automaticien + 1 élec |  |
| 1077 | 3.1.5.22.1.5 | VABF n.4 MUP |  | 1d | 2022-12-16 | 2022-12-16 | 1076 | 0d | BHS | Blank | NA | Blank | NA | INT/IS/GA |  | 1 automaticien |  |
| 1078 | 3.1.5.22.1.6 | Mise en service n.4 MUP | milestone | 0d | 2022-12-16 | 2022-12-16 | 1077 | 0d | BHS | Working | NA | Working | NA | INT |  |  |  |
| 1079 | 3.1.5.22.1.7 | **Travaux Fonction C1 - ENREGISTREMENTS** |  | 22d | 2022-12-19 | 2023-01-25 |  | 0d | BHS | Blank | NA | Blank | NA |  |  |  |  |
| 1080 | 3.1.5.22.1.7.1 | Installation 1ere ligne de collecte T1+ pour les banques G10, G15 |  | 14d | 2022-12-19 | 2023-01-13 | 419, 1078 | 0d | BHS | Installation | NA | Installation |  | INT |  |  |  |
| 1081 | 3.1.5.22.1.7.2 | Test 1er ligne de collecte T1+ (Tous points d'injections operationels) |  | 5d | 2023-01-16 | 2023-01-20 | 1080 | 0d | BHS | Commissioning | NA | Commissioning | NA | INT |  | 1 automaticien + 1 élec |  |
| 1082 | 3.1.5.22.1.7.3 | VABF 1er ligne de collecte T1+ (Tous points d'injections operationels) |  | 1d | 2023-01-23 | 2023-01-23 | 1081 | 0d | BHS | Blank | NA | Blank | NA | INT/IS/GA |  | 1 automaticien |  |
| 1083 | 3.1.5.22.1.7.4 | Mise en service 1er ligne de collecte T1+ (Tous points d'injections operationels) | milestone | 0d | 2023-01-23 | 2023-01-23 | 1082 | 0d | BHS | Working | NA | Working | NA | INT |  |  |  |
| 1084 | 3.1.5.22.1.7.5 | Demontage T1+ (1er partie) |  | 2d | 2023-01-24 | 2023-01-25 | 1083 | 0d | BHS | Dismounting | NA | Dismounting |  | INT |  |  |  |
| 1085 | 3.1.5.23 | **Phase 24** |  | 34d | 2023-01-25 | 2023-03-14 |  | 0d | BHS | Blank | NA | Blank | NA |  |  |  |  |
| 1086 | 3.1.5.23.1 | **Travaux Fonction C2 - CONTROLE SURETE** |  | 34d | 2023-01-26 | 2023-03-14 |  | 0d | BHS | Blank | NA | Blank | NA |  |  |  | Période 5 partielle |
| 1087 | 3.1.5.23.1.1 | Demontage zone HBS std2 (zone Casino) |  | 34d | 2023-01-26 | 2023-03-14 | 1084 | 0d | BHS | Dismounting | NA | Dismounting |  | INT |  |  | Période 5 partielle |
| 1088 | 3.1.5.23.1.2 | Demontage EDS HF T1+ |  | 34d | 2023-01-26 | 2023-03-14 | 1084 | 0d | BHS | Dismounting | EDS | Dismounting |  | INT |  |  | Période 5 partielle |
| 1089 | 3.1.5.23.2 | **Travaux Fonction C1 - ENREGISTREMENTS** |  | 33d | 2023-01-25 | 2023-03-13 |  | 0d | BHS | Blank | NA | Blank | NA |  |  |  |  |
| 1090 | 3.1.5.23.2.1 | Consignation demontage T1+ | milestone | 0d | 2023-01-25 | 2023-01-25 | 1084 | 44d | BLC | Stopped | NA | Stopped | NA | GA |  |  |  |
| 1091 | 3.1.5.23.2.2 | Demontage T1+ (suivi) |  | 14d | 2023-01-26 | 2023-02-14 | 1084 | 0d | BHS | Dismounting | NA | Dismounting |  | INT |  |  |  |
| 1092 | 3.1.5.23.2.3 | Installation 2eme ligne de collecte T1+ pour les banques G10, G15 |  | 10d | 2023-02-15 | 2023-02-28 | 1091 | 0d | BHS | Installation | HBS6 | Installation |  | INT |  |  |  |
| 1093 | 3.1.5.23.2.4 | Test banques G10, G15 et ligne de collecte |  | 4d | 2023-03-01 | 2023-03-06 | 1092 | 0d | BHS | Commissioning | HBS6 | Commissioning | NA | INT |  | 1 automaticien + 1 élec |  |
| 1094 | 3.1.5.23.2.5 | Test 2eme ligne de collecte sur les banques G10, G15 (B.F. G10 - G15 - G17) |  | 4d | 2023-03-07 | 2023-03-10 | 1093 | 0d | BHS | Commissioning | HBS6 | Commissioning | NA | INT |  | 1 automaticien + 1 élec |  |
| 1095 | 3.1.5.23.2.6 | VABF 2eme ligne de collecte sur les banques G10, G15 (B.F. G10 - G15 - G17) |  | 1d | 2023-03-13 | 2023-03-13 | 1094 | 0d | BHS | Blank | HBS6 | Blank | NA | INT |  | 1 automaticien |  |
| 1096 | 3.1.5.23.2.7 | Mise en service 2eme ligne de collecte sur les banques G10, G15 (B.F. G10 - G15 - G17) | milestone | 0d | 2023-03-13 | 2023-03-13 | 1095 | 0d | BHS | Working | HBS6 | Working | NA | INT |  |  |  |

| ID | WBS | Task | Type | Duration | Start | Finish | Predecessors | Total slack | Text1 | Text12 | Text21 | Text26 | Text29 | Acteur | Text27 |
| --- | --- | --- | --- | --- | --- | --- | --- | --- | --- | --- | --- | --- | --- | --- | --- |
| 1097 | 3.1.5.24 | **Phase 25** |  | 21d | 2023-03-14 | 2023-04-11 |  | 0d | BHS | Blank | NA | Blank | NA |  |  |
| 1098 | 3.1.5.24.1 | **Travaux Fonction C1 - ENREGISTREMENTS** |  | 21d | 2023-03-14 | 2023-04-11 |  | 0d | BHS | Blank | NA | Blank | NA |  |  |
| 1099 | 3.1.5.24.1.1 | Demontage ligne provisoire de connection T1+ |  | 10d | 2023-03-15 | 2023-03-28 | 1084, 1096, 1088 | 0d | BHS | Dismounting | NA | Dismounting |  | INT |  |
| 1100 | 3.1.5.24.1.2 | Demontage T1+ (suivi) |  | 10d | 2023-03-29 | 2023-04-11 | 1096, 1090, 1099 | 0d | BHS | Dismounting | NA | Dismounting |  | INT |  |
| 1101 | 3.1.5.24.1.3 | Reinstallation dernieres 2 banques |  | 3d | 2023-03-14 | 2023-03-16 | 1096 | 0d | BHS | Installation | NA | Installation |  | INT |  |
| 1102 | 3.1.5.24.1.4 | Test dernieres 2 banques (G15) |  | 1d | 2023-03-17 | 2023-03-17 | 1101 | 0d | BHS | Commissioning | NA | Commissioning | NA | INT | 1 automaticien + 1 élec |
| 1103 | 3.1.5.24.1.5 | VABF dernieres 2 banques (G15) |  | 1d | 2023-03-20 | 2023-03-20 | 1102 | 0d | BHS | Blank | NA | Blank | NA | INT/IS/GA | 1 automaticien |
| 1104 | 3.1.5.24.1.6 | Mise en service dernieres 2 banques (G15) | milestone | 0d | 2023-03-20 | 2023-03-20 | 1103 | 0d | BHS | Working | NA | Working | NA | INT |  |
| 1105 | 3.1.6 | **Verification attitude au bon fonctionnement (VABF)** |  | 1028d | 2019-02-11 | 2023-03-22 |  | 0d | BHS | Blank | NA | Blank | NA |  |  |
| 1106 | 3.1.6.1 | VABF - Ligne HF4000/ski (B.F. LIV HF ET SPECIAUX) |  | 2d | 2019-12-12 | 2019-12-13 | 548 | 0d | BHS | Blank | HF4000 | Blank | NA | INT/IS/GA |  |
| 1107 | 3.1.6.2 | VABF - Ligne Depose C7 (B.F. LIV n°7) |  | 2d | 2020-01-20 | 2020-01-21 | 603 | 0d | BHS | Blank | C7 | Blank | NA | INT/IS/GA |  |
| 1108 | 3.1.6.3 | VABF - Ligne Depose C6 (B.F. LIV n°6) |  | 2d | 2020-04-24 | 2020-04-27 | 665 | 0d | BHS | Blank | C6 | Blank | NA | INT/IS/GA |  |
| 1109 | 3.1.6.4 | VABF - banques G25 (B.F. G20 - G25 -(HBS3)) |  | 5d | 2020-06-17 | 2020-06-23 | 685 | 0d | BHS | Blank | NA | Blank | NA | INT/IS/GA |  |
| 1110 | 3.1.6.5 | VABF - Ligne BS1 (B.F. BS1) |  | 2d | 2020-05-06 | 2020-05-07 | 621 | 0d | BHS | Blank | BS1 | Blank | NA | INT/IS/GA |  |
| 1111 | 3.1.6.6 | VABF - banques G17, G20 (B.F. G20 - G25 -(HBS3); B.F. G10 - G15 - G17 - (HBS6)) |  | 5d | 2019-02-11 | 2019-02-15 |  | 0d | BHS | Blank | NA | Blank | NA | INT/IS/GA |  |
| 1112 | 3.1.6.7 | VABF - Ligne Depose C5 (B.F LIV n°5) |  | 2d | 2020-06-25 | 2020-06-26 | 704 | 0d | BHS | Blank | C5 | Blank | NA | INT/IS/GA |  |
| 1113 | 3.1.6.8 | VABF - Ligne Depose C4 (B.F LIV n°4) |  | 2d | 2020-11-04 | 2020-11-05 | 784 | 0d | BHS | Blank | C4 | Blank | NA | INT/IS/GA |  |
| 1114 | 3.1.6.9 | VABF - Ligne Depose Secteur France (B.F. LIV SF) |  | 2d | 2020-10-09 | 2020-10-12 | 804 | 0d | BHS | Blank | Secteur France | Blank | NA | INT/IS/GA |  |
| 1115 | 3.1.6.10 | VABF - Ligne Depose C3 (B.F LIV n°3) |  | 2d | 2020-11-04 | 2020-11-05 | 784 | 0d | BHS | Blank | C3 | Blank | NA | INT/IS/GA |  |
| 1116 | 3.1.6.11 | VABF - Ligne Depose C2 (B.F LIV n°2) |  | 2d | 2021-01-18 | 2021-01-19 | 831 | 0d | BHS | Blank | C2 | Blank | NA | INT/IS/GA |  |
| 1117 | 3.1.6.12 | VABF - Ligne Depose C1 (B.F LIV n°1) |  | 2d | 2021-01-19 | 2021-01-20 | 846 | 0d | BHS | Blank | C1 | Blank | NA | INT/IS/GA |  |
| 1118 | 3.1.6.13 | VABF - Depose et Ligne HBS2 (B.F. HF1 - HF2 -(HBS2); B.F. HBS2; B.F. MUP HF) |  | 3d | 2021-03-09 | 2021-03-11 | 882 | 0d | BHS | Blank | HF2 | Blank | NA | INT/IS/GA |  |
| 1119 | 3.1.6.14 | VABF - Trieur Nord, HBS3, HBS4 (B.F. TRI NORD + MUP; B.F. HBS3; B.F. HBS4; B.F. CONTRÔLE COMPLEMENTAIRE) |  | 15d | 2021-04-28 | 2021-05-19 | 901 | 0d | BHS | Blank | NA | Blank | NA | INT/IS/GA |  |
| 1120 | 3.1.6.15 | VABF - Depose HF 1 (B.F. HF1 - HF2 -(HBS2)) |  | 3d | 2021-03-09 | 2021-03-11 | 882 | 0d | BHS | Blank | HF1 | Blank | NA | INT/IS/GA |  |
| 1121 | 3.1.6.16 | VABF - Ligne Transfer 2 (B.F. Ligne AuF Tr2) |  | 2d | 2021-01-18 | 2021-01-19 | 831 | 0d | BHS | Blank | TR2 | Blank | NA | INT/IS/GA |  |
| 1122 | 3.1.6.17 | VABF - Ligne AuF HBS5 (B.F. HBS5) |  | 2d | 2021-10-14 | 2021-10-15 | 958 | 0d | BHS | Blank | HSB5 | Blank | NA | INT/IS/GA |  |
| 1123 | 3.1.6.18 | VABF - Depose HF 3 et Ligne HBS1 (B.F. HF3 - (HBS1); B.F HBS1) |  | 2d | 2021-07-08 | 2021-07-09 | 928 | 0d | BHS | Blank | HF3 | Blank | NA | INT/IS/GA |  |
| 1124 | 3.1.6.19 | VABF - Trieur Nord (tous MUP) |  | 2d | 2021-07-21 | 2021-07-22 | 933 | 0d | BHS | Blank | NA | Blank | NA | INT/IS/GA |  |
| 1125 | 3.1.6.20 | VABF - banques G55 (B.F G50 - G55 - (HBS4)) |  | 2d | 2021-10-14 | 2021-10-15 | 958 | 146d | BHS | Blank | NA | Blank | NA | INT/IS/GA |  |
| 1126 | 3.1.6.21 | VABF - banques G35(B.F. G30 - G35 -(HBS5)) |  | 2d | 2021-10-14 | 2021-10-15 | 958 | 158d | BHS | Blank | NA | Blank | NA | INT/IS/GA |  |
| 1127 | 3.1.6.22 | VABF - EBS vers Trieur Nord (B.F. EBS; B.F. CONNEXIONS) |  | 5d | 2021-09-01 | 2021-09-07 | 948 | 0d | BHS | Blank | NA | Blank | NA | INT/IS/GA |  |
| 1128 | 3.1.6.23 | VABF - carrousel de tri coté Est ave Trieur Nord (B.F. MUP EST) |  | 5d | 2020-10-16 | 2020-10-22 | 850 | 0d | BHS | Blank | NA | Blank | NA | INT/IS/GA |  |
| 1129 | 3.1.6.24 | VABF - Lignes HBS7 et HBS8 (B.F. HBS7; B.F. HBS8) |  | 4d | 2021-07-23 | 2021-07-28 | 938 | 0d | BHS | Blank | HBS7;HBS8 | Blank | NA | INT/IS/GA |  |
| 1130 | 3.1.6.25 | VABF - Lignes EBS vers Trieur Sud (B.F. Connexions) |  | 5d | 2022-02-24 | 2022-03-02 | 1008 | 0d | BHS | Blank | NA | Blank | NA | INT/IS/GA |  |
| 1131 | 3.1.6.26 | VABF - Trieur Sud et Ligne d'injection 1 (B.F. TRI SUD + MUP) |  | 15d | 2022-01-24 | 2022-02-11 | 994 | 0d | BHS | Blank | NA | Blank | NA | INT/IS/GA |  |
| 1132 | 3.1.6.27 | VABF - Ligne Transfer3 (B.F. Ligne AuF Tr3) |  | 2d | 2020-11-04 | 2020-11-05 | 784 | 0d | BHS | Blank | TR3 | Blank | NA | INT/IS/GA |  |
| 1133 | 3.1.6.28 | VABF - Ligne NV5000 et baques G60 (B.F. G60 - Secteur France - (HBS8)) |  | 2d | 2022-04-08 | 2022-04-11 | 1005 | 0d | BHS | Blank | HBS8 | Blank | NA | INT/IS/GA |  |
| 1134 | 3.1.6.29 | VABF - Lignes HBS6 (B.F. HBS6) |  | 2d | 2021-10-14 | 2021-10-15 | 958 | 0d | BHS | Blank | HBS6 | Blank | NA | INT/IS/GA |  |
| 1135 | 3.1.6.30 | VABF - Ligne NV1000 et banques G50 (B.F G50 - G55 - (HBS4)) |  | 2d | 2022-05-19 | 2022-05-20 | 1035 | 0d | BHS | Blank | HBS4 | Blank | NA | INT/IS/GA |  |
| 1136 | 3.1.6.31 | VABF - Ligne Transfer1 (B.F. Ligne AuF Tr1) |  | 2d | 2021-02-16 | 2021-02-17 | 872 | 0d | BHS | Blank | TR1 | Blank | NA | INT/IS/GA |  |
| 1137 | 3.1.6.32 | VABF - banques G40(B.F. G40 -(HBS7)) |  | 2d | 2022-06-03 | 2022-06-07 | 1040 | 0d | BHS | Blank | NA | Blank | NA | INT/IS/GA |  |
| 1138 | 3.1.6.33 | VABF - n.6 MUP (B.F. MUP CENTRAUX) |  | 3d | 2021-10-08 | 2021-10-12 | 966 | 296d | BHS | Blank | NA | Blank | NA | INT/IS/GA |  |
| 1139 | 3.1.6.34 | VABF - boucle de connexion T1+ |  | 1d | 2022-06-29 | 2022-06-29 | 1047 | 0d | BHS | Blank | NA | Blank | NA | INT/IS/GA |  |
| 1140 | 3.1.6.35 | VABF - Ligne NV0000 et banques G30 (B.F. G30 - G35 -(HBS5)) |  | 2d | 2022-06-08 | 2022-06-09 | 1041 | 0d | BHS | Blank | HBS5 | Blank | NA | INT/IS/GA |  |
| 1141 | 3.1.6.36 | VABF - n.4 MUP (B.F. MUP CENTRAUX) |  | 2d | 2022-12-16 | 2022-12-19 | 1076 | 0d | BHS | Blank | NA | Blank | NA | INT/IS/GA |  |
| 1142 | 3.1.6.37 | VABF - carrousel de tri coté Ouest (B.F. MUP OUEST) |  | 5d | 2020-11-13 | 2020-11-19 | 851 | 0d | BHS | Blank | NA | Blank | NA | INT/IS/GA |  |
| 1143 | 3.1.6.38 | VABF - injection 2 sur trieur Sud |  | 2d | 2022-12-14 | 2022-12-15 | 1065 | 0d | BHS | Blank | NA | Blank | NA | INT/IS/GA |  |
| 1144 | 3.1.6.39 | VABF - Ligne MCS (B.F. MCS) |  | 2d | 2022-10-14 | 2022-10-17 | 1068 | 0d | BHS | Blank | NA | Blank | NA | INT/IS/GA |  |
| 1145 | 3.1.6.40 | VABF - 2eme ligne de collecte et banques G10, G15 et dernieres 2 banques (B.F. G10 - G15 - G17) |  | 2d | 2023-03-21 | 2023-03-22 | 1103 | 0d | BHS | Blank | NA | Blank | NA | INT/IS/GA |  |

| ID | WBS | Task | Duration | Start | Finish | Predecessors | Total slack | Text1 | Acteur | Text12 | Text21 | Text26 | Text29 |
| --- | --- | --- | --- | --- | --- | --- | --- | --- | --- | --- | --- | --- | --- |
| 1146 | 3.1.7 | **Verification de service regulier (VSR)** | 1170d | 2019-02-11 | 2023-10-06 |  | 0d | BHS | INT/IS/GA | Blank | NA | Blank | NA |
| 1147 | 3.1.7.1 | VSR - Ligne HF4000/ski (B.F. LIV HF ET SPECIAUX) | 14d | 2020-01-14 | 2020-01-31 | 550, 572 | 0d | BHS | INT/IS/GA | Blank | HF4000;SKI | Blank | NA |
| 1148 | 3.1.7.2 | VSR - Ligne Depose C7 (B.F. LIV n°7) | 14d | 2020-01-20 | 2020-02-06 | 604 | 0d | BHS | INT/IS/GA | Blank | C7 | Blank | NA |
| 1149 | 3.1.7.3 | VSR - Ligne Depose C6 (B.F. LIV n°6) | 14d | 2020-04-24 | 2020-05-13 | 666 | 0d | BHS | INT/IS/GA | Blank | C6 | Blank | NA |
| 1150 | 3.1.7.4 | VSR - banques G25 (B.F. G20 - G25 -(HBS3)) | 14d | 2020-06-17 | 2020-07-06 | 686 | 0d | BHS | INT/IS/GA | Blank | NA | Blank | NA |
| 1151 | 3.1.7.5 | VSR - Ligne BS1 (B.F. BS1) | 14d | 2020-05-20 | 2020-06-10 | 627 | 0d | BHS | INT/IS/GA | Blank | BS1 | Blank | NA |
| 1152 | 3.1.7.6 | VSR - banques G17, G20 (B.F. G20 - G25 -(HBS3); B.F. G10 - G15 - G17 - (HBS6)) | 14d | 2020-06-25 | 2020-07-14 | 714 | 0d | BHS | INT/IS/GA | Blank | NA | Blank | NA |
| 1153 | 3.1.7.7 | VSR - Ligne Depose C5 (B.F LIV n°5) | 14d | 2020-06-25 | 2020-07-14 | 705 | 0d | BHS | INT/IS/GA | Blank | C5 | Blank | NA |
| 1154 | 3.1.7.8 | VSR - Ligne Depose C4 (B.F LIV n°4) | 14d | 2020-11-04 | 2020-11-23 | 785 | 0d | BHS | INT/IS/GA | Blank | C4 | Blank | NA |
| 1155 | 3.1.7.9 | VSR - Ligne Depose Secteur France (B.F. LIV SF) | 14d | 2020-10-09 | 2020-10-28 | 805 | 0d | BHS | INT/IS/GA | Blank | Secteur France | Blank | NA |
| 1156 | 3.1.7.10 | VSR - Ligne Depose C3 (B.F LIV n°3) | 14d | 2020-11-04 | 2020-11-23 | 785 | 0d | BHS | INT/IS/GA | Blank | C3 | Blank | NA |
| 1157 | 3.1.7.11 | VSR - Ligne Depose C2 (B.F LIV n°2) | 14d | 2021-01-18 | 2021-02-04 | 832 | 0d | BHS | INT/IS/GA | Blank | C2 | Blank | NA |
| 1158 | 3.1.7.12 | VSR - Ligne Depose C1 (B.F LIV n°1) | 14d | 2021-01-19 | 2021-02-05 | 847 | 0d | BHS | INT/IS/GA | Blank | C1 | Blank | NA |
| 1159 | 3.1.7.13 | VSR - Depose et Ligne HBS2 (B.F. HF1 - HF2 -(HBS2); B.F. HBS2; B.F. MUP HF) | 60d | 2021-03-09 | 2021-06-04 | 892 | 0d | BHS | INT/IS/GA | Blank | HF2 | Blank | NA |
| 1160 | 3.1.7.14 | VSR - Trieur Nord, HBS3, HBS4 (B.F. TRI NORD + MUP; B.F. HBS3; B.F. HBS4; B.F. CONTRÔLE COMPLEMENTAIRE) | 60d | 2021-04-28 | 2021-07-22 | 902 | 0d | BHS | INT/IS/GA | Blank | NA | Blank | NA |
| 1161 | 3.1.7.15 | VSR - Depose HF 1 (B.F. HF1 - HF2 -(HBS2)) | 14d | 2021-03-09 | 2021-03-26 | 892 | 0d | BHS | INT/IS/GA | Blank | HF1 | Blank | NA |
| 1162 | 3.1.7.16 | VSR - Ligne Transfer 2 (B.F. Ligne AuF Tr2) | 14d | 2021-01-18 | 2021-02-04 | 832 | 0d | BHS | INT/IS/GA | Blank | TR2 | Blank | NA |
| 1163 | 3.1.7.17 | VSR - Ligne AuF HBS5 (B.F. HBS5) | 60d | 2021-10-14 | 2022-01-14 | 959 | 0d | BHS | INT/IS/GA | Blank | HBS5 | Blank | NA |
| 1164 | 3.1.7.18 | VSR - Depose HF 3 et Ligne HBS1 (B.F. HF3 - (HBS1); B.F HBS1) | 60d | 2021-07-08 | 2021-09-30 | 929 | 0d | BHS | INT/IS/GA | Blank | HF3 | Blank | NA |
| 1165 | 3.1.7.19 | VSR - Trieur Nord (tous MUP) | 14d | 2021-10-11 | 2021-10-28 | 967 | 0d | BHS | INT/IS/GA | Blank | NA | Blank | NA |
| 1166 | 3.1.7.20 | VSR - banques G55 (B.F G50 - G55 - (HBS4)) | 14d | 2021-10-14 | 2021-11-02 | 959 | 0d | BHS | INT/IS/GA | Blank | NA | Blank | NA |
| 1167 | 3.1.7.21 | VSR - banques G35 (B.F G30 - G35 - (HBS5)) | 14d | 2021-10-14 | 2021-11-02 | 959 | 0d | BHS | INT/IS/GA | Blank | NA | Blank | NA |
| 1168 | 3.1.7.22 | VSR - EBS vers Trieur Nord (B.F. EBS; B.F. CONNEXIONS) | 60d | 2021-09-08 | 2021-12-01 | 950 | 0d | BHS | INT/IS/GA | Blank | NA | Blank | NA |
| 1169 | 3.1.7.23 | VSR - Lignes HBS7 et HBS8 (B.F. HBS7; B.F. HBS8) | 60d | 2019-02-11 | 2019-05-07 |  | 0d | BHS | INT/IS/GA | Blank | HBS7;HBS8 | Blank | NA |
| 1170 | 3.1.7.24 | VSR- Lignes EBS vers Trieur Sud (B.F. Connexions) | 14d | 2022-03-03 | 2022-03-22 | 1010 | 0d | BHS | INT/IS/GA | Blank | NA | Blank | NA |
| 1171 | 3.1.7.25 | VSR - Trieur Sud et Ligne d'injection 1 (B.F. TRI SUD + MUP) | 60d | 2022-01-31 | 2022-04-26 | 996 | 0d | BHS | INT/IS/GA | Blank | NA | Blank | NA |
| 1172 | 3.1.7.26 | VSR - Ligne Transfer3 (B.F. Ligne AuF Tr3) | 14d | 2020-11-04 | 2020-11-23 | 785 | 0d | BHS | INT/IS/GA | Blank | TR3 | Blank | NA |
| 1173 | 3.1.7.27 | VSR - banques G40(B.F. G40 -(HBS7)) | 14d | 2022-06-08 | 2022-06-27 | 1041 | 0d | BHS | INT/IS/GA | Blank | NA | Blank | NA |
| 1174 | 3.1.7.28 | VSR - Ligne NV5000 et baques G60 (B.F. G60 - Secteur France - (HBS8)) | 14d | 2022-04-08 | 2022-04-29 | 1006 | 0d | BHS | INT/IS/GA | Blank | NA | Blank | NA |
| 1175 | 3.1.7.29 | VSR - Lignes HBS6 (B.F. HBS6) | 60d | 2021-10-14 | 2022-01-14 | 959 | 0d | BHS | INT/IS/GA | Blank | HBS6 | Blank | NA |
| 1176 | 3.1.7.30 | VSR - Ligne NV1000 et banques G50 (B.F G50 - G55 - (HBS4)) | 14d | 2022-05-19 | 2022-06-09 | 1036 | 0d | BHS | INT/IS/GA | Blank | NA | Blank | NA |
| 1177 | 3.1.7.31 | VSR - Ligne Transfer1 (B.F. Ligne AuF Tr1) | 14d | 2021-02-18 | 2021-03-09 | 874 | 0d | BHS | INT/IS/GA | Blank | TR1 | Blank | NA |
| 1178 | 3.1.7.32 | VSR - n.6 MUP | 14d | 2021-10-11 | 2021-10-28 | 968 | 0d | BHS | INT/IS/GA | Blank | NA | Blank | NA |
| 1179 | 3.1.7.33 | VSR - boucle de connexion T1+ | 14d | 2022-06-30 | 2022-07-19 | 1139 | 0d | BHS | INT/IS/GA | Blank | NA | Blank | NA |
| 1180 | 3.1.7.34 | VSR - Ligne NV0000 et banques G30 (B.F. G30 - G35 -(HBS5)) | 14d | 2022-06-08 | 2022-06-27 | 1042 | 0d | BHS | INT/IS/GA | Blank | NA | Blank | NA |
| 1181 | 3.1.7.35 | VSR - n.4 MUP trieur Sud | 14d | 2022-12-19 | 2023-01-13 | 1078 | 0d | BHS | INT/IS/GA | Blank | NA | Blank | NA |
| 1182 | 3.1.7.36 | VSR - injection 2 sur trieur Sud | 14d | 2022-12-15 | 2023-01-11 | 1067 | 0d | BHS | INT/IS/GA | Blank | NA | Blank | NA |
| 1183 | 3.1.7.37 | VSR - Ligne MCS (B.F. MCS) | 14d | 2022-10-17 | 2022-11-03 | 1070 | 0d | BHS | INT/IS/GA | Blank | NA | Blank | NA |
| 1184 | 3.1.7.38 | VSR - 2eme ligne de collecte et banques G10, G15 et dernieres 2 banques (B.F. G10 - G15 - G17) | 14d | 2023-03-21 | 2023-04-07 | 1104 | 0d | BHS | INT/IS/GA | Blank | NA | Blank | NA |
| 1185 | 3.1.7.39 | VSR - SYSTEME GLOBAL (et dernieres 2 banques) | 130d | 2023-04-10 | 2023-10-06 | 1184 | 0d | BHS | INT/IS/GA | Blank | NA | Blank | NA |

| ID | WBS | Task | Type | Duration | Start | Finish | Predecessors | Total slack | Free slack | Constraint | Text1 | Text12 | Text21 | Text26 | Text29 | Acteur |
| --- | --- | --- | --- | --- | --- | --- | --- | --- | --- | --- | --- | --- | --- | --- | --- | --- |
| 1186 | 3.2 | **Jalons principaux du programme** |  | 264d | 2022-05-02 | 2023-05-19 |  | 0d |  |  | BHS | Blank | NA | Blank | NA |  |
| 1187 | 3.2.1 | Tous les bagages traités avec EDS std3 | milestone | 0d | 2022-06-28 | 2022-06-28 | 1047, 1042, 1006, 987, 929, 925, 908, 892, 893, 959, 1036 | 0d |  |  | BHS | Blank | NA | Blank | NA |  |
| 1188 | 3.2.2 | OBJECTIF GA : Tous les bagages traités avec EDS std3 | milestone | 0d | 2022-05-02 | 2022-05-02 | 1047, 1042, 1006, 987, 929, 925, 908, 892, 893, 959 | -39d | 0d | must finish on 2022-05-02 | BHS | Blank | NA | Blank | NA |  |
| 1189 | 3.2.3 | Reception de tous les blocs fonctionnels | milestone | 0d | 2023-05-19 | 2023-05-19 | 1185SS+30d | 0d |  |  | BHS | Blank | NA | Blank | NA |  |
| 1190 | 3.3 | **Periode de Garantie** |  | 2328d | 2019-02-18 | 2028-03-22 |  | 0d |  |  | BHS | Blank | NA | Blank | NA |  |
| 1191 | 3.3.1 | **C1 -Enregistrement** |  | 2328d | 2019-02-18 | 2028-03-22 |  | 0d |  |  | BHS | Blank | NA | Blank |  |  |
| 1192 | 3.3.1.1 | **Bloc Fonctionnels** |  | 2328d | 2019-02-18 | 2028-03-22 |  | 0d |  |  | BHS | Blank | NA | Blank |  |  |
| 1193 | 3.3.1.1.1 | HF3 - (HBS1) |  | 1305d | 2021-07-12 | 2026-08-07 | 1123 | 0d |  |  | BHS | Blank | HF3 | Blank |  | INT |
| 1194 | 3.3.1.1.2 | HF1 - HF2 -(HBS2) |  | 1305d | 2021-03-12 | 2026-04-15 | 1120, 1118 | 0d |  |  | BHS | Blank | HF1;HF2 | Blank |  | INT |
| 1195 | 3.3.1.1.3 | Banques G20 - G25 -(HBS3) |  | 1305d | 2020-06-24 | 2025-08-08 | 1111, 1109 | 0d |  |  | BHS | Blank | NA | Blank |  | INT |
| 1196 | 3.3.1.1.4 | Banques G50 - G55 - (HBS4) |  | 1305d | 2022-05-23 | 2027-06-04 | 1125, 1135 | 0d |  |  | BHS | Blank | NA | Blank |  | INT |
| 1197 | 3.3.1.1.5 | Banques G30 - G35 -(HBS5) |  | 1305d | 2022-06-10 | 2027-06-22 | 1126, 1140 | 0d |  |  | BHS | Blank | NA | Blank |  | INT |
| 1198 | 3.3.1.1.6 | **Banques G10 - G15 - G17 - (HBS6)** |  | 2328d | 2019-02-18 | 2028-03-22 |  | 0d |  |  | BHS | Blank | NA | Blank |  |  |
| 1199 | 3.3.1.1.6.1 | Banques G17 - (HBS6) |  | 1305d | 2019-02-18 | 2024-04-19 | 1111 | 0d |  |  | BHS | Blank | NA | Blank |  | INT |
| 1200 | 3.3.1.1.6.2 | Banques G10 - G15 - (HBS6) |  | 1305d | 2023-03-23 | 2028-03-22 | 1145 | 0d |  |  | BHS | Blank | NA | Blank |  | INT |
| 1201 | 3.3.1.1.7 | Banques G40 - (HBS7) |  | 1305d | 2022-06-08 | 2027-06-18 | 1137 | 0d |  |  | BHS | Blank | NA | Blank |  | INT |
| 1202 | 3.3.1.1.8 | Banques G60 - Secteur France - (HBS8) |  | 1305d | 2022-04-12 | 2027-04-28 | 1133 | 0d |  |  | BHS | Blank | NA | Blank |  | INT |
| 1203 | 3.3.2 | **C2- Controle sureté** |  | 1456d | 2021-03-12 | 2026-11-12 |  | 0d |  |  | BHS | Blank | NA | Blank |  |  |
| 1204 | 3.3.2.1 | HBS1 |  | 1305d | 2021-07-12 | 2026-08-07 | 1123 | 0d |  |  | BHS | Blank | HBS1 | Blank |  | INT |
| 1205 | 3.3.2.2 | HBS2 |  | 1305d | 2021-03-12 | 2026-04-15 | 1118 | 0d |  |  | BHS | Blank | HBS2 | Blank |  | INT |
| 1206 | 3.3.2.3 | HBS3 |  | 1305d | 2021-05-20 | 2026-06-18 | 1119 | 0d |  |  | BHS | Blank | HBS3 | Blank |  | INT |
| 1207 | 3.3.2.4 | HBS4 |  | 1305d | 2021-05-20 | 2026-06-18 | 1119 | 0d |  |  | BHS | Blank | HBS4 | Blank |  | INT |
| 1208 | 3.3.2.5 | HBS5 |  | 1305d | 2021-10-18 | 2026-11-12 | 1122 | 0d |  |  | BHS | Blank | HBS5 | Blank |  | INT |
| 1209 | 3.3.2.6 | HBS6 |  | 1305d | 2021-10-18 | 2026-11-12 | 1134 | 0d |  |  | BHS | Blank | HBS6 | Blank |  | INT |
| 1210 | 3.3.2.7 | HBS7 |  | 1305d | 2021-07-29 | 2026-08-26 | 1129 | 0d |  |  | BHS | Blank | HBS7 | Blank |  | INT |
| 1211 | 3.3.2.8 | HBS8 |  | 1305d | 2021-07-29 | 2026-08-26 | 1129 | 0d |  |  | BHS | Blank | HBS8 | Blank |  | INT |

| ID | WBS | Task | Duration | Start | Finish | Predecessors | Total slack | Text1 | Text12 | Text26 | Acteur | Text21 |
| --- | --- | --- | --- | --- | --- | --- | --- | --- | --- | --- | --- | --- |
| 1212 | 3.3.3 | **C3 - Triage** | 1841d | 2020-10-23 | 2027-12-28 |  | 0d | BHS | Blank | Blank |  |  |
| 1213 | 3.3.3.1 | MUP HF | 1305d | 2021-03-12 | 2026-04-15 | 1118 | 0d | BHS | Blank | Blank | INT | NA |
| 1214 | 3.3.3.2 | TRIEUR NORD + MUP | 1305d | 2021-05-20 | 2026-06-18 | 1119 | 0d | BHS | Blank | Blank | INT | NA |
| 1215 | 3.3.3.3 | TRIEUR SUD + MUP | 1305d | 2022-02-14 | 2027-03-02 | 1131 | 0d | BHS | Blank | Blank | INT | NA |
| 1216 | 3.3.3.4 | MUP EST | 1305d | 2020-10-23 | 2025-12-08 | 1128 | 0d | BHS | Blank | Blank | INT | NA |
| 1217 | 3.3.3.5 | MUP OUEST | 1305d | 2020-11-20 | 2026-01-05 | 1142 | 0d | BHS | Blank | Blank | INT | NA |
| 1218 | 3.3.3.6 | MUP CENTRAUX | 1305d | 2022-12-20 | 2027-12-28 | 1138, 1141 | 0d | BHS | Blank | Blank | INT | NA |
| 1219 | 3.3.4 | **C4- EBS** | 1423d | 2021-09-08 | 2027-03-19 |  | 0d | BHS | Blank | Blank |  | NA |
| 1220 | 3.3.4.1 | CONNEXIONS | 1305d | 2022-03-03 | 2027-03-19 | 1130, 1127 | 0d | BHS | Blank | Blank | INT | NA |
| 1221 | 3.3.4.2 | EBS A | 1305d | 2021-09-08 | 2026-10-06 | 1127 | 0d | BHS | Blank | Blank | INT | NA |
| 1222 | 3.3.4.3 | EBS B | 1305d | 2021-09-08 | 2026-10-06 | 1127 | 0d | BHS | Blank | Blank | INT | NA |
| 1223 | 3.3.4.4 | EBS C | 1305d | 2021-09-08 | 2026-10-06 | 1127 | 0d | BHS | Blank | Blank | INT | NA |
| 1224 | 3.3.5 | **C5 - Arrivée** | 1578d | 2019-12-16 | 2026-02-24 |  | 0d | BHS | Blank | Blank |  | NA |
| 1225 | 3.3.5.1 | LIV HF ET SPECIAUX | 1305d | 2019-12-16 | 2025-02-06 | 1106 | 0d | BHS | Blank | Blank | INT | NA |
| 1226 | 3.3.5.2 | LIV SF | 1305d | 2020-10-13 | 2025-11-26 | 1114 | 0d | BHS | Blank | Blank | INT | NA |
| 1227 | 3.3.5.3 | Ligne Depose C1 | 1305d | 2021-01-21 | 2026-02-24 | 1117 | 0d | BHS | Blank | Blank | INT | NA |
| 1228 | 3.3.5.4 | Ligne Depose C2 | 1305d | 2021-01-20 | 2026-02-23 | 1116 | 0d | BHS | Blank | Blank | INT | NA |
| 1229 | 3.3.5.5 | Ligne Depose C3 | 1305d | 2020-11-06 | 2025-12-22 | 1115 | 0d | BHS | Blank | Blank | INT | NA |
| 1230 | 3.3.5.6 | Ligne Depose C4 | 1305d | 2020-11-06 | 2025-12-22 | 1113 | 0d | BHS | Blank | Blank | INT | NA |
| 1231 | 3.3.5.7 | Ligne Depose C5 | 1305d | 2020-06-29 | 2025-08-13 | 1112 | 0d | BHS | Blank | Blank | INT | NA |
| 1232 | 3.3.5.8 | Ligne Depose C6 | 1305d | 2020-04-28 | 2025-06-16 | 1108 | 0d | BHS | Blank | Blank | INT | NA |
| 1233 | 3.3.5.9 | Ligne Depose C7 | 1305d | 2020-01-22 | 2025-03-13 | 1107 | 0d | BHS | Blank | Blank | INT | NA |
